# Calendário do Projeto

Schedule from MS Project, 2021-08-02 to 2021-08-25, status date 2016-10-12, 8.8 hours a day, costs in R$.

## Calendars

- Curso Unichristus: Mon-Fri 07:00-12:00, 13:00-16:48; Sat-Sun off.

## Resources

| Resource |
| --- |
| carpinteiro |
| ferreiro |
| servente estrutura |
| aux. Carpinteiro |
| aux. ferreiro |
| enc. carpinteiro |
| enc. ferreiro |
| pedreiro alv. |
| servente alv. |
| gesseiro |
| aux. gesseiro |
| aplicador de manta |
| aux. aplicador |
| pedreiro acab. |
| servente acab. |
| pedreiro fac. |
| servente fac. |
| montador esquadrias |
| aux.Marceneiro |
| marceneiro |
| aux. eletricista |
| eletricista |
| pintor |
| aux. Pintor |
| aux. bombeiro |
| bombeiro |
| Diarista |
| mecânico |
| servente geral |
| pedreiro |
| servente |
| aux.pintor |

## Schedule

| ID | WBS | Task | Duration | Start | Finish | Total slack | Resources | Work | Cost | Casa | Pav | Equipe | Empresa | Pacote | Cor | LB |
| --- | --- | --- | --- | --- | --- | --- | --- | --- | --- | --- | --- | --- | --- | --- | --- | --- |
| 1 | 1 | **Curso PO CREA-CE 2023** | 18d? | 2021-08-02 | 2021-08-25 | 0d |  | 151078h | 8,801,080.51 |  |  |  |  |  |  |  |
| 2 | 1.1 | Custo Indireto | 1d? | 2021-08-02 | 2021-08-02 | 17d |  |  | 2,083,229.72 |  |  |  |  |  |  |  |
| 3 | 1.2 | Áreas Comuns | 1d? | 2021-08-02 | 2021-08-02 | 17d |  |  | 520,807.43 |  |  |  |  |  |  |  |
| 4 | 1.3 | **Obra Civil** | 18d? | 2021-08-02 | 2021-08-25 | 0d |  | 138688h | 5,044,249.44 |  |  |  |  |  |  |  |
| 5 | 1.3.1 | **1. Casa 1** | 18d? | 2021-08-02 | 2021-08-25 | 0d |  | 8668h | 315,265.59 |  |  |  |  |  |  |  |
| 6 | 1.3.1.1 | **0. Térreo** | 16d? | 2021-08-02 | 2021-08-23 | 2d |  | 4496.8h | 165,509.25 |  |  |  |  |  |  |  |
| 7 | 1.3.1.1.1 | 0. Locação | 2d | 2021-08-02 | 2021-08-03 | 16d | carpinteiro; aux. Carpinteiro | 35.2h | 456.99 | 1. Casa 1 | 0. Térreo | 0. Locação 1 | Própria |  |  |  |
| 8 | 1.3.1.1.2 | 1. Fundação | 9d | 2021-08-02 | 2021-08-12 | 9d | servente estrutura [300%]; aux. Carpinteiro; aux. ferreiro; ferreiro; carpinteiro [200%] | 633.6h | 19,882.86 | 1. Casa 1 | 0. Térreo | 1. Fundação 1 | Própria |  |  |  |
| 9 | 1.3.1.1.3 | 2. Estrutura | 7d | 2021-08-02 | 2021-08-10 | 11d | servente estrutura [300%]; aux. Carpinteiro [200%]; aux. ferreiro [200%]; ferreiro [500%]; carpinteiro [200%] | 862.4h | 46,439.03 | 1. Casa 1 | 0. Térreo | 2. Estrutura 1 | Própria |  |  |  |
| 10 | 1.3.1.1.4 | 3. Alvenarias | 10d | 2021-08-02 | 2021-08-13 | 8d | pedreiro [200%]; servente [200%] | 352h | 8,388.41 | 1. Casa 1 | 0. Térreo | 3. Alvenarias 1 | Própria |  |  |  |
| 11 | 1.3.1.1.5 | 5. Ref. Inter. Arg (Parede) | 16d | 2021-08-02 | 2021-08-23 | 2d | pedreiro [400%]; servente [400%] | 1126.4h | 5,776 | 1. Casa 1 | 0. Térreo | 5. Ref. Inter. Arg (Parede) 1 | Própria |  |  |  |
| 12 | 1.3.1.1.6 | 6. Revest. Gesso (Parede + Teto) | 5d | 2021-08-02 | 2021-08-06 | 13d | gesseiro [300%]; servente | 176h | 2,119.41 | 1. Casa 1 | 0. Térreo | 6. Revest. Gesso (Parede + Teto) 1 | Própria |  |  |  |
| 13 | 1.3.1.1.7 | 7. Impermeabilização | 2d | 2021-08-02 | 2021-08-03 | 16d | aplicador de manta | 17.6h | 3,288.15 | 1. Casa 1 | 0. Térreo | 7. Impermeabilização 1 | Própria |  |  |  |
| 14 | 1.3.1.1.8 | 8. Contrapiso | 2d | 2021-08-02 | 2021-08-03 | 16d | pedreiro [200%]; servente | 52.8h | 3,735.07 | 1. Casa 1 | 0. Térreo | 8. Contrapiso 1 | Própria |  |  |  |
| 15 | 1.3.1.1.9 | 9. Fachada | 1d? | 2021-08-02 | 2021-08-02 | 17d |  |  |  | 1. Casa 1 | 0. Térreo | 9. Fachada 1 | Própria |  |  |  |
| 16 | 1.3.1.1.10 | 9.1. Chapisco | 0.5d | 2021-08-02 | 2021-08-02 | 17.5d | pedreiro [600%]; servente [400%] | 44h | 5,131.51 | 1. Casa 1 | 0. Térreo | 9. Fachada 1 | Própria |  |  |  |
| 17 | 1.3.1.1.11 | 9.2. Emboço | 1.5d | 2021-08-02 | 2021-08-03 | 16.5d | pedreiro [600%]; servente [400%] | 132h | 7,697.26 | 1. Casa 1 | 0. Térreo | 9. Fachada 1 | Própria |  |  |  |
| 18 | 1.3.1.1.12 | 9.3. Pint. 1 Demão | 1d | 2021-08-02 | 2021-08-02 | 17d | pintor [400%]; aux.pintor [200%] | 52.8h | 1,135.92 | 1. Casa 1 | 0. Térreo | 9. Fachada 1 | Própria |  |  |  |
| 19 | 1.3.1.1.13 | 9.4. Pint. 2 Demão | 2d | 2021-08-02 | 2021-08-03 | 16d | pintor [400%]; aux.pintor [200%] | 105.6h | 757.28 | 1. Casa 1 | 0. Térreo | 9. Fachada 1 | Própria |  |  |  |
| 20 | 1.3.1.1.14 | 10. Cer. Piso | 7d | 2021-08-02 | 2021-08-10 | 11d | pedreiro [200%]; servente | 184.8h | 25,485.98 | 1. Casa 1 | 0. Térreo | 10. Cer. Piso 1 | Própria | 10 | 10 | 10 |
| 21 | 1.3.1.1.15 | 11. Cer. Parede | 3d | 2021-08-02 | 2021-08-04 | 15d | pedreiro [200%]; servente | 79.2h | 4,238.82 | 1. Casa 1 | 0. Térreo | 11. Cer. Parede 1 | Própria | 11 | 11 | 11 |
| 22 | 1.3.1.1.16 | 12. Forro (WC's e cozinha) | 1d | 2021-08-02 | 2021-08-02 | 17d | gesseiro; servente | 17.6h | 635.82 | 1. Casa 1 | 0. Térreo | 12. Forro (WC's e cozinha) 1 | Própria | 12 | 12 | 12 |
| 23 | 1.3.1.1.17 | 13. Esq. Alumínio | 1d | 2021-08-02 | 2021-08-02 | 17d | montador esquadrias [200%] | 17.6h | 11,307.22 | 1. Casa 1 | 0. Térreo | 13. Esq. Alumínio 1 | Própria | 13 | 13 | 13 |
| 24 | 1.3.1.1.18 | 14. Portas | 2d | 2021-08-02 | 2021-08-03 | 16d | marceneiro [200%] | 35.2h | 2,827.85 | 1. Casa 1 | 0. Térreo | 14. Portas 1 | Própria | 14 | 14 | 14 |
| 25 | 1.3.1.1.19 | 15. Pintura (1ª Demão) | 6d | 2021-08-02 | 2021-08-09 | 12d | pintor [400%]; aux.pintor [200%] | 316.8h | 3,764.82 | 1. Casa 1 | 0. Térreo | 15. Pintura (1ª Demão) 1 | Própria | 15 | 15 | 15 |
| 26 | 1.3.1.1.20 | 16. Bancadas | 1d | 2021-08-02 | 2021-08-02 | 17d | pedreiro [200%]; servente | 26.4h | 10,458.12 | 1. Casa 1 | 0. Térreo | 16. Bancadas 1 | Própria | 16 | 16 | 16 |
| 27 | 1.3.1.1.21 | 17. Pintura (2ª Demão) | 4d | 2021-08-02 | 2021-08-05 | 14d | pintor [400%]; aux.pintor [200%] | 211.2h | 1,563.98 | 1. Casa 1 | 0. Térreo | 17. Pintura (2ª Demão) 1 | Própria | 17 | 17 | 17 |
| 28 | 1.3.1.1.22 | 18. Limp. Interna | 1d | 2021-08-02 | 2021-08-02 | 17d | Diarista [200%] | 17.6h | 418.75 | 1. Casa 1 | 0. Térreo | 18. Limp. Interna 1 | Própria | 18 | 18 | 18 |

| ID | WBS | Task | Duration | Start | Finish | Total slack | Resources | Work | Cost | Casa | Pav | Equipe | Empresa | Pacote | Cor | LB |
| --- | --- | --- | --- | --- | --- | --- | --- | --- | --- | --- | --- | --- | --- | --- | --- | --- |
| 29 | 1.3.1.2 | **1. Pav. Superior** | 18d? | 2021-08-02 | 2021-08-25 | 0d |  | 3634.4h | 114,461.15 |  |  |  |  |  |  |  |
| 30 | 1.3.1.2.1 | 2. Estrutura | 7d | 2021-08-02 | 2021-08-10 | 11d |  |  |  | 1. Casa 1 | 1. Pav. Superior |  |  |  |  |  |
| 31 | 1.3.1.2.2 | 3. Alvenarias | 10d | 2021-08-02 | 2021-08-13 | 8d | servente estrutura [300%]; aux. Carpinteiro [200%]; aux. ferreiro [200%]; ferreiro [500%]; carpinteiro [200%] | 1232h | 30,006.55 | 1. Casa 1 | 1. Pav. Superior | 2. Estrutura 1 | Própria |  |  |  |
| 32 | 1.3.1.2.3 | 5. Ref. Inter. Arg (Parede) | 18d | 2021-08-02 | 2021-08-25 | 0d | pedreiro [200%]; servente [200%] | 633.6h | 10,101.74 | 1. Casa 1 | 1. Pav. Superior | 3. Alvenarias 1 | Própria |  |  |  |
| 33 | 1.3.1.2.4 | 6. Revest. Gesso (Parede + Teto) | 7d | 2021-08-02 | 2021-08-10 | 11d | pedreiro [400%]; servente [400%] | 492.8h | 5,398.69 | 1. Casa 1 | 1. Pav. Superior | 5. Ref. Inter. Arg (Parede) 1 | Própria |  |  |  |
| 34 | 1.3.1.2.5 | 7. Impermeabilização | 1d | 2021-08-02 | 2021-08-02 | 17d | gesseiro [300%]; servente | 35.2h | 2,119.41 | 1. Casa 1 | 1. Pav. Superior | 6. Revest. Gesso (Parede + Teto) 1 | Própria |  |  |  |
| 35 | 1.3.1.2.6 | 8. Contrapiso | 2d | 2021-08-02 | 2021-08-03 | 16d | aplicador de manta | 17.6h | 2,046.85 | 1. Casa 1 | 1. Pav. Superior | 7. Impermeabilização 1 | Própria |  |  |  |
| 36 | 1.3.1.2.7 | 9. Fachada | 1d? | 2021-08-02 | 2021-08-02 | 17d | pedreiro [200%]; servente | 26.4h | 2,476.11 | 1. Casa 1 | 1. Pav. Superior | 8. Contrapiso 1 | Própria |  |  |  |
| 37 | 1.3.1.2.8 | 9.1. Chapisco | 0.5d | 2021-08-02 | 2021-08-02 | 17.5d |  |  |  | 1. Casa 1 | 1. Pav. Superior | 9. Fachada 1 | Própria |  |  |  |
| 38 | 1.3.1.2.9 | 9.2. Emboço | 1.5d | 2021-08-02 | 2021-08-03 | 16.5d | pedreiro [600%]; servente [400%] | 132h | 5,131.51 | 1. Casa 1 | 1. Pav. Superior | 9. Fachada 1 | Própria |  |  |  |
| 39 | 1.3.1.2.10 | 9.3. Pint. 1 Demão | 1d | 2021-08-02 | 2021-08-02 | 17d | pedreiro [600%]; servente [400%] | 88h | 7,697.26 | 1. Casa 1 | 1. Pav. Superior | 9. Fachada 1 | Própria |  |  |  |
| 40 | 1.3.1.2.11 | 9.4. Pint. 2 Demão | 2d | 2021-08-02 | 2021-08-03 | 16d | pintor [400%]; aux.pintor [200%] | 105.6h | 1,135.92 | 1. Casa 1 | 1. Pav. Superior | 9. Fachada 1 | Própria |  |  |  |
| 41 | 1.3.1.2.12 | 10. Cer. Piso | 8d | 2021-08-02 | 2021-08-11 | 10d | pintor [400%]; aux.pintor [200%] | 422.4h | 757.28 | 1. Casa 1 | 1. Pav. Superior | 9. Fachada 1 | Própria |  |  |  |
| 42 | 1.3.1.2.13 | 11. Cer. Parede | 2d | 2021-08-02 | 2021-08-03 | 16d | pedreiro [200%]; servente | 52.8h | 19,807.17 | 1. Casa 1 | 1. Pav. Superior | 10. Cer. Piso 1 | Própria | 10 | 10 | 10 |
| 43 | 1.3.1.2.14 | 12. Forro (WC's e cozinha) | 1d | 2021-08-02 | 2021-08-02 | 17d | pedreiro [200%]; servente | 26.4h | 4,238.82 | 1. Casa 1 | 1. Pav. Superior | 11. Cer. Parede 1 | Própria | 11 | 11 | 11 |
| 44 | 1.3.1.2.15 | 13. Esq. Alumínio | 1d | 2021-08-02 | 2021-08-02 | 17d | gesseiro; servente | 17.6h | 895 | 1. Casa 1 | 1. Pav. Superior | 12. Forro (WC's e cozinha) 1 | Própria | 12 | 12 | 12 |
| 45 | 1.3.1.2.16 | 14. Portas | 2d | 2021-08-02 | 2021-08-03 | 16d | montador esquadrias [200%] | 35.2h | 8,489.61 | 1. Casa 1 | 1. Pav. Superior | 13. Esq. Alumínio 1 | Própria | 13 | 13 | 13 |
| 46 | 1.3.1.2.17 | 15. Pintura (1ª Demão) | 6d | 2021-08-02 | 2021-08-09 | 12d | marceneiro [200%] | 105.6h | 1,858.35 | 1. Casa 1 | 1. Pav. Superior | 14. Portas 1 | Própria | 14 | 14 | 14 |
| 47 | 1.3.1.2.18 | 16. Bancadas | 1d | 2021-08-02 | 2021-08-02 | 17d | pintor [400%]; aux.pintor [200%] | 52.8h | 3,764.82 | 1. Casa 1 | 1. Pav. Superior | 15. Pintura (1ª Demão) 1 | Própria | 15 | 15 | 15 |
| 48 | 1.3.1.2.19 | 17. Pintura (2ª Demão) | 4d | 2021-08-02 | 2021-08-05 | 14d | pedreiro [200%]; servente | 105.6h | 6,972.08 | 1. Casa 1 | 1. Pav. Superior | 16. Bancadas 1 | Própria | 16 | 16 | 16 |
| 49 | 1.3.1.2.20 | 18. Limp. Interna | 1d | 2021-08-02 | 2021-08-02 | 17d | pintor [400%]; aux.pintor [200%] | 52.8h | 1,563.98 | 1. Casa 1 | 1. Pav. Superior | 17. Pintura (2ª Demão) 1 | Própria | 17 | 17 | 17 |
| 50 | 1.3.1.3 | **2. Coberta** | 6d | 2021-08-02 | 2021-08-09 | 12d |  | 536.8h | 35,295.19 |  |  |  |  |  |  |  |
| 51 | 1.3.1.3.1 | 1. Alvenarias | 6d | 2021-08-02 | 2021-08-09 | 12d | pedreiro [200%]; servente [200%] | 211.2h | 9,834.12 | 1. Casa 1 | 2. Coberta | 3. Alvenarias 1 | Própria |  |  |  |
| 52 | 1.3.1.3.2 | 2. Impermeabilização | 1d | 2021-08-02 | 2021-08-02 | 17d | aplicador de manta | 8.8h | 1,296.54 | 1. Casa 1 | 2. Coberta | 7. Impermeabilização 1 | Própria |  |  |  |
| 53 | 1.3.1.3.3 | 3. Coberta | 6d | 2021-08-02 | 2021-08-09 | 12d | carpinteiro [400%]; aux. Carpinteiro [200%] | 316.8h | 24,164.53 | 1. Casa 1 | 2. Coberta | 4. Coberta 1 | Própria |  |  |  |

| ID | WBS | Task | Duration | Start | Finish | Total slack | Resources | Work | Cost | Casa | Pav | Equipe | Empresa | Pacote | Cor | LB |
| --- | --- | --- | --- | --- | --- | --- | --- | --- | --- | --- | --- | --- | --- | --- | --- | --- |
| 54 | 1.3.2 | **2. Casa 2** | 18d? | 2021-08-02 | 2021-08-25 | 0d |  | 8668h | 315,265.59 |  |  |  |  |  |  |  |
| 55 | 1.3.2.1 | **0. Térreo** | 16d? | 2021-08-02 | 2021-08-23 | 2d |  | 4496.8h | 165,509.25 |  |  |  |  |  |  |  |
| 56 | 1.3.2.1.1 | 0. Locação | 2d | 2021-08-02 | 2021-08-03 | 16d | carpinteiro; aux. Carpinteiro | 35.2h | 456.99 | 2. Casa 2 | 0. Térreo | 0. Locação 1 | Própria |  |  |  |
| 57 | 1.3.2.1.2 | 1. Fundação | 9d | 2021-08-02 | 2021-08-12 | 9d | servente estrutura [300%]; aux. Carpinteiro; aux. ferreiro; ferreiro; carpinteiro [200%] | 633.6h | 19,882.86 | 2. Casa 2 | 0. Térreo | 1. Fundação 1 | Própria |  |  |  |
| 58 | 1.3.2.1.3 | 2. Estrutura | 7d | 2021-08-02 | 2021-08-10 | 11d | servente estrutura [300%]; aux. Carpinteiro [200%]; aux. ferreiro [200%]; ferreiro [500%]; carpinteiro [200%] | 862.4h | 46,439.03 | 2. Casa 2 | 0. Térreo | 2. Estrutura 1 | Própria |  |  |  |
| 59 | 1.3.2.1.4 | 3. Alvenarias | 10d | 2021-08-02 | 2021-08-13 | 8d | pedreiro [200%]; servente [200%] | 352h | 8,388.41 | 2. Casa 2 | 0. Térreo | 3. Alvenarias 1 | Própria |  |  |  |
| 60 | 1.3.2.1.5 | 5. Ref. Inter. Arg (Parede) | 16d | 2021-08-02 | 2021-08-23 | 2d | pedreiro [400%]; servente [400%] | 1126.4h | 5,776 | 2. Casa 2 | 0. Térreo | 5. Ref. Inter. Arg (Parede) 1 | Própria |  |  |  |
| 61 | 1.3.2.1.6 | 6. Revest. Gesso (Parede + Teto) | 5d | 2021-08-02 | 2021-08-06 | 13d | gesseiro [300%]; servente | 176h | 2,119.41 | 2. Casa 2 | 0. Térreo | 6. Revest. Gesso (Parede + Teto) 1 | Própria |  |  |  |
| 62 | 1.3.2.1.7 | 7. Impermeabilização | 2d | 2021-08-02 | 2021-08-03 | 16d | aplicador de manta | 17.6h | 3,288.15 | 2. Casa 2 | 0. Térreo | 7. Impermeabilização 1 | Própria |  |  |  |
| 63 | 1.3.2.1.8 | 8. Contrapiso | 2d | 2021-08-02 | 2021-08-03 | 16d | pedreiro [200%]; servente | 52.8h | 3,735.07 | 2. Casa 2 | 0. Térreo | 8. Contrapiso 1 | Própria |  |  |  |
| 64 | 1.3.2.1.9 | 9. Fachada | 1d? | 2021-08-02 | 2021-08-02 | 17d |  |  |  | 2. Casa 2 | 0. Térreo | 9. Fachada 1 | Própria |  |  |  |
| 65 | 1.3.2.1.10 | 9.1. Chapisco | 0.5d | 2021-08-02 | 2021-08-02 | 17.5d | pedreiro [600%]; servente [400%] | 44h | 5,131.51 | 2. Casa 2 | 0. Térreo | 9. Fachada 1 | Própria |  |  |  |
| 66 | 1.3.2.1.11 | 9.2. Emboço | 1.5d | 2021-08-02 | 2021-08-03 | 16.5d | pedreiro [600%]; servente [400%] | 132h | 7,697.26 | 2. Casa 2 | 0. Térreo | 9. Fachada 1 | Própria |  |  |  |
| 67 | 1.3.2.1.12 | 9.3. Pint. 1 Demão | 1d | 2021-08-02 | 2021-08-02 | 17d | pintor [400%]; aux.pintor [200%] | 52.8h | 1,135.92 | 2. Casa 2 | 0. Térreo | 9. Fachada 1 | Própria |  |  |  |
| 68 | 1.3.2.1.13 | 9.4. Pint. 2 Demão | 2d | 2021-08-02 | 2021-08-03 | 16d | pintor [400%]; aux.pintor [200%] | 105.6h | 757.28 | 2. Casa 2 | 0. Térreo | 9. Fachada 1 | Própria |  |  |  |
| 69 | 1.3.2.1.14 | 10. Cer. Piso | 7d | 2021-08-02 | 2021-08-10 | 11d | pedreiro [200%]; servente | 184.8h | 25,485.98 | 2. Casa 2 | 0. Térreo | 10. Cer. Piso 1 | Própria | 10 | 10 | 10 |
| 70 | 1.3.2.1.15 | 11. Cer. Parede | 3d | 2021-08-02 | 2021-08-04 | 15d | pedreiro [200%]; servente | 79.2h | 4,238.82 | 2. Casa 2 | 0. Térreo | 11. Cer. Parede 1 | Própria | 11 | 11 | 11 |
| 71 | 1.3.2.1.16 | 12. Forro (WC's e cozinha) | 1d | 2021-08-02 | 2021-08-02 | 17d | gesseiro; servente | 17.6h | 635.82 | 2. Casa 2 | 0. Térreo | 12. Forro (WC's e cozinha) 1 | Própria | 12 | 12 | 12 |
| 72 | 1.3.2.1.17 | 13. Esq. Alumínio | 1d | 2021-08-02 | 2021-08-02 | 17d | montador esquadrias [200%] | 17.6h | 11,307.22 | 2. Casa 2 | 0. Térreo | 13. Esq. Alumínio 1 | Própria | 13 | 13 | 13 |
| 73 | 1.3.2.1.18 | 14. Portas | 2d | 2021-08-02 | 2021-08-03 | 16d | marceneiro [200%] | 35.2h | 2,827.85 | 2. Casa 2 | 0. Térreo | 14. Portas 1 | Própria | 14 | 14 | 14 |
| 74 | 1.3.2.1.19 | 15. Pintura (1ª Demão) | 6d | 2021-08-02 | 2021-08-09 | 12d | pintor [400%]; aux.pintor [200%] | 316.8h | 3,764.82 | 2. Casa 2 | 0. Térreo | 15. Pintura (1ª Demão) 1 | Própria | 15 | 15 | 15 |
| 75 | 1.3.2.1.20 | 16. Bancadas | 1d | 2021-08-02 | 2021-08-02 | 17d | pedreiro [200%]; servente | 26.4h | 10,458.12 | 2. Casa 2 | 0. Térreo | 16. Bancadas 1 | Própria | 16 | 16 | 16 |
| 76 | 1.3.2.1.21 | 17. Pintura (2ª Demão) | 4d | 2021-08-02 | 2021-08-05 | 14d | pintor [400%]; aux.pintor [200%] | 211.2h | 1,563.98 | 2. Casa 2 | 0. Térreo | 17. Pintura (2ª Demão) 1 | Própria | 17 | 17 | 17 |
| 77 | 1.3.2.1.22 | 18. Limp. Interna | 1d | 2021-08-02 | 2021-08-02 | 17d | Diarista [200%] | 17.6h | 418.75 | 2. Casa 2 | 0. Térreo | 18. Limp. Interna 1 | Própria | 18 | 18 | 18 |

| ID | WBS | Task | Duration | Start | Finish | Total slack | Resources | Work | Cost | Casa | Pav | Equipe | Empresa | Pacote | Cor | LB |
| --- | --- | --- | --- | --- | --- | --- | --- | --- | --- | --- | --- | --- | --- | --- | --- | --- |
| 78 | 1.3.2.2 | **1. Pav. Superior** | 18d? | 2021-08-02 | 2021-08-25 | 0d |  | 3634.4h | 114,461.15 |  |  |  |  |  |  |  |
| 79 | 1.3.2.2.1 | 2. Estrutura | 7d | 2021-08-02 | 2021-08-10 | 11d |  |  |  | 2. Casa 2 |  |  |  |  |  |  |
| 80 | 1.3.2.2.2 | 3. Alvenarias | 10d | 2021-08-02 | 2021-08-13 | 8d | servente estrutura [300%]; aux. Carpinteiro [200%]; aux. ferreiro [200%]; ferreiro [500%]; carpinteiro [200%] | 1232h | 30,006.55 | 2. Casa 2 | 1. Pav. Superior | 2. Estrutura 1 | Própria |  |  |  |
| 81 | 1.3.2.2.3 | 5. Ref. Inter. Arg (Parede) | 18d | 2021-08-02 | 2021-08-25 | 0d | pedreiro [200%]; servente [200%] | 633.6h | 10,101.74 | 2. Casa 2 | 1. Pav. Superior | 3. Alvenarias 1 | Própria |  |  |  |
| 82 | 1.3.2.2.4 | 6. Revest. Gesso (Parede + Teto) | 7d | 2021-08-02 | 2021-08-10 | 11d | pedreiro [400%]; servente [400%] | 492.8h | 5,398.69 | 2. Casa 2 | 1. Pav. Superior | 5. Ref. Inter. Arg (Parede) 1 | Própria |  |  |  |
| 83 | 1.3.2.2.5 | 7. Impermeabilização | 1d | 2021-08-02 | 2021-08-02 | 17d | gesseiro [300%]; servente | 35.2h | 2,119.41 | 2. Casa 2 | 1. Pav. Superior | 6. Revest. Gesso (Parede + Teto) 1 | Própria |  |  |  |
| 84 | 1.3.2.2.6 | 8. Contrapiso | 2d | 2021-08-02 | 2021-08-03 | 16d | aplicador de manta | 17.6h | 2,046.85 | 2. Casa 2 | 1. Pav. Superior | 7. Impermeabilização 1 | Própria |  |  |  |
| 85 | 1.3.2.2.7 | 9. Fachada | 1d? | 2021-08-02 | 2021-08-02 | 17d | pedreiro [200%]; servente | 26.4h | 2,476.11 | 2. Casa 2 | 1. Pav. Superior | 8. Contrapiso 1 | Própria |  |  |  |
| 86 | 1.3.2.2.8 | 9.1. Chapisco | 0.5d | 2021-08-02 | 2021-08-02 | 17.5d |  |  |  | 2. Casa 2 | 1. Pav. Superior | 9. Fachada 1 | Própria |  |  |  |
| 87 | 1.3.2.2.9 | 9.2. Emboço | 1.5d | 2021-08-02 | 2021-08-03 | 16.5d | pedreiro [600%]; servente [400%] | 132h | 5,131.51 | 2. Casa 2 | 1. Pav. Superior | 9. Fachada 1 | Própria |  |  |  |
| 88 | 1.3.2.2.10 | 9.3. Pint. 1 Demão | 1d | 2021-08-02 | 2021-08-02 | 17d | pedreiro [600%]; servente [400%] | 88h | 7,697.26 | 2. Casa 2 | 1. Pav. Superior | 9. Fachada 1 | Própria |  |  |  |
| 89 | 1.3.2.2.11 | 9.4. Pint. 2 Demão | 2d | 2021-08-02 | 2021-08-03 | 16d | pintor [400%]; aux.pintor [200%] | 105.6h | 1,135.92 | 2. Casa 2 | 1. Pav. Superior | 9. Fachada 1 | Própria |  |  |  |
| 90 | 1.3.2.2.12 | 10. Cer. Piso | 8d | 2021-08-02 | 2021-08-11 | 10d | pintor [400%]; aux.pintor [200%] | 422.4h | 757.28 | 2. Casa 2 | 1. Pav. Superior | 9. Fachada 1 | Própria |  |  |  |
| 91 | 1.3.2.2.13 | 11. Cer. Parede | 2d | 2021-08-02 | 2021-08-03 | 16d | pedreiro [200%]; servente | 52.8h | 19,807.17 | 2. Casa 2 | 1. Pav. Superior | 10. Cer. Piso 1 | Própria | 10 | 10 | 10 |
| 92 | 1.3.2.2.14 | 12. Forro (WC's e cozinha) | 1d | 2021-08-02 | 2021-08-02 | 17d | pedreiro [200%]; servente | 26.4h | 4,238.82 | 2. Casa 2 | 1. Pav. Superior | 11. Cer. Parede 1 | Própria | 11 | 11 | 11 |
| 93 | 1.3.2.2.15 | 13. Esq. Alumínio | 1d | 2021-08-02 | 2021-08-02 | 17d | gesseiro; servente | 17.6h | 895 | 2. Casa 2 | 1. Pav. Superior | 12. Forro (WC's e cozinha) 1 | Própria | 12 | 12 | 12 |
| 94 | 1.3.2.2.16 | 14. Portas | 2d | 2021-08-02 | 2021-08-03 | 16d | montador esquadrias [200%] | 35.2h | 8,489.61 | 2. Casa 2 | 1. Pav. Superior | 13. Esq. Alumínio 1 | Própria | 13 | 13 | 13 |
| 95 | 1.3.2.2.17 | 15. Pintura (1ª Demão) | 6d | 2021-08-02 | 2021-08-09 | 12d | marceneiro [200%] | 105.6h | 1,858.35 | 2. Casa 2 | 1. Pav. Superior | 14. Portas 1 | Própria | 14 | 14 | 14 |
| 96 | 1.3.2.2.18 | 16. Bancadas | 1d | 2021-08-02 | 2021-08-02 | 17d | pintor [400%]; aux.pintor [200%] | 52.8h | 3,764.82 | 2. Casa 2 | 1. Pav. Superior | 15. Pintura (1ª Demão) 1 | Própria | 15 | 15 | 15 |
| 97 | 1.3.2.2.19 | 17. Pintura (2ª Demão) | 4d | 2021-08-02 | 2021-08-05 | 14d | pedreiro [200%]; servente | 105.6h | 6,972.08 | 2. Casa 2 | 1. Pav. Superior | 16. Bancadas 1 | Própria | 16 | 16 | 16 |
| 98 | 1.3.2.2.20 | 18. Limp. Interna | 1d | 2021-08-02 | 2021-08-02 | 17d | pintor [400%]; aux.pintor [200%] | 52.8h | 1,563.98 | 2. Casa 2 | 1. Pav. Superior | 17. Pintura (2ª Demão) 1 | Própria | 17 | 17 | 17 |
| 99 | 1.3.2.3 | **2. Coberta** | 6d | 2021-08-02 | 2021-08-09 | 12d |  | 536.8h | 35,295.19 |  |  |  |  |  |  |  |
| 100 | 1.3.2.3.1 | 1. Alvenarias | 6d | 2021-08-02 | 2021-08-09 | 12d | pedreiro [200%]; servente [200%] | 211.2h | 9,834.12 | 2. Casa 2 | 2. Coberta | 3. Alvenarias 1 | Própria |  |  |  |
| 101 | 1.3.2.3.2 | 2. Impermeabilização | 1d | 2021-08-02 | 2021-08-02 | 17d | aplicador de manta | 8.8h | 1,296.54 | 2. Casa 2 | 2. Coberta | 7. Impermeabilização 1 | Própria |  |  |  |
| 102 | 1.3.2.3.3 | 3. Coberta | 6d | 2021-08-02 | 2021-08-09 | 12d | carpinteiro [400%]; aux. Carpinteiro [200%] | 316.8h | 24,164.53 | 2. Casa 2 | 2. Coberta | 4. Coberta 1 | Própria |  |  |  |

| ID | WBS | Task | Duration | Start | Finish | Total slack | Resources | Work | Cost | Casa | Pav | Equipe | Empresa | Pacote | Cor | LB |
| --- | --- | --- | --- | --- | --- | --- | --- | --- | --- | --- | --- | --- | --- | --- | --- | --- |
| 103 | 1.3.3 | **3. Casa 3** | 18d? | 2021-08-02 | 2021-08-25 | 0d |  | 8668h | 315,265.59 |  |  |  |  |  |  |  |
| 104 | 1.3.3.1 | **0. Térreo** | 16d? | 2021-08-02 | 2021-08-23 | 2d |  | 4496.8h | 165,509.25 |  |  |  |  |  |  |  |
| 105 | 1.3.3.1.1 | 0. Locação | 2d | 2021-08-02 | 2021-08-03 | 16d | carpinteiro; aux. Carpinteiro | 35.2h | 456.99 | 3. Casa 3 | 0. Térreo | 0. Locação 1 | Própria |  |  |  |
| 106 | 1.3.3.1.2 | 1. Fundação | 9d | 2021-08-02 | 2021-08-12 | 9d | servente estrutura [300%]; aux. Carpinteiro; aux. ferreiro; ferreiro; carpinteiro [200%] | 633.6h | 19,882.86 | 3. Casa 3 | 0. Térreo | 1. Fundação 1 | Própria |  |  |  |
| 107 | 1.3.3.1.3 | 2. Estrutura | 7d | 2021-08-02 | 2021-08-10 | 11d | servente estrutura [300%]; aux. Carpinteiro [200%]; aux. ferreiro [200%]; ferreiro [500%]; carpinteiro [200%] | 862.4h | 46,439.03 | 3. Casa 3 | 0. Térreo | 2. Estrutura 1 | Própria |  |  |  |
| 108 | 1.3.3.1.4 | 3. Alvenarias | 10d | 2021-08-02 | 2021-08-13 | 8d | pedreiro [200%]; servente [200%] | 352h | 8,388.41 | 3. Casa 3 | 0. Térreo | 3. Alvenarias 1 | Própria |  |  |  |
| 109 | 1.3.3.1.5 | 5. Ref. Inter. Arg (Parede) | 16d | 2021-08-02 | 2021-08-23 | 2d | pedreiro [400%]; servente [400%] | 1126.4h | 5,776 | 3. Casa 3 | 0. Térreo | 5. Ref. Inter. Arg (Parede) 1 | Própria |  |  |  |
| 110 | 1.3.3.1.6 | 6. Revest. Gesso (Parede + Teto) | 5d | 2021-08-02 | 2021-08-06 | 13d | gesseiro [300%]; servente | 176h | 2,119.41 | 3. Casa 3 | 0. Térreo | 6. Revest. Gesso (Parede + Teto) 1 | Própria |  |  |  |
| 111 | 1.3.3.1.7 | 7. Impermeabilização | 2d | 2021-08-02 | 2021-08-03 | 16d | aplicador de manta | 17.6h | 3,288.15 | 3. Casa 3 | 0. Térreo | 7. Impermeabilização 1 | Própria |  |  |  |
| 112 | 1.3.3.1.8 | 8. Contrapiso | 2d | 2021-08-02 | 2021-08-03 | 16d | pedreiro [200%]; servente | 52.8h | 3,735.07 | 3. Casa 3 | 0. Térreo | 8. Contrapiso 1 | Própria |  |  |  |
| 113 | 1.3.3.1.9 | 9. Fachada | 1d? | 2021-08-02 | 2021-08-02 | 17d |  |  |  | 3. Casa 3 | 0. Térreo | 9. Fachada 1 | Própria |  |  |  |
| 114 | 1.3.3.1.10 | 9.1. Chapisco | 0.5d | 2021-08-02 | 2021-08-02 | 17.5d | pedreiro [600%]; servente [400%] | 44h | 5,131.51 | 3. Casa 3 | 0. Térreo | 9. Fachada 1 | Própria |  |  |  |
| 115 | 1.3.3.1.11 | 9.2. Emboço | 1.5d | 2021-08-02 | 2021-08-03 | 16.5d | pedreiro [600%]; servente [400%] | 132h | 7,697.26 | 3. Casa 3 | 0. Térreo | 9. Fachada 1 | Própria |  |  |  |
| 116 | 1.3.3.1.12 | 9.3. Pint. 1 Demão | 1d | 2021-08-02 | 2021-08-02 | 17d | pintor [400%]; aux.pintor [200%] | 52.8h | 1,135.92 | 3. Casa 3 | 0. Térreo | 9. Fachada 1 | Própria |  |  |  |
| 117 | 1.3.3.1.13 | 9.4. Pint. 2 Demão | 2d | 2021-08-02 | 2021-08-03 | 16d | pintor [400%]; aux.pintor [200%] | 105.6h | 757.28 | 3. Casa 3 | 0. Térreo | 9. Fachada 1 | Própria |  |  |  |
| 118 | 1.3.3.1.14 | 10. Cer. Piso | 7d | 2021-08-02 | 2021-08-10 | 11d | pedreiro [200%]; servente | 184.8h | 25,485.98 | 3. Casa 3 | 0. Térreo | 10. Cer. Piso 1 | Própria | 10 | 10 | 10 |
| 119 | 1.3.3.1.15 | 11. Cer. Parede | 3d | 2021-08-02 | 2021-08-04 | 15d | pedreiro [200%]; servente | 79.2h | 4,238.82 | 3. Casa 3 | 0. Térreo | 11. Cer. Parede 1 | Própria | 11 | 11 | 11 |
| 120 | 1.3.3.1.16 | 12. Forro (WC's e cozinha) | 1d | 2021-08-02 | 2021-08-02 | 17d | gesseiro; servente | 17.6h | 635.82 | 3. Casa 3 | 0. Térreo | 12. Forro (WC's e cozinha) 1 | Própria | 12 | 12 | 12 |
| 121 | 1.3.3.1.17 | 13. Esq. Alumínio | 1d | 2021-08-02 | 2021-08-02 | 17d | montador esquadrias [200%] | 17.6h | 11,307.22 | 3. Casa 3 | 0. Térreo | 13. Esq. Alumínio 1 | Própria | 13 | 13 | 13 |
| 122 | 1.3.3.1.18 | 14. Portas | 2d | 2021-08-02 | 2021-08-03 | 16d | marceneiro [200%] | 35.2h | 2,827.85 | 3. Casa 3 | 0. Térreo | 14. Portas 1 | Própria | 14 | 14 | 14 |
| 123 | 1.3.3.1.19 | 15. Pintura (1ª Demão) | 6d | 2021-08-02 | 2021-08-09 | 12d | pintor [400%]; aux.pintor [200%] | 316.8h | 3,764.82 | 3. Casa 3 | 0. Térreo | 15. Pintura (1ª Demão) 1 | Própria | 15 | 15 | 15 |
| 124 | 1.3.3.1.20 | 16. Bancadas | 1d | 2021-08-02 | 2021-08-02 | 17d | pedreiro [200%]; servente | 26.4h | 10,458.12 | 3. Casa 3 | 0. Térreo | 16. Bancadas 1 | Própria | 16 | 16 | 16 |
| 125 | 1.3.3.1.21 | 17. Pintura (2ª Demão) | 4d | 2021-08-02 | 2021-08-05 | 14d | pintor [400%]; aux.pintor [200%] | 211.2h | 1,563.98 | 3. Casa 3 | 0. Térreo | 17. Pintura (2ª Demão) 1 | Própria | 17 | 17 | 17 |
| 126 | 1.3.3.1.22 | 18. Limp. Interna | 1d | 2021-08-02 | 2021-08-02 | 17d | Diarista [200%] | 17.6h | 418.75 | 3. Casa 3 | 0. Térreo | 18. Limp. Interna 1 | Própria | 18 | 18 | 18 |

| ID | WBS | Task | Duration | Start | Finish | Total slack | Resources | Work | Cost | Casa | Pav | Equipe | Empresa | Pacote | Cor | LB |
| --- | --- | --- | --- | --- | --- | --- | --- | --- | --- | --- | --- | --- | --- | --- | --- | --- |
| 127 | 1.3.3.2 | **1. Pav. Superior** | 18d? | 2021-08-02 | 2021-08-25 | 0d |  | 3634.4h | 114,461.15 |  |  |  |  |  |  |  |
| 128 | 1.3.3.2.1 | 2. Estrutura | 7d | 2021-08-02 | 2021-08-10 | 11d |  |  |  | 3. Casa 3 |  |  |  |  |  |  |
| 129 | 1.3.3.2.2 | 3. Alvenarias | 10d | 2021-08-02 | 2021-08-13 | 8d | servente estrutura [300%]; aux. Carpinteiro [200%]; aux. ferreiro [200%]; ferreiro [500%]; carpinteiro [200%] | 1232h | 30,006.55 | 3. Casa 3 | 1. Pav. Superior | 2. Estrutura 1 | Própria |  |  |  |
| 130 | 1.3.3.2.3 | 5. Ref. Inter. Arg (Parede) | 18d | 2021-08-02 | 2021-08-25 | 0d | pedreiro [200%]; servente [200%] | 633.6h | 10,101.74 | 3. Casa 3 | 1. Pav. Superior | 3. Alvenarias 1 | Própria |  |  |  |
| 131 | 1.3.3.2.4 | 6. Revest. Gesso (Parede + Teto) | 7d | 2021-08-02 | 2021-08-10 | 11d | pedreiro [400%]; servente [400%] | 492.8h | 5,398.69 | 3. Casa 3 | 1. Pav. Superior | 5. Ref. Inter. Arg (Parede) 1 | Própria |  |  |  |
| 132 | 1.3.3.2.5 | 7. Impermeabilização | 1d | 2021-08-02 | 2021-08-02 | 17d | gesseiro [300%]; servente | 35.2h | 2,119.41 | 3. Casa 3 | 1. Pav. Superior | 6. Revest. Gesso (Parede + Teto) 1 | Própria |  |  |  |
| 133 | 1.3.3.2.6 | 8. Contrapiso | 2d | 2021-08-02 | 2021-08-03 | 16d | aplicador de manta | 17.6h | 2,046.85 | 3. Casa 3 | 1. Pav. Superior | 7. Impermeabilização 1 | Própria |  |  |  |
| 134 | 1.3.3.2.7 | 9. Fachada | 1d? | 2021-08-02 | 2021-08-02 | 17d | pedreiro [200%]; servente | 26.4h | 2,476.11 | 3. Casa 3 | 1. Pav. Superior | 8. Contrapiso 1 | Própria |  |  |  |
| 135 | 1.3.3.2.8 | 9.1. Chapisco | 0.5d | 2021-08-02 | 2021-08-02 | 17.5d |  |  |  | 3. Casa 3 | 1. Pav. Superior | 9. Fachada 1 | Própria |  |  |  |
| 136 | 1.3.3.2.9 | 9.2. Emboço | 1.5d | 2021-08-02 | 2021-08-03 | 16.5d | pedreiro [600%]; servente [400%] | 132h | 5,131.51 | 3. Casa 3 | 1. Pav. Superior | 9. Fachada 1 | Própria |  |  |  |
| 137 | 1.3.3.2.10 | 9.3. Pint. 1 Demão | 1d | 2021-08-02 | 2021-08-02 | 17d | pedreiro [600%]; servente [400%] | 88h | 7,697.26 | 3. Casa 3 | 1. Pav. Superior | 9. Fachada 1 | Própria |  |  |  |
| 138 | 1.3.3.2.11 | 9.4. Pint. 2 Demão | 2d | 2021-08-02 | 2021-08-03 | 16d | pintor [400%]; aux.pintor [200%] | 105.6h | 1,135.92 | 3. Casa 3 | 1. Pav. Superior | 9. Fachada 1 | Própria |  |  |  |
| 139 | 1.3.3.2.12 | 10. Cer. Piso | 8d | 2021-08-02 | 2021-08-11 | 10d | pintor [400%]; aux.pintor [200%] | 422.4h | 757.28 | 3. Casa 3 | 1. Pav. Superior | 9. Fachada 1 | Própria |  |  |  |
| 140 | 1.3.3.2.13 | 11. Cer. Parede | 2d | 2021-08-02 | 2021-08-03 | 16d | pedreiro [200%]; servente | 52.8h | 19,807.17 | 3. Casa 3 | 1. Pav. Superior | 10. Cer. Piso 1 | Própria | 10 | 10 | 10 |
| 141 | 1.3.3.2.14 | 12. Forro (WC's e cozinha) | 1d | 2021-08-02 | 2021-08-02 | 17d | pedreiro [200%]; servente | 26.4h | 4,238.82 | 3. Casa 3 | 1. Pav. Superior | 11. Cer. Parede 1 | Própria | 11 | 11 | 11 |
| 142 | 1.3.3.2.15 | 13. Esq. Alumínio | 1d | 2021-08-02 | 2021-08-02 | 17d | gesseiro; servente | 17.6h | 895 | 3. Casa 3 | 1. Pav. Superior | 12. Forro (WC's e cozinha) 1 | Própria | 12 | 12 | 12 |
| 143 | 1.3.3.2.16 | 14. Portas | 2d | 2021-08-02 | 2021-08-03 | 16d | montador esquadrias [200%] | 35.2h | 8,489.61 | 3. Casa 3 | 1. Pav. Superior | 13. Esq. Alumínio 1 | Própria | 13 | 13 | 13 |
| 144 | 1.3.3.2.17 | 15. Pintura (1ª Demão) | 6d | 2021-08-02 | 2021-08-09 | 12d | marceneiro [200%] | 105.6h | 1,858.35 | 3. Casa 3 | 1. Pav. Superior | 14. Portas 1 | Própria | 14 | 14 | 14 |
| 145 | 1.3.3.2.18 | 16. Bancadas | 1d | 2021-08-02 | 2021-08-02 | 17d | pintor [400%]; aux.pintor [200%] | 52.8h | 3,764.82 | 3. Casa 3 | 1. Pav. Superior | 15. Pintura (1ª Demão) 1 | Própria | 15 | 15 | 15 |
| 146 | 1.3.3.2.19 | 17. Pintura (2ª Demão) | 4d | 2021-08-02 | 2021-08-05 | 14d | pedreiro [200%]; servente | 105.6h | 6,972.08 | 3. Casa 3 | 1. Pav. Superior | 16. Bancadas 1 | Própria | 16 | 16 | 16 |
| 147 | 1.3.3.2.20 | 18. Limp. Interna | 1d | 2021-08-02 | 2021-08-02 | 17d | pintor [400%]; aux.pintor [200%] | 52.8h | 1,563.98 | 3. Casa 3 | 1. Pav. Superior | 17. Pintura (2ª Demão) 1 | Própria | 17 | 17 | 17 |
| 148 | 1.3.3.3 | **2. Coberta** | 6d | 2021-08-02 | 2021-08-09 | 12d |  | 536.8h | 35,295.19 |  |  |  |  |  |  |  |
| 149 | 1.3.3.3.1 | 1. Alvenarias | 6d | 2021-08-02 | 2021-08-09 | 12d | pedreiro [200%]; servente [200%] | 211.2h | 9,834.12 | 3. Casa 3 | 2. Coberta | 3. Alvenarias 1 | Própria |  |  |  |
| 150 | 1.3.3.3.2 | 2. Impermeabilização | 1d | 2021-08-02 | 2021-08-02 | 17d | aplicador de manta | 8.8h | 1,296.54 | 3. Casa 3 | 2. Coberta | 7. Impermeabilização 1 | Própria |  |  |  |
| 151 | 1.3.3.3.3 | 3. Coberta | 6d | 2021-08-02 | 2021-08-09 | 12d | carpinteiro [400%]; aux. Carpinteiro [200%] | 316.8h | 24,164.53 | 3. Casa 3 | 2. Coberta | 4. Coberta 1 | Própria |  |  |  |

| ID | WBS | Task | Duration | Start | Finish | Total slack | Resources | Work | Cost | Casa | Pav | Equipe | Empresa | Pacote | Cor | LB |
| --- | --- | --- | --- | --- | --- | --- | --- | --- | --- | --- | --- | --- | --- | --- | --- | --- |
| 152 | 1.3.4 | **4. Casa 4** | 18d? | 2021-08-02 | 2021-08-25 | 0d |  | 8668h | 315,265.59 |  |  |  |  |  |  |  |
| 153 | 1.3.4.1 | **0. Térreo** | 16d? | 2021-08-02 | 2021-08-23 | 2d |  | 4496.8h | 165,509.25 |  |  |  |  |  |  |  |
| 154 | 1.3.4.1.1 | 0. Locação | 2d | 2021-08-02 | 2021-08-03 | 16d | carpinteiro; aux. Carpinteiro | 35.2h | 456.99 | 4. Casa 4 | 0. Térreo | 0. Locação 1 | Própria |  |  |  |
| 155 | 1.3.4.1.2 | 1. Fundação | 9d | 2021-08-02 | 2021-08-12 | 9d | servente estrutura [300%]; aux. Carpinteiro; aux. ferreiro; ferreiro; carpinteiro [200%] | 633.6h | 19,882.86 | 4. Casa 4 | 0. Térreo | 1. Fundação 1 | Própria |  |  |  |
| 156 | 1.3.4.1.3 | 2. Estrutura | 7d | 2021-08-02 | 2021-08-10 | 11d | servente estrutura [300%]; aux. Carpinteiro [200%]; aux. ferreiro [200%]; ferreiro [500%]; carpinteiro [200%] | 862.4h | 46,439.03 | 4. Casa 4 | 0. Térreo | 2. Estrutura 1 | Própria |  |  |  |
| 157 | 1.3.4.1.4 | 3. Alvenarias | 10d | 2021-08-02 | 2021-08-13 | 8d | pedreiro [200%]; servente [200%] | 352h | 8,388.41 | 4. Casa 4 | 0. Térreo | 3. Alvenarias 1 | Própria |  |  |  |
| 158 | 1.3.4.1.5 | 5. Ref. Inter. Arg (Parede) | 16d | 2021-08-02 | 2021-08-23 | 2d | pedreiro [400%]; servente [400%] | 1126.4h | 5,776 | 4. Casa 4 | 0. Térreo | 5. Ref. Inter. Arg (Parede) 1 | Própria |  |  |  |
| 159 | 1.3.4.1.6 | 6. Revest. Gesso (Parede + Teto) | 5d | 2021-08-02 | 2021-08-06 | 13d | gesseiro [300%]; servente | 176h | 2,119.41 | 4. Casa 4 | 0. Térreo | 6. Revest. Gesso (Parede + Teto) 1 | Própria |  |  |  |
| 160 | 1.3.4.1.7 | 7. Impermeabilização | 2d | 2021-08-02 | 2021-08-03 | 16d | aplicador de manta | 17.6h | 3,288.15 | 4. Casa 4 | 0. Térreo | 7. Impermeabilização 1 | Própria |  |  |  |
| 161 | 1.3.4.1.8 | 8. Contrapiso | 2d | 2021-08-02 | 2021-08-03 | 16d | pedreiro [200%]; servente | 52.8h | 3,735.07 | 4. Casa 4 | 0. Térreo | 8. Contrapiso 1 | Própria |  |  |  |
| 162 | 1.3.4.1.9 | 9. Fachada | 1d? | 2021-08-02 | 2021-08-02 | 17d |  |  |  | 4. Casa 4 | 0. Térreo | 9. Fachada 1 | Própria |  |  |  |
| 163 | 1.3.4.1.10 | 9.1. Chapisco | 0.5d | 2021-08-02 | 2021-08-02 | 17.5d | pedreiro [600%]; servente [400%] | 44h | 5,131.51 | 4. Casa 4 | 0. Térreo | 9. Fachada 1 | Própria |  |  |  |
| 164 | 1.3.4.1.11 | 9.2. Emboço | 1.5d | 2021-08-02 | 2021-08-03 | 16.5d | pedreiro [600%]; servente [400%] | 132h | 7,697.26 | 4. Casa 4 | 0. Térreo | 9. Fachada 1 | Própria |  |  |  |
| 165 | 1.3.4.1.12 | 9.3. Pint. 1 Demão | 1d | 2021-08-02 | 2021-08-02 | 17d | pintor [400%]; aux.pintor [200%] | 52.8h | 1,135.92 | 4. Casa 4 | 0. Térreo | 9. Fachada 1 | Própria |  |  |  |
| 166 | 1.3.4.1.13 | 9.4. Pint. 2 Demão | 2d | 2021-08-02 | 2021-08-03 | 16d | pintor [400%]; aux.pintor [200%] | 105.6h | 757.28 | 4. Casa 4 | 0. Térreo | 9. Fachada 1 | Própria |  |  |  |
| 167 | 1.3.4.1.14 | 10. Cer. Piso | 7d | 2021-08-02 | 2021-08-10 | 11d | pedreiro [200%]; servente | 184.8h | 25,485.98 | 4. Casa 4 | 0. Térreo | 10. Cer. Piso 1 | Própria | 10 | 10 | 10 |
| 168 | 1.3.4.1.15 | 11. Cer. Parede | 3d | 2021-08-02 | 2021-08-04 | 15d | pedreiro [200%]; servente | 79.2h | 4,238.82 | 4. Casa 4 | 0. Térreo | 11. Cer. Parede 1 | Própria | 11 | 11 | 11 |
| 169 | 1.3.4.1.16 | 12. Forro (WC's e cozinha) | 1d | 2021-08-02 | 2021-08-02 | 17d | gesseiro; servente | 17.6h | 635.82 | 4. Casa 4 | 0. Térreo | 12. Forro (WC's e cozinha) 1 | Própria | 12 | 12 | 12 |
| 170 | 1.3.4.1.17 | 13. Esq. Alumínio | 1d | 2021-08-02 | 2021-08-02 | 17d | montador esquadrias [200%] | 17.6h | 11,307.22 | 4. Casa 4 | 0. Térreo | 13. Esq. Alumínio 1 | Própria | 13 | 13 | 13 |
| 171 | 1.3.4.1.18 | 14. Portas | 2d | 2021-08-02 | 2021-08-03 | 16d | marceneiro [200%] | 35.2h | 2,827.85 | 4. Casa 4 | 0. Térreo | 14. Portas 1 | Própria | 14 | 14 | 14 |
| 172 | 1.3.4.1.19 | 15. Pintura (1ª Demão) | 6d | 2021-08-02 | 2021-08-09 | 12d | pintor [400%]; aux.pintor [200%] | 316.8h | 3,764.82 | 4. Casa 4 | 0. Térreo | 15. Pintura (1ª Demão) 1 | Própria | 15 | 15 | 15 |
| 173 | 1.3.4.1.20 | 16. Bancadas | 1d | 2021-08-02 | 2021-08-02 | 17d | pedreiro [200%]; servente | 26.4h | 10,458.12 | 4. Casa 4 | 0. Térreo | 16. Bancadas 1 | Própria | 16 | 16 | 16 |
| 174 | 1.3.4.1.21 | 17. Pintura (2ª Demão) | 4d | 2021-08-02 | 2021-08-05 | 14d | pintor [400%]; aux.pintor [200%] | 211.2h | 1,563.98 | 4. Casa 4 | 0. Térreo | 17. Pintura (2ª Demão) 1 | Própria | 17 | 17 | 17 |
| 175 | 1.3.4.1.22 | 18. Limp. Interna | 1d | 2021-08-02 | 2021-08-02 | 17d | Diarista [200%] | 17.6h | 418.75 | 4. Casa 4 | 0. Térreo | 18. Limp. Interna 1 | Própria | 18 | 18 | 18 |

| ID | WBS | Task | Duration | Start | Finish | Total slack | Resources | Work | Cost | Casa | Pav | Equipe | Empresa | Pacote | Cor | LB |
| --- | --- | --- | --- | --- | --- | --- | --- | --- | --- | --- | --- | --- | --- | --- | --- | --- |
| 176 | 1.3.4.2 | **1. Pav. Superior** | 18d? | 2021-08-02 | 2021-08-25 | 0d |  | 3634.4h | 114,461.15 |  |  |  |  |  |  |  |
| 177 | 1.3.4.2.1 | 2. Estrutura | 7d | 2021-08-02 | 2021-08-10 | 11d |  |  |  | 4. Casa 4 |  |  |  |  |  |  |
| 178 | 1.3.4.2.2 | 3. Alvenarias | 10d | 2021-08-02 | 2021-08-13 | 8d | servente estrutura [300%]; aux. Carpinteiro [200%]; aux. ferreiro [200%]; ferreiro [500%]; carpinteiro [200%] | 1232h | 30,006.55 | 4. Casa 4 | 1. Pav. Superior | 2. Estrutura 1 | Própria |  |  |  |
| 179 | 1.3.4.2.3 | 5. Ref. Inter. Arg (Parede) | 18d | 2021-08-02 | 2021-08-25 | 0d | pedreiro [200%]; servente [200%] | 633.6h | 10,101.74 | 4. Casa 4 | 1. Pav. Superior | 3. Alvenarias 1 | Própria |  |  |  |
| 180 | 1.3.4.2.4 | 6. Revest. Gesso (Parede + Teto) | 7d | 2021-08-02 | 2021-08-10 | 11d | pedreiro [400%]; servente [400%] | 492.8h | 5,398.69 | 4. Casa 4 | 1. Pav. Superior | 5. Ref. Inter. Arg (Parede) 1 | Própria |  |  |  |
| 181 | 1.3.4.2.5 | 7. Impermeabilização | 1d | 2021-08-02 | 2021-08-02 | 17d | gesseiro [300%]; servente | 35.2h | 2,119.41 | 4. Casa 4 | 1. Pav. Superior | 6. Revest. Gesso (Parede + Teto) 1 | Própria |  |  |  |
| 182 | 1.3.4.2.6 | 8. Contrapiso | 2d | 2021-08-02 | 2021-08-03 | 16d | aplicador de manta | 17.6h | 2,046.85 | 4. Casa 4 | 1. Pav. Superior | 7. Impermeabilização 1 | Própria |  |  |  |
| 183 | 1.3.4.2.7 | 9. Fachada | 1d? | 2021-08-02 | 2021-08-02 | 17d | pedreiro [200%]; servente | 26.4h | 2,476.11 | 4. Casa 4 | 1. Pav. Superior | 8. Contrapiso 1 | Própria |  |  |  |
| 184 | 1.3.4.2.8 | 9.1. Chapisco | 0.5d | 2021-08-02 | 2021-08-02 | 17.5d |  |  |  | 4. Casa 4 | 1. Pav. Superior | 9. Fachada 1 | Própria |  |  |  |
| 185 | 1.3.4.2.9 | 9.2. Emboço | 1.5d | 2021-08-02 | 2021-08-03 | 16.5d | pedreiro [600%]; servente [400%] | 132h | 5,131.51 | 4. Casa 4 | 1. Pav. Superior | 9. Fachada 1 | Própria |  |  |  |
| 186 | 1.3.4.2.10 | 9.3. Pint. 1 Demão | 1d | 2021-08-02 | 2021-08-02 | 17d | pedreiro [600%]; servente [400%] | 88h | 7,697.26 | 4. Casa 4 | 1. Pav. Superior | 9. Fachada 1 | Própria |  |  |  |
| 187 | 1.3.4.2.11 | 9.4. Pint. 2 Demão | 2d | 2021-08-02 | 2021-08-03 | 16d | pintor [400%]; aux.pintor [200%] | 105.6h | 1,135.92 | 4. Casa 4 | 1. Pav. Superior | 9. Fachada 1 | Própria |  |  |  |
| 188 | 1.3.4.2.12 | 10. Cer. Piso | 8d | 2021-08-02 | 2021-08-11 | 10d | pintor [400%]; aux.pintor [200%] | 422.4h | 757.28 | 4. Casa 4 | 1. Pav. Superior | 9. Fachada 1 | Própria |  |  |  |
| 189 | 1.3.4.2.13 | 11. Cer. Parede | 2d | 2021-08-02 | 2021-08-03 | 16d | pedreiro [200%]; servente | 52.8h | 19,807.17 | 4. Casa 4 | 1. Pav. Superior | 10. Cer. Piso 1 | Própria | 10 | 10 | 10 |
| 190 | 1.3.4.2.14 | 12. Forro (WC's e cozinha) | 1d | 2021-08-02 | 2021-08-02 | 17d | pedreiro [200%]; servente | 26.4h | 4,238.82 | 4. Casa 4 | 1. Pav. Superior | 11. Cer. Parede 1 | Própria | 11 | 11 | 11 |
| 191 | 1.3.4.2.15 | 13. Esq. Alumínio | 1d | 2021-08-02 | 2021-08-02 | 17d | gesseiro; servente | 17.6h | 895 | 4. Casa 4 | 1. Pav. Superior | 12. Forro (WC's e cozinha) 1 | Própria | 12 | 12 | 12 |
| 192 | 1.3.4.2.16 | 14. Portas | 2d | 2021-08-02 | 2021-08-03 | 16d | montador esquadrias [200%] | 35.2h | 8,489.61 | 4. Casa 4 | 1. Pav. Superior | 13. Esq. Alumínio 1 | Própria | 13 | 13 | 13 |
| 193 | 1.3.4.2.17 | 15. Pintura (1ª Demão) | 6d | 2021-08-02 | 2021-08-09 | 12d | marceneiro [200%] | 105.6h | 1,858.35 | 4. Casa 4 | 1. Pav. Superior | 14. Portas 1 | Própria | 14 | 14 | 14 |
| 194 | 1.3.4.2.18 | 16. Bancadas | 1d | 2021-08-02 | 2021-08-02 | 17d | pintor [400%]; aux.pintor [200%] | 52.8h | 3,764.82 | 4. Casa 4 | 1. Pav. Superior | 15. Pintura (1ª Demão) 1 | Própria | 15 | 15 | 15 |
| 195 | 1.3.4.2.19 | 17. Pintura (2ª Demão) | 4d | 2021-08-02 | 2021-08-05 | 14d | pedreiro [200%]; servente | 105.6h | 6,972.08 | 4. Casa 4 | 1. Pav. Superior | 16. Bancadas 1 | Própria | 16 | 16 | 16 |
| 196 | 1.3.4.2.20 | 18. Limp. Interna | 1d | 2021-08-02 | 2021-08-02 | 17d | pintor [400%]; aux.pintor [200%] | 52.8h | 1,563.98 | 4. Casa 4 | 1. Pav. Superior | 17. Pintura (2ª Demão) 1 | Própria | 17 | 17 | 17 |
| 197 | 1.3.4.3 | **2. Coberta** | 6d | 2021-08-02 | 2021-08-09 | 12d |  | 536.8h | 35,295.19 |  |  |  |  |  |  |  |
| 198 | 1.3.4.3.1 | 1. Alvenarias | 6d | 2021-08-02 | 2021-08-09 | 12d | pedreiro [200%]; servente [200%] | 211.2h | 9,834.12 | 4. Casa 4 | 2. Coberta | 3. Alvenarias 1 | Própria |  |  |  |
| 199 | 1.3.4.3.2 | 2. Impermeabilização | 1d | 2021-08-02 | 2021-08-02 | 17d | aplicador de manta | 8.8h | 1,296.54 | 4. Casa 4 | 2. Coberta | 7. Impermeabilização 1 | Própria |  |  |  |
| 200 | 1.3.4.3.3 | 3. Coberta | 6d | 2021-08-02 | 2021-08-09 | 12d | carpinteiro [400%]; aux. Carpinteiro [200%] | 316.8h | 24,164.53 | 4. Casa 4 | 2. Coberta | 4. Coberta 1 | Própria |  |  |  |

| ID | WBS | Task | Duration | Start | Finish | Total slack | Resources | Work | Cost | Casa | Pav | Equipe | Empresa | Pacote | Cor | LB |
| --- | --- | --- | --- | --- | --- | --- | --- | --- | --- | --- | --- | --- | --- | --- | --- | --- |
| 201 | 1.3.5 | **5. Casa 5** | 18d? | 2021-08-02 | 2021-08-25 | 0d |  | 8668h | 315,265.59 |  |  |  |  |  |  |  |
| 202 | 1.3.5.1 | **0. Térreo** | 16d? | 2021-08-02 | 2021-08-23 | 2d |  | 4496.8h | 165,509.25 |  |  |  |  |  |  |  |
| 203 | 1.3.5.1.1 | 0. Locação | 2d | 2021-08-02 | 2021-08-03 | 16d | carpinteiro; aux. Carpinteiro | 35.2h | 456.99 | 5. Casa 5 | 0. Térreo | 0. Locação 1 | Própria |  |  |  |
| 204 | 1.3.5.1.2 | 1. Fundação | 9d | 2021-08-02 | 2021-08-12 | 9d | servente estrutura [300%]; aux. Carpinteiro; aux. ferreiro; ferreiro; carpinteiro [200%] | 633.6h | 19,882.86 | 5. Casa 5 | 0. Térreo | 1. Fundação 1 | Própria |  |  |  |
| 205 | 1.3.5.1.3 | 2. Estrutura | 7d | 2021-08-02 | 2021-08-10 | 11d | servente estrutura [300%]; aux. Carpinteiro [200%]; aux. ferreiro [200%]; ferreiro [500%]; carpinteiro [200%] | 862.4h | 46,439.03 | 5. Casa 5 | 0. Térreo | 2. Estrutura 1 | Própria |  |  |  |
| 206 | 1.3.5.1.4 | 3. Alvenarias | 10d | 2021-08-02 | 2021-08-13 | 8d | pedreiro [200%]; servente [200%] | 352h | 8,388.41 | 5. Casa 5 | 0. Térreo | 3. Alvenarias 1 | Própria |  |  |  |
| 207 | 1.3.5.1.5 | 5. Ref. Inter. Arg (Parede) | 16d | 2021-08-02 | 2021-08-23 | 2d | pedreiro [400%]; servente [400%] | 1126.4h | 5,776 | 5. Casa 5 | 0. Térreo | 5. Ref. Inter. Arg (Parede) 1 | Própria |  |  |  |
| 208 | 1.3.5.1.6 | 6. Revest. Gesso (Parede + Teto) | 5d | 2021-08-02 | 2021-08-06 | 13d | gesseiro [300%]; servente | 176h | 2,119.41 | 5. Casa 5 | 0. Térreo | 6. Revest. Gesso (Parede + Teto) 1 | Própria |  |  |  |
| 209 | 1.3.5.1.7 | 7. Impermeabilização | 2d | 2021-08-02 | 2021-08-03 | 16d | aplicador de manta | 17.6h | 3,288.15 | 5. Casa 5 | 0. Térreo | 7. Impermeabilização 1 | Própria |  |  |  |
| 210 | 1.3.5.1.8 | 8. Contrapiso | 2d | 2021-08-02 | 2021-08-03 | 16d | pedreiro [200%]; servente | 52.8h | 3,735.07 | 5. Casa 5 | 0. Térreo | 8. Contrapiso 1 | Própria |  |  |  |
| 211 | 1.3.5.1.9 | 9. Fachada | 1d? | 2021-08-02 | 2021-08-02 | 17d |  |  |  | 5. Casa 5 | 0. Térreo | 9. Fachada 1 | Própria |  |  |  |
| 212 | 1.3.5.1.10 | 9.1. Chapisco | 0.5d | 2021-08-02 | 2021-08-02 | 17.5d | pedreiro [600%]; servente [400%] | 44h | 5,131.51 | 5. Casa 5 | 0. Térreo | 9. Fachada 1 | Própria |  |  |  |
| 213 | 1.3.5.1.11 | 9.2. Emboço | 1.5d | 2021-08-02 | 2021-08-03 | 16.5d | pedreiro [600%]; servente [400%] | 132h | 7,697.26 | 5. Casa 5 | 0. Térreo | 9. Fachada 1 | Própria |  |  |  |
| 214 | 1.3.5.1.12 | 9.3. Pint. 1 Demão | 1d | 2021-08-02 | 2021-08-02 | 17d | pintor [400%]; aux.pintor [200%] | 52.8h | 1,135.92 | 5. Casa 5 | 0. Térreo | 9. Fachada 1 | Própria |  |  |  |
| 215 | 1.3.5.1.13 | 9.4. Pint. 2 Demão | 2d | 2021-08-02 | 2021-08-03 | 16d | pintor [400%]; aux.pintor [200%] | 105.6h | 757.28 | 5. Casa 5 | 0. Térreo | 9. Fachada 1 | Própria |  |  |  |
| 216 | 1.3.5.1.14 | 10. Cer. Piso | 7d | 2021-08-02 | 2021-08-10 | 11d | pedreiro [200%]; servente | 184.8h | 25,485.98 | 5. Casa 5 | 0. Térreo | 10. Cer. Piso 1 | Própria | 10 | 10 | 10 |
| 217 | 1.3.5.1.15 | 11. Cer. Parede | 3d | 2021-08-02 | 2021-08-04 | 15d | pedreiro [200%]; servente | 79.2h | 4,238.82 | 5. Casa 5 | 0. Térreo | 11. Cer. Parede 1 | Própria | 11 | 11 | 11 |
| 218 | 1.3.5.1.16 | 12. Forro (WC's e cozinha) | 1d | 2021-08-02 | 2021-08-02 | 17d | gesseiro; servente | 17.6h | 635.82 | 5. Casa 5 | 0. Térreo | 12. Forro (WC's e cozinha) 1 | Própria | 12 | 12 | 12 |
| 219 | 1.3.5.1.17 | 13. Esq. Alumínio | 1d | 2021-08-02 | 2021-08-02 | 17d | montador esquadrias [200%] | 17.6h | 11,307.22 | 5. Casa 5 | 0. Térreo | 13. Esq. Alumínio 1 | Própria | 13 | 13 | 13 |
| 220 | 1.3.5.1.18 | 14. Portas | 2d | 2021-08-02 | 2021-08-03 | 16d | marceneiro [200%] | 35.2h | 2,827.85 | 5. Casa 5 | 0. Térreo | 14. Portas 1 | Própria | 14 | 14 | 14 |
| 221 | 1.3.5.1.19 | 15. Pintura (1ª Demão) | 6d | 2021-08-02 | 2021-08-09 | 12d | pintor [400%]; aux.pintor [200%] | 316.8h | 3,764.82 | 5. Casa 5 | 0. Térreo | 15. Pintura (1ª Demão) 1 | Própria | 15 | 15 | 15 |
| 222 | 1.3.5.1.20 | 16. Bancadas | 1d | 2021-08-02 | 2021-08-02 | 17d | pedreiro [200%]; servente | 26.4h | 10,458.12 | 5. Casa 5 | 0. Térreo | 16. Bancadas 1 | Própria | 16 | 16 | 16 |
| 223 | 1.3.5.1.21 | 17. Pintura (2ª Demão) | 4d | 2021-08-02 | 2021-08-05 | 14d | pintor [400%]; aux.pintor [200%] | 211.2h | 1,563.98 | 5. Casa 5 | 0. Térreo | 17. Pintura (2ª Demão) 1 | Própria | 17 | 17 | 17 |
| 224 | 1.3.5.1.22 | 18. Limp. Interna | 1d | 2021-08-02 | 2021-08-02 | 17d | Diarista [200%] | 17.6h | 418.75 | 5. Casa 5 | 0. Térreo | 18. Limp. Interna 1 | Própria | 18 | 18 | 18 |

| ID | WBS | Task | Duration | Start | Finish | Total slack | Resources | Work | Cost | Casa | Pav | Equipe | Empresa | Pacote | Cor | LB |
| --- | --- | --- | --- | --- | --- | --- | --- | --- | --- | --- | --- | --- | --- | --- | --- | --- |
| 225 | 1.3.5.2 | **1. Pav. Superior** | 18d? | 2021-08-02 | 2021-08-25 | 0d |  | 3634.4h | 114,461.15 |  |  |  |  |  |  |  |
| 226 | 1.3.5.2.1 | 2. Estrutura | 7d | 2021-08-02 | 2021-08-10 | 11d |  |  |  | 5. Casa 5 |  |  |  |  |  |  |
| 227 | 1.3.5.2.2 | 3. Alvenarias | 10d | 2021-08-02 | 2021-08-13 | 8d | servente estrutura [300%]; aux. Carpinteiro [200%]; aux. ferreiro [200%]; ferreiro [500%]; carpinteiro [200%] | 1232h | 30,006.55 | 5. Casa 5 | 1. Pav. Superior | 2. Estrutura 1 | Própria |  |  |  |
| 228 | 1.3.5.2.3 | 5. Ref. Inter. Arg (Parede) | 18d | 2021-08-02 | 2021-08-25 | 0d | pedreiro [200%]; servente [200%] | 633.6h | 10,101.74 | 5. Casa 5 | 1. Pav. Superior | 3. Alvenarias 1 | Própria |  |  |  |
| 229 | 1.3.5.2.4 | 6. Revest. Gesso (Parede + Teto) | 7d | 2021-08-02 | 2021-08-10 | 11d | pedreiro [400%]; servente [400%] | 492.8h | 5,398.69 | 5. Casa 5 | 1. Pav. Superior | 5. Ref. Inter. Arg (Parede) 1 | Própria |  |  |  |
| 230 | 1.3.5.2.5 | 7. Impermeabilização | 1d | 2021-08-02 | 2021-08-02 | 17d | gesseiro [300%]; servente | 35.2h | 2,119.41 | 5. Casa 5 | 1. Pav. Superior | 6. Revest. Gesso (Parede + Teto) 1 | Própria |  |  |  |
| 231 | 1.3.5.2.6 | 8. Contrapiso | 2d | 2021-08-02 | 2021-08-03 | 16d | aplicador de manta | 17.6h | 2,046.85 | 5. Casa 5 | 1. Pav. Superior | 7. Impermeabilização 1 | Própria |  |  |  |
| 232 | 1.3.5.2.7 | 9. Fachada | 1d? | 2021-08-02 | 2021-08-02 | 17d | pedreiro [200%]; servente | 26.4h | 2,476.11 | 5. Casa 5 | 1. Pav. Superior | 8. Contrapiso 1 | Própria |  |  |  |
| 233 | 1.3.5.2.8 | 9.1. Chapisco | 0.5d | 2021-08-02 | 2021-08-02 | 17.5d |  |  |  | 5. Casa 5 | 1. Pav. Superior | 9. Fachada 1 | Própria |  |  |  |
| 234 | 1.3.5.2.9 | 9.2. Emboço | 1.5d | 2021-08-02 | 2021-08-03 | 16.5d | pedreiro [600%]; servente [400%] | 132h | 5,131.51 | 5. Casa 5 | 1. Pav. Superior | 9. Fachada 1 | Própria |  |  |  |
| 235 | 1.3.5.2.10 | 9.3. Pint. 1 Demão | 1d | 2021-08-02 | 2021-08-02 | 17d | pedreiro [600%]; servente [400%] | 88h | 7,697.26 | 5. Casa 5 | 1. Pav. Superior | 9. Fachada 1 | Própria |  |  |  |
| 236 | 1.3.5.2.11 | 9.4. Pint. 2 Demão | 2d | 2021-08-02 | 2021-08-03 | 16d | pintor [400%]; aux.pintor [200%] | 105.6h | 1,135.92 | 5. Casa 5 | 1. Pav. Superior | 9. Fachada 1 | Própria |  |  |  |
| 237 | 1.3.5.2.12 | 10. Cer. Piso | 8d | 2021-08-02 | 2021-08-11 | 10d | pintor [400%]; aux.pintor [200%] | 422.4h | 757.28 | 5. Casa 5 | 1. Pav. Superior | 9. Fachada 1 | Própria |  |  |  |
| 238 | 1.3.5.2.13 | 11. Cer. Parede | 2d | 2021-08-02 | 2021-08-03 | 16d | pedreiro [200%]; servente | 52.8h | 19,807.17 | 5. Casa 5 | 1. Pav. Superior | 10. Cer. Piso 1 | Própria | 10 | 10 | 10 |
| 239 | 1.3.5.2.14 | 12. Forro (WC's e cozinha) | 1d | 2021-08-02 | 2021-08-02 | 17d | pedreiro [200%]; servente | 26.4h | 4,238.82 | 5. Casa 5 | 1. Pav. Superior | 11. Cer. Parede 1 | Própria | 11 | 11 | 11 |
| 240 | 1.3.5.2.15 | 13. Esq. Alumínio | 1d | 2021-08-02 | 2021-08-02 | 17d | gesseiro; servente | 17.6h | 895 | 5. Casa 5 | 1. Pav. Superior | 12. Forro (WC's e cozinha) 1 | Própria | 12 | 12 | 12 |
| 241 | 1.3.5.2.16 | 14. Portas | 2d | 2021-08-02 | 2021-08-03 | 16d | montador esquadrias [200%] | 35.2h | 8,489.61 | 5. Casa 5 | 1. Pav. Superior | 13. Esq. Alumínio 1 | Própria | 13 | 13 | 13 |
| 242 | 1.3.5.2.17 | 15. Pintura (1ª Demão) | 6d | 2021-08-02 | 2021-08-09 | 12d | marceneiro [200%] | 105.6h | 1,858.35 | 5. Casa 5 | 1. Pav. Superior | 14. Portas 1 | Própria | 14 | 14 | 14 |
| 243 | 1.3.5.2.18 | 16. Bancadas | 1d | 2021-08-02 | 2021-08-02 | 17d | pintor [400%]; aux.pintor [200%] | 52.8h | 3,764.82 | 5. Casa 5 | 1. Pav. Superior | 15. Pintura (1ª Demão) 1 | Própria | 15 | 15 | 15 |
| 244 | 1.3.5.2.19 | 17. Pintura (2ª Demão) | 4d | 2021-08-02 | 2021-08-05 | 14d | pedreiro [200%]; servente | 105.6h | 6,972.08 | 5. Casa 5 | 1. Pav. Superior | 16. Bancadas 1 | Própria | 16 | 16 | 16 |
| 245 | 1.3.5.2.20 | 18. Limp. Interna | 1d | 2021-08-02 | 2021-08-02 | 17d | pintor [400%]; aux.pintor [200%] | 52.8h | 1,563.98 | 5. Casa 5 | 1. Pav. Superior | 17. Pintura (2ª Demão) 1 | Própria | 17 | 17 | 17 |
| 246 | 1.3.5.3 | **2. Coberta** | 6d | 2021-08-02 | 2021-08-09 | 12d |  | 536.8h | 35,295.19 |  |  |  |  |  |  |  |
| 247 | 1.3.5.3.1 | 1. Alvenarias | 6d | 2021-08-02 | 2021-08-09 | 12d | pedreiro [200%]; servente [200%] | 211.2h | 9,834.12 | 5. Casa 5 | 2. Coberta | 3. Alvenarias 1 | Própria |  |  |  |
| 248 | 1.3.5.3.2 | 2. Impermeabilização | 1d | 2021-08-02 | 2021-08-02 | 17d | aplicador de manta | 8.8h | 1,296.54 | 5. Casa 5 | 2. Coberta | 7. Impermeabilização 1 | Própria |  |  |  |
| 249 | 1.3.5.3.3 | 3. Coberta | 6d | 2021-08-02 | 2021-08-09 | 12d | carpinteiro [400%]; aux. Carpinteiro [200%] | 316.8h | 24,164.53 | 5. Casa 5 | 2. Coberta | 4. Coberta 1 | Própria |  |  |  |

| ID | WBS | Task | Duration | Start | Finish | Total slack | Resources | Work | Cost | Casa | Pav | Equipe | Empresa | Pacote | Cor | LB |
| --- | --- | --- | --- | --- | --- | --- | --- | --- | --- | --- | --- | --- | --- | --- | --- | --- |
| 250 | 1.3.6 | **6. Casa 6** | 18d? | 2021-08-02 | 2021-08-25 | 0d |  | 8668h | 315,265.59 |  |  |  |  |  |  |  |
| 251 | 1.3.6.1 | **0. Térreo** | 16d? | 2021-08-02 | 2021-08-23 | 2d |  | 4496.8h | 165,509.25 |  |  |  |  |  |  |  |
| 252 | 1.3.6.1.1 | 0. Locação | 2d | 2021-08-02 | 2021-08-03 | 16d | carpinteiro; aux. Carpinteiro | 35.2h | 456.99 | 6. Casa 6 | 0. Térreo | 0. Locação 1 | Própria |  |  |  |
| 253 | 1.3.6.1.2 | 1. Fundação | 9d | 2021-08-02 | 2021-08-12 | 9d | servente estrutura [300%]; aux. Carpinteiro; aux. ferreiro; ferreiro; carpinteiro [200%] | 633.6h | 19,882.86 | 6. Casa 6 | 0. Térreo | 1. Fundação 1 | Própria |  |  |  |
| 254 | 1.3.6.1.3 | 2. Estrutura | 7d | 2021-08-02 | 2021-08-10 | 11d | servente estrutura [300%]; aux. Carpinteiro [200%]; aux. ferreiro [200%]; ferreiro [500%]; carpinteiro [200%] | 862.4h | 46,439.03 | 6. Casa 6 | 0. Térreo | 2. Estrutura 1 | Própria |  |  |  |
| 255 | 1.3.6.1.4 | 3. Alvenarias | 10d | 2021-08-02 | 2021-08-13 | 8d | pedreiro [200%]; servente [200%] | 352h | 8,388.41 | 6. Casa 6 | 0. Térreo | 3. Alvenarias 1 | Própria |  |  |  |
| 256 | 1.3.6.1.5 | 5. Ref. Inter. Arg (Parede) | 16d | 2021-08-02 | 2021-08-23 | 2d | pedreiro [400%]; servente [400%] | 1126.4h | 5,776 | 6. Casa 6 | 0. Térreo | 5. Ref. Inter. Arg (Parede) 1 | Própria |  |  |  |
| 257 | 1.3.6.1.6 | 6. Revest. Gesso (Parede + Teto) | 5d | 2021-08-02 | 2021-08-06 | 13d | gesseiro [300%]; servente | 176h | 2,119.41 | 6. Casa 6 | 0. Térreo | 6. Revest. Gesso (Parede + Teto) 1 | Própria |  |  |  |
| 258 | 1.3.6.1.7 | 7. Impermeabilização | 2d | 2021-08-02 | 2021-08-03 | 16d | aplicador de manta | 17.6h | 3,288.15 | 6. Casa 6 | 0. Térreo | 7. Impermeabilização 1 | Própria |  |  |  |
| 259 | 1.3.6.1.8 | 8. Contrapiso | 2d | 2021-08-02 | 2021-08-03 | 16d | pedreiro [200%]; servente | 52.8h | 3,735.07 | 6. Casa 6 | 0. Térreo | 8. Contrapiso 1 | Própria |  |  |  |
| 260 | 1.3.6.1.9 | 9. Fachada | 1d? | 2021-08-02 | 2021-08-02 | 17d |  |  |  | 6. Casa 6 | 0. Térreo | 9. Fachada 1 | Própria |  |  |  |
| 261 | 1.3.6.1.10 | 9.1. Chapisco | 0.5d | 2021-08-02 | 2021-08-02 | 17.5d | pedreiro [600%]; servente [400%] | 44h | 5,131.51 | 6. Casa 6 | 0. Térreo | 9. Fachada 1 | Própria |  |  |  |
| 262 | 1.3.6.1.11 | 9.2. Emboço | 1.5d | 2021-08-02 | 2021-08-03 | 16.5d | pedreiro [600%]; servente [400%] | 132h | 7,697.26 | 6. Casa 6 | 0. Térreo | 9. Fachada 1 | Própria |  |  |  |
| 263 | 1.3.6.1.12 | 9.3. Pint. 1 Demão | 1d | 2021-08-02 | 2021-08-02 | 17d | pintor [400%]; aux.pintor [200%] | 52.8h | 1,135.92 | 6. Casa 6 | 0. Térreo | 9. Fachada 1 | Própria |  |  |  |
| 264 | 1.3.6.1.13 | 9.4. Pint. 2 Demão | 2d | 2021-08-02 | 2021-08-03 | 16d | pintor [400%]; aux.pintor [200%] | 105.6h | 757.28 | 6. Casa 6 | 0. Térreo | 9. Fachada 1 | Própria |  |  |  |
| 265 | 1.3.6.1.14 | 10. Cer. Piso | 7d | 2021-08-02 | 2021-08-10 | 11d | pedreiro [200%]; servente | 184.8h | 25,485.98 | 6. Casa 6 | 0. Térreo | 10. Cer. Piso 1 | Própria | 10 | 10 | 10 |
| 266 | 1.3.6.1.15 | 11. Cer. Parede | 3d | 2021-08-02 | 2021-08-04 | 15d | pedreiro [200%]; servente | 79.2h | 4,238.82 | 6. Casa 6 | 0. Térreo | 11. Cer. Parede 1 | Própria | 11 | 11 | 11 |
| 267 | 1.3.6.1.16 | 12. Forro (WC's e cozinha) | 1d | 2021-08-02 | 2021-08-02 | 17d | gesseiro; servente | 17.6h | 635.82 | 6. Casa 6 | 0. Térreo | 12. Forro (WC's e cozinha) 1 | Própria | 12 | 12 | 12 |
| 268 | 1.3.6.1.17 | 13. Esq. Alumínio | 1d | 2021-08-02 | 2021-08-02 | 17d | montador esquadrias [200%] | 17.6h | 11,307.22 | 6. Casa 6 | 0. Térreo | 13. Esq. Alumínio 1 | Própria | 13 | 13 | 13 |
| 269 | 1.3.6.1.18 | 14. Portas | 2d | 2021-08-02 | 2021-08-03 | 16d | marceneiro [200%] | 35.2h | 2,827.85 | 6. Casa 6 | 0. Térreo | 14. Portas 1 | Própria | 14 | 14 | 14 |
| 270 | 1.3.6.1.19 | 15. Pintura (1ª Demão) | 6d | 2021-08-02 | 2021-08-09 | 12d | pintor [400%]; aux.pintor [200%] | 316.8h | 3,764.82 | 6. Casa 6 | 0. Térreo | 15. Pintura (1ª Demão) 1 | Própria | 15 | 15 | 15 |
| 271 | 1.3.6.1.20 | 16. Bancadas | 1d | 2021-08-02 | 2021-08-02 | 17d | pedreiro [200%]; servente | 26.4h | 10,458.12 | 6. Casa 6 | 0. Térreo | 16. Bancadas 1 | Própria | 16 | 16 | 16 |
| 272 | 1.3.6.1.21 | 17. Pintura (2ª Demão) | 4d | 2021-08-02 | 2021-08-05 | 14d | pintor [400%]; aux.pintor [200%] | 211.2h | 1,563.98 | 6. Casa 6 | 0. Térreo | 17. Pintura (2ª Demão) 1 | Própria | 17 | 17 | 17 |
| 273 | 1.3.6.1.22 | 18. Limp. Interna | 1d | 2021-08-02 | 2021-08-02 | 17d | Diarista [200%] | 17.6h | 418.75 | 6. Casa 6 | 0. Térreo | 18. Limp. Interna 1 | Própria | 18 | 18 | 18 |

| ID | WBS | Task | Duration | Start | Finish | Total slack | Resources | Work | Cost | Casa | Pav | Equipe | Empresa | Pacote | Cor | LB |
| --- | --- | --- | --- | --- | --- | --- | --- | --- | --- | --- | --- | --- | --- | --- | --- | --- |
| 274 | 1.3.6.2 | **1. Pav. Superior** | 18d? | 2021-08-02 | 2021-08-25 | 0d |  | 3634.4h | 114,461.15 |  |  |  |  |  |  |  |
| 275 | 1.3.6.2.1 | 2. Estrutura | 7d | 2021-08-02 | 2021-08-10 | 11d |  |  |  | 6. Casa 6 |  |  |  |  |  |  |
| 276 | 1.3.6.2.2 | 3. Alvenarias | 10d | 2021-08-02 | 2021-08-13 | 8d | servente estrutura [300%]; aux. Carpinteiro [200%]; aux. ferreiro [200%]; ferreiro [500%]; carpinteiro [200%] | 1232h | 30,006.55 | 6. Casa 6 | 1. Pav. Superior | 2. Estrutura 1 | Própria |  |  |  |
| 277 | 1.3.6.2.3 | 5. Ref. Inter. Arg (Parede) | 18d | 2021-08-02 | 2021-08-25 | 0d | pedreiro [200%]; servente [200%] | 633.6h | 10,101.74 | 6. Casa 6 | 1. Pav. Superior | 3. Alvenarias 1 | Própria |  |  |  |
| 278 | 1.3.6.2.4 | 6. Revest. Gesso (Parede + Teto) | 7d | 2021-08-02 | 2021-08-10 | 11d | pedreiro [400%]; servente [400%] | 492.8h | 5,398.69 | 6. Casa 6 | 1. Pav. Superior | 5. Ref. Inter. Arg (Parede) 1 | Própria |  |  |  |
| 279 | 1.3.6.2.5 | 7. Impermeabilização | 1d | 2021-08-02 | 2021-08-02 | 17d | gesseiro [300%]; servente | 35.2h | 2,119.41 | 6. Casa 6 | 1. Pav. Superior | 6. Revest. Gesso (Parede + Teto) 1 | Própria |  |  |  |
| 280 | 1.3.6.2.6 | 8. Contrapiso | 2d | 2021-08-02 | 2021-08-03 | 16d | aplicador de manta | 17.6h | 2,046.85 | 6. Casa 6 | 1. Pav. Superior | 7. Impermeabilização 1 | Própria |  |  |  |
| 281 | 1.3.6.2.7 | 9. Fachada | 1d? | 2021-08-02 | 2021-08-02 | 17d | pedreiro [200%]; servente | 26.4h | 2,476.11 | 6. Casa 6 | 1. Pav. Superior | 8. Contrapiso 1 | Própria |  |  |  |
| 282 | 1.3.6.2.8 | 9.1. Chapisco | 0.5d | 2021-08-02 | 2021-08-02 | 17.5d |  |  |  | 6. Casa 6 | 1. Pav. Superior | 9. Fachada 1 | Própria |  |  |  |
| 283 | 1.3.6.2.9 | 9.2. Emboço | 1.5d | 2021-08-02 | 2021-08-03 | 16.5d | pedreiro [600%]; servente [400%] | 132h | 5,131.51 | 6. Casa 6 | 1. Pav. Superior | 9. Fachada 1 | Própria |  |  |  |
| 284 | 1.3.6.2.10 | 9.3. Pint. 1 Demão | 1d | 2021-08-02 | 2021-08-02 | 17d | pedreiro [600%]; servente [400%] | 88h | 7,697.26 | 6. Casa 6 | 1. Pav. Superior | 9. Fachada 1 | Própria |  |  |  |
| 285 | 1.3.6.2.11 | 9.4. Pint. 2 Demão | 2d | 2021-08-02 | 2021-08-03 | 16d | pintor [400%]; aux.pintor [200%] | 105.6h | 1,135.92 | 6. Casa 6 | 1. Pav. Superior | 9. Fachada 1 | Própria |  |  |  |
| 286 | 1.3.6.2.12 | 10. Cer. Piso | 8d | 2021-08-02 | 2021-08-11 | 10d | pintor [400%]; aux.pintor [200%] | 422.4h | 757.28 | 6. Casa 6 | 1. Pav. Superior | 9. Fachada 1 | Própria |  |  |  |
| 287 | 1.3.6.2.13 | 11. Cer. Parede | 2d | 2021-08-02 | 2021-08-03 | 16d | pedreiro [200%]; servente | 52.8h | 19,807.17 | 6. Casa 6 | 1. Pav. Superior | 10. Cer. Piso 1 | Própria | 10 | 10 | 10 |
| 288 | 1.3.6.2.14 | 12. Forro (WC's e cozinha) | 1d | 2021-08-02 | 2021-08-02 | 17d | pedreiro [200%]; servente | 26.4h | 4,238.82 | 6. Casa 6 | 1. Pav. Superior | 11. Cer. Parede 1 | Própria | 11 | 11 | 11 |
| 289 | 1.3.6.2.15 | 13. Esq. Alumínio | 1d | 2021-08-02 | 2021-08-02 | 17d | gesseiro; servente | 17.6h | 895 | 6. Casa 6 | 1. Pav. Superior | 12. Forro (WC's e cozinha) 1 | Própria | 12 | 12 | 12 |
| 290 | 1.3.6.2.16 | 14. Portas | 2d | 2021-08-02 | 2021-08-03 | 16d | montador esquadrias [200%] | 35.2h | 8,489.61 | 6. Casa 6 | 1. Pav. Superior | 13. Esq. Alumínio 1 | Própria | 13 | 13 | 13 |
| 291 | 1.3.6.2.17 | 15. Pintura (1ª Demão) | 6d | 2021-08-02 | 2021-08-09 | 12d | marceneiro [200%] | 105.6h | 1,858.35 | 6. Casa 6 | 1. Pav. Superior | 14. Portas 1 | Própria | 14 | 14 | 14 |
| 292 | 1.3.6.2.18 | 16. Bancadas | 1d | 2021-08-02 | 2021-08-02 | 17d | pintor [400%]; aux.pintor [200%] | 52.8h | 3,764.82 | 6. Casa 6 | 1. Pav. Superior | 15. Pintura (1ª Demão) 1 | Própria | 15 | 15 | 15 |
| 293 | 1.3.6.2.19 | 17. Pintura (2ª Demão) | 4d | 2021-08-02 | 2021-08-05 | 14d | pedreiro [200%]; servente | 105.6h | 6,972.08 | 6. Casa 6 | 1. Pav. Superior | 16. Bancadas 1 | Própria | 16 | 16 | 16 |
| 294 | 1.3.6.2.20 | 18. Limp. Interna | 1d | 2021-08-02 | 2021-08-02 | 17d | pintor [400%]; aux.pintor [200%] | 52.8h | 1,563.98 | 6. Casa 6 | 1. Pav. Superior | 17. Pintura (2ª Demão) 1 | Própria | 17 | 17 | 17 |
| 295 | 1.3.6.3 | **2. Coberta** | 6d | 2021-08-02 | 2021-08-09 | 12d |  | 536.8h | 35,295.19 |  |  |  |  |  |  |  |
| 296 | 1.3.6.3.1 | 1. Alvenarias | 6d | 2021-08-02 | 2021-08-09 | 12d | pedreiro [200%]; servente [200%] | 211.2h | 9,834.12 | 6. Casa 6 | 2. Coberta | 3. Alvenarias 1 | Própria |  |  |  |
| 297 | 1.3.6.3.2 | 2. Impermeabilização | 1d | 2021-08-02 | 2021-08-02 | 17d | aplicador de manta | 8.8h | 1,296.54 | 6. Casa 6 | 2. Coberta | 7. Impermeabilização 1 | Própria |  |  |  |
| 298 | 1.3.6.3.3 | 3. Coberta | 6d | 2021-08-02 | 2021-08-09 | 12d | carpinteiro [400%]; aux. Carpinteiro [200%] | 316.8h | 24,164.53 | 6. Casa 6 | 2. Coberta | 4. Coberta 1 | Própria |  |  |  |

| ID | WBS | Task | Duration | Start | Finish | Total slack | Resources | Work | Cost | Casa | Pav | Equipe | Empresa | Pacote | Cor | LB |
| --- | --- | --- | --- | --- | --- | --- | --- | --- | --- | --- | --- | --- | --- | --- | --- | --- |
| 299 | 1.3.7 | **7. Casa 7** | 18d? | 2021-08-02 | 2021-08-25 | 0d |  | 8668h | 315,265.59 |  |  |  |  |  |  |  |
| 300 | 1.3.7.1 | **0. Térreo** | 16d? | 2021-08-02 | 2021-08-23 | 2d |  | 4496.8h | 165,509.25 |  |  |  |  |  |  |  |
| 301 | 1.3.7.1.1 | 0. Locação | 2d | 2021-08-02 | 2021-08-03 | 16d | carpinteiro; aux. Carpinteiro | 35.2h | 456.99 | 7. Casa 7 | 0. Térreo | 0. Locação 1 | Própria |  |  |  |
| 302 | 1.3.7.1.2 | 1. Fundação | 9d | 2021-08-02 | 2021-08-12 | 9d | servente estrutura [300%]; aux. Carpinteiro; aux. ferreiro; ferreiro; carpinteiro [200%] | 633.6h | 19,882.86 | 7. Casa 7 | 0. Térreo | 1. Fundação 1 | Própria |  |  |  |
| 303 | 1.3.7.1.3 | 2. Estrutura | 7d | 2021-08-02 | 2021-08-10 | 11d | servente estrutura [300%]; aux. Carpinteiro [200%]; aux. ferreiro [200%]; ferreiro [500%]; carpinteiro [200%] | 862.4h | 46,439.03 | 7. Casa 7 | 0. Térreo | 2. Estrutura 1 | Própria |  |  |  |
| 304 | 1.3.7.1.4 | 3. Alvenarias | 10d | 2021-08-02 | 2021-08-13 | 8d | pedreiro [200%]; servente [200%] | 352h | 8,388.41 | 7. Casa 7 | 0. Térreo | 3. Alvenarias 1 | Própria |  |  |  |
| 305 | 1.3.7.1.5 | 5. Ref. Inter. Arg (Parede) | 16d | 2021-08-02 | 2021-08-23 | 2d | pedreiro [400%]; servente [400%] | 1126.4h | 5,776 | 7. Casa 7 | 0. Térreo | 5. Ref. Inter. Arg (Parede) 1 | Própria |  |  |  |
| 306 | 1.3.7.1.6 | 6. Revest. Gesso (Parede + Teto) | 5d | 2021-08-02 | 2021-08-06 | 13d | gesseiro [300%]; servente | 176h | 2,119.41 | 7. Casa 7 | 0. Térreo | 6. Revest. Gesso (Parede + Teto) 1 | Própria |  |  |  |
| 307 | 1.3.7.1.7 | 7. Impermeabilização | 2d | 2021-08-02 | 2021-08-03 | 16d | aplicador de manta | 17.6h | 3,288.15 | 7. Casa 7 | 0. Térreo | 7. Impermeabilização 1 | Própria |  |  |  |
| 308 | 1.3.7.1.8 | 8. Contrapiso | 2d | 2021-08-02 | 2021-08-03 | 16d | pedreiro [200%]; servente | 52.8h | 3,735.07 | 7. Casa 7 | 0. Térreo | 8. Contrapiso 1 | Própria |  |  |  |
| 309 | 1.3.7.1.9 | 9. Fachada | 1d? | 2021-08-02 | 2021-08-02 | 17d |  |  |  | 7. Casa 7 | 0. Térreo | 9. Fachada 1 | Própria |  |  |  |
| 310 | 1.3.7.1.10 | 9.1. Chapisco | 0.5d | 2021-08-02 | 2021-08-02 | 17.5d | pedreiro [600%]; servente [400%] | 44h | 5,131.51 | 7. Casa 7 | 0. Térreo | 9. Fachada 1 | Própria |  |  |  |
| 311 | 1.3.7.1.11 | 9.2. Emboço | 1.5d | 2021-08-02 | 2021-08-03 | 16.5d | pedreiro [600%]; servente [400%] | 132h | 7,697.26 | 7. Casa 7 | 0. Térreo | 9. Fachada 1 | Própria |  |  |  |
| 312 | 1.3.7.1.12 | 9.3. Pint. 1 Demão | 1d | 2021-08-02 | 2021-08-02 | 17d | pintor [400%]; aux.pintor [200%] | 52.8h | 1,135.92 | 7. Casa 7 | 0. Térreo | 9. Fachada 1 | Própria |  |  |  |
| 313 | 1.3.7.1.13 | 9.4. Pint. 2 Demão | 2d | 2021-08-02 | 2021-08-03 | 16d | pintor [400%]; aux.pintor [200%] | 105.6h | 757.28 | 7. Casa 7 | 0. Térreo | 9. Fachada 1 | Própria |  |  |  |
| 314 | 1.3.7.1.14 | 10. Cer. Piso | 7d | 2021-08-02 | 2021-08-10 | 11d | pedreiro [200%]; servente | 184.8h | 25,485.98 | 7. Casa 7 | 0. Térreo | 10. Cer. Piso 1 | Própria | 10 | 10 | 10 |
| 315 | 1.3.7.1.15 | 11. Cer. Parede | 3d | 2021-08-02 | 2021-08-04 | 15d | pedreiro [200%]; servente | 79.2h | 4,238.82 | 7. Casa 7 | 0. Térreo | 11. Cer. Parede 1 | Própria | 11 | 11 | 11 |
| 316 | 1.3.7.1.16 | 12. Forro (WC's e cozinha) | 1d | 2021-08-02 | 2021-08-02 | 17d | gesseiro; servente | 17.6h | 635.82 | 7. Casa 7 | 0. Térreo | 12. Forro (WC's e cozinha) 1 | Própria | 12 | 12 | 12 |
| 317 | 1.3.7.1.17 | 13. Esq. Alumínio | 1d | 2021-08-02 | 2021-08-02 | 17d | montador esquadrias [200%] | 17.6h | 11,307.22 | 7. Casa 7 | 0. Térreo | 13. Esq. Alumínio 1 | Própria | 13 | 13 | 13 |
| 318 | 1.3.7.1.18 | 14. Portas | 2d | 2021-08-02 | 2021-08-03 | 16d | marceneiro [200%] | 35.2h | 2,827.85 | 7. Casa 7 | 0. Térreo | 14. Portas 1 | Própria | 14 | 14 | 14 |
| 319 | 1.3.7.1.19 | 15. Pintura (1ª Demão) | 6d | 2021-08-02 | 2021-08-09 | 12d | pintor [400%]; aux.pintor [200%] | 316.8h | 3,764.82 | 7. Casa 7 | 0. Térreo | 15. Pintura (1ª Demão) 1 | Própria | 15 | 15 | 15 |
| 320 | 1.3.7.1.20 | 16. Bancadas | 1d | 2021-08-02 | 2021-08-02 | 17d | pedreiro [200%]; servente | 26.4h | 10,458.12 | 7. Casa 7 | 0. Térreo | 16. Bancadas 1 | Própria | 16 | 16 | 16 |
| 321 | 1.3.7.1.21 | 17. Pintura (2ª Demão) | 4d | 2021-08-02 | 2021-08-05 | 14d | pintor [400%]; aux.pintor [200%] | 211.2h | 1,563.98 | 7. Casa 7 | 0. Térreo | 17. Pintura (2ª Demão) 1 | Própria | 17 | 17 | 17 |
| 322 | 1.3.7.1.22 | 18. Limp. Interna | 1d | 2021-08-02 | 2021-08-02 | 17d | Diarista [200%] | 17.6h | 418.75 | 7. Casa 7 | 0. Térreo | 18. Limp. Interna 1 | Própria | 18 | 18 | 18 |

| ID | WBS | Task | Duration | Start | Finish | Total slack | Resources | Work | Cost | Casa | Pav | Equipe | Empresa | Pacote | Cor | LB |
| --- | --- | --- | --- | --- | --- | --- | --- | --- | --- | --- | --- | --- | --- | --- | --- | --- |
| 323 | 1.3.7.2 | **1. Pav. Superior** | 18d? | 2021-08-02 | 2021-08-25 | 0d |  | 3634.4h | 114,461.15 |  |  |  |  |  |  |  |
| 324 | 1.3.7.2.1 | 2. Estrutura | 7d | 2021-08-02 | 2021-08-10 | 11d |  |  |  | 7. Casa 7 |  |  |  |  |  |  |
| 325 | 1.3.7.2.2 | 3. Alvenarias | 10d | 2021-08-02 | 2021-08-13 | 8d | servente estrutura [300%]; aux. Carpinteiro [200%]; aux. ferreiro [200%]; ferreiro [500%]; carpinteiro [200%] | 1232h | 30,006.55 | 7. Casa 7 | 1. Pav. Superior | 2. Estrutura 1 | Própria |  |  |  |
| 326 | 1.3.7.2.3 | 5. Ref. Inter. Arg (Parede) | 18d | 2021-08-02 | 2021-08-25 | 0d | pedreiro [200%]; servente [200%] | 633.6h | 10,101.74 | 7. Casa 7 | 1. Pav. Superior | 3. Alvenarias 1 | Própria |  |  |  |
| 327 | 1.3.7.2.4 | 6. Revest. Gesso (Parede + Teto) | 7d | 2021-08-02 | 2021-08-10 | 11d | pedreiro [400%]; servente [400%] | 492.8h | 5,398.69 | 7. Casa 7 | 1. Pav. Superior | 5. Ref. Inter. Arg (Parede) 1 | Própria |  |  |  |
| 328 | 1.3.7.2.5 | 7. Impermeabilização | 1d | 2021-08-02 | 2021-08-02 | 17d | gesseiro [300%]; servente | 35.2h | 2,119.41 | 7. Casa 7 | 1. Pav. Superior | 6. Revest. Gesso (Parede + Teto) 1 | Própria |  |  |  |
| 329 | 1.3.7.2.6 | 8. Contrapiso | 2d | 2021-08-02 | 2021-08-03 | 16d | aplicador de manta | 17.6h | 2,046.85 | 7. Casa 7 | 1. Pav. Superior | 7. Impermeabilização 1 | Própria |  |  |  |
| 330 | 1.3.7.2.7 | 9. Fachada | 1d? | 2021-08-02 | 2021-08-02 | 17d | pedreiro [200%]; servente | 26.4h | 2,476.11 | 7. Casa 7 | 1. Pav. Superior | 8. Contrapiso 1 | Própria |  |  |  |
| 331 | 1.3.7.2.8 | 9.1. Chapisco | 0.5d | 2021-08-02 | 2021-08-02 | 17.5d |  |  |  | 7. Casa 7 | 1. Pav. Superior | 9. Fachada 1 | Própria |  |  |  |
| 332 | 1.3.7.2.9 | 9.2. Emboço | 1.5d | 2021-08-02 | 2021-08-03 | 16.5d | pedreiro [600%]; servente [400%] | 132h | 5,131.51 | 7. Casa 7 | 1. Pav. Superior | 9. Fachada 1 | Própria |  |  |  |
| 333 | 1.3.7.2.10 | 9.3. Pint. 1 Demão | 1d | 2021-08-02 | 2021-08-02 | 17d | pedreiro [600%]; servente [400%] | 88h | 7,697.26 | 7. Casa 7 | 1. Pav. Superior | 9. Fachada 1 | Própria |  |  |  |
| 334 | 1.3.7.2.11 | 9.4. Pint. 2 Demão | 2d | 2021-08-02 | 2021-08-03 | 16d | pintor [400%]; aux.pintor [200%] | 105.6h | 1,135.92 | 7. Casa 7 | 1. Pav. Superior | 9. Fachada 1 | Própria |  |  |  |
| 335 | 1.3.7.2.12 | 10. Cer. Piso | 8d | 2021-08-02 | 2021-08-11 | 10d | pintor [400%]; aux.pintor [200%] | 422.4h | 757.28 | 7. Casa 7 | 1. Pav. Superior | 9. Fachada 1 | Própria |  |  |  |
| 336 | 1.3.7.2.13 | 11. Cer. Parede | 2d | 2021-08-02 | 2021-08-03 | 16d | pedreiro [200%]; servente | 52.8h | 19,807.17 | 7. Casa 7 | 1. Pav. Superior | 10. Cer. Piso 1 | Própria | 10 | 10 | 10 |
| 337 | 1.3.7.2.14 | 12. Forro (WC's e cozinha) | 1d | 2021-08-02 | 2021-08-02 | 17d | pedreiro [200%]; servente | 26.4h | 4,238.82 | 7. Casa 7 | 1. Pav. Superior | 11. Cer. Parede 1 | Própria | 11 | 11 | 11 |
| 338 | 1.3.7.2.15 | 13. Esq. Alumínio | 1d | 2021-08-02 | 2021-08-02 | 17d | gesseiro; servente | 17.6h | 895 | 7. Casa 7 | 1. Pav. Superior | 12. Forro (WC's e cozinha) 1 | Própria | 12 | 12 | 12 |
| 339 | 1.3.7.2.16 | 14. Portas | 2d | 2021-08-02 | 2021-08-03 | 16d | montador esquadrias [200%] | 35.2h | 8,489.61 | 7. Casa 7 | 1. Pav. Superior | 13. Esq. Alumínio 1 | Própria | 13 | 13 | 13 |
| 340 | 1.3.7.2.17 | 15. Pintura (1ª Demão) | 6d | 2021-08-02 | 2021-08-09 | 12d | marceneiro [200%] | 105.6h | 1,858.35 | 7. Casa 7 | 1. Pav. Superior | 14. Portas 1 | Própria | 14 | 14 | 14 |
| 341 | 1.3.7.2.18 | 16. Bancadas | 1d | 2021-08-02 | 2021-08-02 | 17d | pintor [400%]; aux.pintor [200%] | 52.8h | 3,764.82 | 7. Casa 7 | 1. Pav. Superior | 15. Pintura (1ª Demão) 1 | Própria | 15 | 15 | 15 |
| 342 | 1.3.7.2.19 | 17. Pintura (2ª Demão) | 4d | 2021-08-02 | 2021-08-05 | 14d | pedreiro [200%]; servente | 105.6h | 6,972.08 | 7. Casa 7 | 1. Pav. Superior | 16. Bancadas 1 | Própria | 16 | 16 | 16 |
| 343 | 1.3.7.2.20 | 18. Limp. Interna | 1d | 2021-08-02 | 2021-08-02 | 17d | pintor [400%]; aux.pintor [200%] | 52.8h | 1,563.98 | 7. Casa 7 | 1. Pav. Superior | 17. Pintura (2ª Demão) 1 | Própria | 17 | 17 | 17 |
| 344 | 1.3.7.3 | **2. Coberta** | 6d | 2021-08-02 | 2021-08-09 | 12d |  | 536.8h | 35,295.19 |  |  |  |  |  |  |  |
| 345 | 1.3.7.3.1 | 1. Alvenarias | 6d | 2021-08-02 | 2021-08-09 | 12d | pedreiro [200%]; servente [200%] | 211.2h | 9,834.12 | 7. Casa 7 | 2. Coberta | 3. Alvenarias 1 | Própria |  |  |  |
| 346 | 1.3.7.3.2 | 2. Impermeabilização | 1d | 2021-08-02 | 2021-08-02 | 17d | aplicador de manta | 8.8h | 1,296.54 | 7. Casa 7 | 2. Coberta | 7. Impermeabilização 1 | Própria |  |  |  |
| 347 | 1.3.7.3.3 | 3. Coberta | 6d | 2021-08-02 | 2021-08-09 | 12d | carpinteiro [400%]; aux. Carpinteiro [200%] | 316.8h | 24,164.53 | 7. Casa 7 | 2. Coberta | 4. Coberta 1 | Própria |  |  |  |

| ID | WBS | Task | Duration | Start | Finish | Total slack | Resources | Work | Cost | Casa | Pav | Equipe | Empresa | Pacote | Cor | LB |
| --- | --- | --- | --- | --- | --- | --- | --- | --- | --- | --- | --- | --- | --- | --- | --- | --- |
| 348 | 1.3.8 | **8. Casa 8** | 18d? | 2021-08-02 | 2021-08-25 | 0d |  | 8668h | 315,265.59 |  |  |  |  |  |  |  |
| 349 | 1.3.8.1 | **0. Térreo** | 16d? | 2021-08-02 | 2021-08-23 | 2d |  | 4496.8h | 165,509.25 |  |  |  |  |  |  |  |
| 350 | 1.3.8.1.1 | 0. Locação | 2d | 2021-08-02 | 2021-08-03 | 16d | carpinteiro; aux. Carpinteiro | 35.2h | 456.99 | 8. Casa 8 | 0. Térreo | 0. Locação 1 | Própria |  |  |  |
| 351 | 1.3.8.1.2 | 1. Fundação | 9d | 2021-08-02 | 2021-08-12 | 9d | servente estrutura [300%]; aux. Carpinteiro; aux. ferreiro; ferreiro; carpinteiro [200%] | 633.6h | 19,882.86 | 8. Casa 8 | 0. Térreo | 1. Fundação 1 | Própria |  |  |  |
| 352 | 1.3.8.1.3 | 2. Estrutura | 7d | 2021-08-02 | 2021-08-10 | 11d | servente estrutura [300%]; aux. Carpinteiro [200%]; aux. ferreiro [200%]; ferreiro [500%]; carpinteiro [200%] | 862.4h | 46,439.03 | 8. Casa 8 | 0. Térreo | 2. Estrutura 1 | Própria |  |  |  |
| 353 | 1.3.8.1.4 | 3. Alvenarias | 10d | 2021-08-02 | 2021-08-13 | 8d | pedreiro [200%]; servente [200%] | 352h | 8,388.41 | 8. Casa 8 | 0. Térreo | 3. Alvenarias 1 | Própria |  |  |  |
| 354 | 1.3.8.1.5 | 5. Ref. Inter. Arg (Parede) | 16d | 2021-08-02 | 2021-08-23 | 2d | pedreiro [400%]; servente [400%] | 1126.4h | 5,776 | 8. Casa 8 | 0. Térreo | 5. Ref. Inter. Arg (Parede) 1 | Própria |  |  |  |
| 355 | 1.3.8.1.6 | 6. Revest. Gesso (Parede + Teto) | 5d | 2021-08-02 | 2021-08-06 | 13d | gesseiro [300%]; servente | 176h | 2,119.41 | 8. Casa 8 | 0. Térreo | 6. Revest. Gesso (Parede + Teto) 1 | Própria |  |  |  |
| 356 | 1.3.8.1.7 | 7. Impermeabilização | 2d | 2021-08-02 | 2021-08-03 | 16d | aplicador de manta | 17.6h | 3,288.15 | 8. Casa 8 | 0. Térreo | 7. Impermeabilização 1 | Própria |  |  |  |
| 357 | 1.3.8.1.8 | 8. Contrapiso | 2d | 2021-08-02 | 2021-08-03 | 16d | pedreiro [200%]; servente | 52.8h | 3,735.07 | 8. Casa 8 | 0. Térreo | 8. Contrapiso 1 | Própria |  |  |  |
| 358 | 1.3.8.1.9 | 9. Fachada | 1d? | 2021-08-02 | 2021-08-02 | 17d |  |  |  | 8. Casa 8 | 0. Térreo | 9. Fachada 1 | Própria |  |  |  |
| 359 | 1.3.8.1.10 | 9.1. Chapisco | 0.5d | 2021-08-02 | 2021-08-02 | 17.5d | pedreiro [600%]; servente [400%] | 44h | 5,131.51 | 8. Casa 8 | 0. Térreo | 9. Fachada 1 | Própria |  |  |  |
| 360 | 1.3.8.1.11 | 9.2. Emboço | 1.5d | 2021-08-02 | 2021-08-03 | 16.5d | pedreiro [600%]; servente [400%] | 132h | 7,697.26 | 8. Casa 8 | 0. Térreo | 9. Fachada 1 | Própria |  |  |  |
| 361 | 1.3.8.1.12 | 9.3. Pint. 1 Demão | 1d | 2021-08-02 | 2021-08-02 | 17d | pintor [400%]; aux.pintor [200%] | 52.8h | 1,135.92 | 8. Casa 8 | 0. Térreo | 9. Fachada 1 | Própria |  |  |  |
| 362 | 1.3.8.1.13 | 9.4. Pint. 2 Demão | 2d | 2021-08-02 | 2021-08-03 | 16d | pintor [400%]; aux.pintor [200%] | 105.6h | 757.28 | 8. Casa 8 | 0. Térreo | 9. Fachada 1 | Própria |  |  |  |
| 363 | 1.3.8.1.14 | 10. Cer. Piso | 7d | 2021-08-02 | 2021-08-10 | 11d | pedreiro [200%]; servente | 184.8h | 25,485.98 | 8. Casa 8 | 0. Térreo | 10. Cer. Piso 1 | Própria | 10 | 10 | 10 |
| 364 | 1.3.8.1.15 | 11. Cer. Parede | 3d | 2021-08-02 | 2021-08-04 | 15d | pedreiro [200%]; servente | 79.2h | 4,238.82 | 8. Casa 8 | 0. Térreo | 11. Cer. Parede 1 | Própria | 11 | 11 | 11 |
| 365 | 1.3.8.1.16 | 12. Forro (WC's e cozinha) | 1d | 2021-08-02 | 2021-08-02 | 17d | gesseiro; servente | 17.6h | 635.82 | 8. Casa 8 | 0. Térreo | 12. Forro (WC's e cozinha) 1 | Própria | 12 | 12 | 12 |
| 366 | 1.3.8.1.17 | 13. Esq. Alumínio | 1d | 2021-08-02 | 2021-08-02 | 17d | montador esquadrias [200%] | 17.6h | 11,307.22 | 8. Casa 8 | 0. Térreo | 13. Esq. Alumínio 1 | Própria | 13 | 13 | 13 |
| 367 | 1.3.8.1.18 | 14. Portas | 2d | 2021-08-02 | 2021-08-03 | 16d | marceneiro [200%] | 35.2h | 2,827.85 | 8. Casa 8 | 0. Térreo | 14. Portas 1 | Própria | 14 | 14 | 14 |
| 368 | 1.3.8.1.19 | 15. Pintura (1ª Demão) | 6d | 2021-08-02 | 2021-08-09 | 12d | pintor [400%]; aux.pintor [200%] | 316.8h | 3,764.82 | 8. Casa 8 | 0. Térreo | 15. Pintura (1ª Demão) 1 | Própria | 15 | 15 | 15 |
| 369 | 1.3.8.1.20 | 16. Bancadas | 1d | 2021-08-02 | 2021-08-02 | 17d | pedreiro [200%]; servente | 26.4h | 10,458.12 | 8. Casa 8 | 0. Térreo | 16. Bancadas 1 | Própria | 16 | 16 | 16 |
| 370 | 1.3.8.1.21 | 17. Pintura (2ª Demão) | 4d | 2021-08-02 | 2021-08-05 | 14d | pintor [400%]; aux.pintor [200%] | 211.2h | 1,563.98 | 8. Casa 8 | 0. Térreo | 17. Pintura (2ª Demão) 1 | Própria | 17 | 17 | 17 |
| 371 | 1.3.8.1.22 | 18. Limp. Interna | 1d | 2021-08-02 | 2021-08-02 | 17d | Diarista [200%] | 17.6h | 418.75 | 8. Casa 8 | 0. Térreo | 18. Limp. Interna 1 | Própria | 18 | 18 | 18 |

| ID | WBS | Task | Duration | Start | Finish | Total slack | Resources | Work | Cost | Casa | Pav | Equipe | Empresa | Pacote | Cor | LB |
| --- | --- | --- | --- | --- | --- | --- | --- | --- | --- | --- | --- | --- | --- | --- | --- | --- |
| 372 | 1.3.8.2 | **1. Pav. Superior** | 18d? | 2021-08-02 | 2021-08-25 | 0d |  | 3634.4h | 114,461.15 |  |  |  |  |  |  |  |
| 373 | 1.3.8.2.1 | 2. Estrutura | 7d | 2021-08-02 | 2021-08-10 | 11d |  |  |  | 8. Casa 8 |  |  |  |  |  |  |
| 374 | 1.3.8.2.2 | 3. Alvenarias | 10d | 2021-08-02 | 2021-08-13 | 8d | servente estrutura [300%]; aux. Carpinteiro [200%]; aux. ferreiro [200%]; ferreiro [500%]; carpinteiro [200%] | 1232h | 30,006.55 | 8. Casa 8 | 1. Pav. Superior | 2. Estrutura 1 | Própria |  |  |  |
| 375 | 1.3.8.2.3 | 5. Ref. Inter. Arg (Parede) | 18d | 2021-08-02 | 2021-08-25 | 0d | pedreiro [200%]; servente [200%] | 633.6h | 10,101.74 | 8. Casa 8 | 1. Pav. Superior | 3. Alvenarias 1 | Própria |  |  |  |
| 376 | 1.3.8.2.4 | 6. Revest. Gesso (Parede + Teto) | 7d | 2021-08-02 | 2021-08-10 | 11d | pedreiro [400%]; servente [400%] | 492.8h | 5,398.69 | 8. Casa 8 | 1. Pav. Superior | 5. Ref. Inter. Arg (Parede) 1 | Própria |  |  |  |
| 377 | 1.3.8.2.5 | 7. Impermeabilização | 1d | 2021-08-02 | 2021-08-02 | 17d | gesseiro [300%]; servente | 35.2h | 2,119.41 | 8. Casa 8 | 1. Pav. Superior | 6. Revest. Gesso (Parede + Teto) 1 | Própria |  |  |  |
| 378 | 1.3.8.2.6 | 8. Contrapiso | 2d | 2021-08-02 | 2021-08-03 | 16d | aplicador de manta | 17.6h | 2,046.85 | 8. Casa 8 | 1. Pav. Superior | 7. Impermeabilização 1 | Própria |  |  |  |
| 379 | 1.3.8.2.7 | 9. Fachada | 1d? | 2021-08-02 | 2021-08-02 | 17d | pedreiro [200%]; servente | 26.4h | 2,476.11 | 8. Casa 8 | 1. Pav. Superior | 8. Contrapiso 1 | Própria |  |  |  |
| 380 | 1.3.8.2.8 | 9.1. Chapisco | 0.5d | 2021-08-02 | 2021-08-02 | 17.5d |  |  |  | 8. Casa 8 | 1. Pav. Superior | 9. Fachada 1 | Própria |  |  |  |
| 381 | 1.3.8.2.9 | 9.2. Emboço | 1.5d | 2021-08-02 | 2021-08-03 | 16.5d | pedreiro [600%]; servente [400%] | 132h | 5,131.51 | 8. Casa 8 | 1. Pav. Superior | 9. Fachada 1 | Própria |  |  |  |
| 382 | 1.3.8.2.10 | 9.3. Pint. 1 Demão | 1d | 2021-08-02 | 2021-08-02 | 17d | pedreiro [600%]; servente [400%] | 88h | 7,697.26 | 8. Casa 8 | 1. Pav. Superior | 9. Fachada 1 | Própria |  |  |  |
| 383 | 1.3.8.2.11 | 9.4. Pint. 2 Demão | 2d | 2021-08-02 | 2021-08-03 | 16d | pintor [400%]; aux.pintor [200%] | 105.6h | 1,135.92 | 8. Casa 8 | 1. Pav. Superior | 9. Fachada 1 | Própria |  |  |  |
| 384 | 1.3.8.2.12 | 10. Cer. Piso | 8d | 2021-08-02 | 2021-08-11 | 10d | pintor [400%]; aux.pintor [200%] | 422.4h | 757.28 | 8. Casa 8 | 1. Pav. Superior | 9. Fachada 1 | Própria |  |  |  |
| 385 | 1.3.8.2.13 | 11. Cer. Parede | 2d | 2021-08-02 | 2021-08-03 | 16d | pedreiro [200%]; servente | 52.8h | 19,807.17 | 8. Casa 8 | 1. Pav. Superior | 10. Cer. Piso 1 | Própria | 10 | 10 | 10 |
| 386 | 1.3.8.2.14 | 12. Forro (WC's e cozinha) | 1d | 2021-08-02 | 2021-08-02 | 17d | pedreiro [200%]; servente | 26.4h | 4,238.82 | 8. Casa 8 | 1. Pav. Superior | 11. Cer. Parede 1 | Própria | 11 | 11 | 11 |
| 387 | 1.3.8.2.15 | 13. Esq. Alumínio | 1d | 2021-08-02 | 2021-08-02 | 17d | gesseiro; servente | 17.6h | 895 | 8. Casa 8 | 1. Pav. Superior | 12. Forro (WC's e cozinha) 1 | Própria | 12 | 12 | 12 |
| 388 | 1.3.8.2.16 | 14. Portas | 2d | 2021-08-02 | 2021-08-03 | 16d | montador esquadrias [200%] | 35.2h | 8,489.61 | 8. Casa 8 | 1. Pav. Superior | 13. Esq. Alumínio 1 | Própria | 13 | 13 | 13 |
| 389 | 1.3.8.2.17 | 15. Pintura (1ª Demão) | 6d | 2021-08-02 | 2021-08-09 | 12d | marceneiro [200%] | 105.6h | 1,858.35 | 8. Casa 8 | 1. Pav. Superior | 14. Portas 1 | Própria | 14 | 14 | 14 |
| 390 | 1.3.8.2.18 | 16. Bancadas | 1d | 2021-08-02 | 2021-08-02 | 17d | pintor [400%]; aux.pintor [200%] | 52.8h | 3,764.82 | 8. Casa 8 | 1. Pav. Superior | 15. Pintura (1ª Demão) 1 | Própria | 15 | 15 | 15 |
| 391 | 1.3.8.2.19 | 17. Pintura (2ª Demão) | 4d | 2021-08-02 | 2021-08-05 | 14d | pedreiro [200%]; servente | 105.6h | 6,972.08 | 8. Casa 8 | 1. Pav. Superior | 16. Bancadas 1 | Própria | 16 | 16 | 16 |
| 392 | 1.3.8.2.20 | 18. Limp. Interna | 1d | 2021-08-02 | 2021-08-02 | 17d | pintor [400%]; aux.pintor [200%] | 52.8h | 1,563.98 | 8. Casa 8 | 1. Pav. Superior | 17. Pintura (2ª Demão) 1 | Própria | 17 | 17 | 17 |
| 393 | 1.3.8.3 | **2. Coberta** | 6d | 2021-08-02 | 2021-08-09 | 12d |  | 536.8h | 35,295.19 |  |  |  |  |  |  |  |
| 394 | 1.3.8.3.1 | 1. Alvenarias | 6d | 2021-08-02 | 2021-08-09 | 12d | pedreiro [200%]; servente [200%] | 211.2h | 9,834.12 | 8. Casa 8 | 2. Coberta | 3. Alvenarias 1 | Própria |  |  |  |
| 395 | 1.3.8.3.2 | 2. Impermeabilização | 1d | 2021-08-02 | 2021-08-02 | 17d | aplicador de manta | 8.8h | 1,296.54 | 8. Casa 8 | 2. Coberta | 7. Impermeabilização 1 | Própria |  |  |  |
| 396 | 1.3.8.3.3 | 3. Coberta | 6d | 2021-08-02 | 2021-08-09 | 12d | carpinteiro [400%]; aux. Carpinteiro [200%] | 316.8h | 24,164.53 | 8. Casa 8 | 2. Coberta | 4. Coberta 1 | Própria |  |  |  |

| ID | WBS | Task | Duration | Start | Finish | Total slack | Resources | Work | Cost | Casa | Pav | Equipe | Empresa | Pacote | Cor | LB |
| --- | --- | --- | --- | --- | --- | --- | --- | --- | --- | --- | --- | --- | --- | --- | --- | --- |
| 397 | 1.3.9 | **9. Casa 9** | 18d? | 2021-08-02 | 2021-08-25 | 0d |  | 8668h | 315,265.59 |  |  |  |  |  |  |  |
| 398 | 1.3.9.1 | **0. Térreo** | 16d? | 2021-08-02 | 2021-08-23 | 2d |  | 4496.8h | 165,509.25 |  |  |  |  |  |  |  |
| 399 | 1.3.9.1.1 | 0. Locação | 2d | 2021-08-02 | 2021-08-03 | 16d | carpinteiro; aux. Carpinteiro | 35.2h | 456.99 | 9. Casa 9 | 0. Térreo | 0. Locação 1 | Própria |  |  |  |
| 400 | 1.3.9.1.2 | 1. Fundação | 9d | 2021-08-02 | 2021-08-12 | 9d | servente estrutura [300%]; aux. Carpinteiro; aux. ferreiro; ferreiro; carpinteiro [200%] | 633.6h | 19,882.86 | 9. Casa 9 | 0. Térreo | 1. Fundação 1 | Própria |  |  |  |
| 401 | 1.3.9.1.3 | 2. Estrutura | 7d | 2021-08-02 | 2021-08-10 | 11d | servente estrutura [300%]; aux. Carpinteiro [200%]; aux. ferreiro [200%]; ferreiro [500%]; carpinteiro [200%] | 862.4h | 46,439.03 | 9. Casa 9 | 0. Térreo | 2. Estrutura 1 | Própria |  |  |  |
| 402 | 1.3.9.1.4 | 3. Alvenarias | 10d | 2021-08-02 | 2021-08-13 | 8d | pedreiro [200%]; servente [200%] | 352h | 8,388.41 | 9. Casa 9 | 0. Térreo | 3. Alvenarias 1 | Própria |  |  |  |
| 403 | 1.3.9.1.5 | 5. Ref. Inter. Arg (Parede) | 16d | 2021-08-02 | 2021-08-23 | 2d | pedreiro [400%]; servente [400%] | 1126.4h | 5,776 | 9. Casa 9 | 0. Térreo | 5. Ref. Inter. Arg (Parede) 1 | Própria |  |  |  |
| 404 | 1.3.9.1.6 | 6. Revest. Gesso (Parede + Teto) | 5d | 2021-08-02 | 2021-08-06 | 13d | gesseiro [300%]; servente | 176h | 2,119.41 | 9. Casa 9 | 0. Térreo | 6. Revest. Gesso (Parede + Teto) 1 | Própria |  |  |  |
| 405 | 1.3.9.1.7 | 7. Impermeabilização | 2d | 2021-08-02 | 2021-08-03 | 16d | aplicador de manta | 17.6h | 3,288.15 | 9. Casa 9 | 0. Térreo | 7. Impermeabilização 1 | Própria |  |  |  |
| 406 | 1.3.9.1.8 | 8. Contrapiso | 2d | 2021-08-02 | 2021-08-03 | 16d | pedreiro [200%]; servente | 52.8h | 3,735.07 | 9. Casa 9 | 0. Térreo | 8. Contrapiso 1 | Própria |  |  |  |
| 407 | 1.3.9.1.9 | 9. Fachada | 1d? | 2021-08-02 | 2021-08-02 | 17d |  |  |  | 9. Casa 9 | 0. Térreo | 9. Fachada 1 | Própria |  |  |  |
| 408 | 1.3.9.1.10 | 9.1. Chapisco | 0.5d | 2021-08-02 | 2021-08-02 | 17.5d | pedreiro [600%]; servente [400%] | 44h | 5,131.51 | 9. Casa 9 | 0. Térreo | 9. Fachada 1 | Própria |  |  |  |
| 409 | 1.3.9.1.11 | 9.2. Emboço | 1.5d | 2021-08-02 | 2021-08-03 | 16.5d | pedreiro [600%]; servente [400%] | 132h | 7,697.26 | 9. Casa 9 | 0. Térreo | 9. Fachada 1 | Própria |  |  |  |
| 410 | 1.3.9.1.12 | 9.3. Pint. 1 Demão | 1d | 2021-08-02 | 2021-08-02 | 17d | pintor [400%]; aux.pintor [200%] | 52.8h | 1,135.92 | 9. Casa 9 | 0. Térreo | 9. Fachada 1 | Própria |  |  |  |
| 411 | 1.3.9.1.13 | 9.4. Pint. 2 Demão | 2d | 2021-08-02 | 2021-08-03 | 16d | pintor [400%]; aux.pintor [200%] | 105.6h | 757.28 | 9. Casa 9 | 0. Térreo | 9. Fachada 1 | Própria |  |  |  |
| 412 | 1.3.9.1.14 | 10. Cer. Piso | 7d | 2021-08-02 | 2021-08-10 | 11d | pedreiro [200%]; servente | 184.8h | 25,485.98 | 9. Casa 9 | 0. Térreo | 10. Cer. Piso 1 | Própria | 10 | 10 | 10 |
| 413 | 1.3.9.1.15 | 11. Cer. Parede | 3d | 2021-08-02 | 2021-08-04 | 15d | pedreiro [200%]; servente | 79.2h | 4,238.82 | 9. Casa 9 | 0. Térreo | 11. Cer. Parede 1 | Própria | 11 | 11 | 11 |
| 414 | 1.3.9.1.16 | 12. Forro (WC's e cozinha) | 1d | 2021-08-02 | 2021-08-02 | 17d | gesseiro; servente | 17.6h | 635.82 | 9. Casa 9 | 0. Térreo | 12. Forro (WC's e cozinha) 1 | Própria | 12 | 12 | 12 |
| 415 | 1.3.9.1.17 | 13. Esq. Alumínio | 1d | 2021-08-02 | 2021-08-02 | 17d | montador esquadrias [200%] | 17.6h | 11,307.22 | 9. Casa 9 | 0. Térreo | 13. Esq. Alumínio 1 | Própria | 13 | 13 | 13 |
| 416 | 1.3.9.1.18 | 14. Portas | 2d | 2021-08-02 | 2021-08-03 | 16d | marceneiro [200%] | 35.2h | 2,827.85 | 9. Casa 9 | 0. Térreo | 14. Portas 1 | Própria | 14 | 14 | 14 |
| 417 | 1.3.9.1.19 | 15. Pintura (1ª Demão) | 6d | 2021-08-02 | 2021-08-09 | 12d | pintor [400%]; aux.pintor [200%] | 316.8h | 3,764.82 | 9. Casa 9 | 0. Térreo | 15. Pintura (1ª Demão) 1 | Própria | 15 | 15 | 15 |
| 418 | 1.3.9.1.20 | 16. Bancadas | 1d | 2021-08-02 | 2021-08-02 | 17d | pedreiro [200%]; servente | 26.4h | 10,458.12 | 9. Casa 9 | 0. Térreo | 16. Bancadas 1 | Própria | 16 | 16 | 16 |
| 419 | 1.3.9.1.21 | 17. Pintura (2ª Demão) | 4d | 2021-08-02 | 2021-08-05 | 14d | pintor [400%]; aux.pintor [200%] | 211.2h | 1,563.98 | 9. Casa 9 | 0. Térreo | 17. Pintura (2ª Demão) 1 | Própria | 17 | 17 | 17 |
| 420 | 1.3.9.1.22 | 18. Limp. Interna | 1d | 2021-08-02 | 2021-08-02 | 17d | Diarista [200%] | 17.6h | 418.75 | 9. Casa 9 | 0. Térreo | 18. Limp. Interna 1 | Própria | 18 | 18 | 18 |

| ID | WBS | Task | Duration | Start | Finish | Total slack | Resources | Work | Cost | Casa | Pav | Equipe | Empresa | Pacote | Cor | LB |
| --- | --- | --- | --- | --- | --- | --- | --- | --- | --- | --- | --- | --- | --- | --- | --- | --- |
| 421 | 1.3.9.2 | **1. Pav. Superior** | 18d? | 2021-08-02 | 2021-08-25 | 0d |  | 3634.4h | 114,461.15 |  |  |  |  |  |  |  |
| 422 | 1.3.9.2.1 | 2. Estrutura | 7d | 2021-08-02 | 2021-08-10 | 11d |  |  |  | 9. Casa 9 |  |  |  |  |  |  |
| 423 | 1.3.9.2.2 | 3. Alvenarias | 10d | 2021-08-02 | 2021-08-13 | 8d | servente estrutura [300%]; aux. Carpinteiro [200%]; aux. ferreiro [200%]; ferreiro [500%]; carpinteiro [200%] | 1232h | 30,006.55 | 9. Casa 9 | 1. Pav. Superior | 2. Estrutura 1 | Própria |  |  |  |
| 424 | 1.3.9.2.3 | 5. Ref. Inter. Arg (Parede) | 18d | 2021-08-02 | 2021-08-25 | 0d | pedreiro [200%]; servente [200%] | 633.6h | 10,101.74 | 9. Casa 9 | 1. Pav. Superior | 3. Alvenarias 1 | Própria |  |  |  |
| 425 | 1.3.9.2.4 | 6. Revest. Gesso (Parede + Teto) | 7d | 2021-08-02 | 2021-08-10 | 11d | pedreiro [400%]; servente [400%] | 492.8h | 5,398.69 | 9. Casa 9 | 1. Pav. Superior | 5. Ref. Inter. Arg (Parede) 1 | Própria |  |  |  |
| 426 | 1.3.9.2.5 | 7. Impermeabilização | 1d | 2021-08-02 | 2021-08-02 | 17d | gesseiro [300%]; servente | 35.2h | 2,119.41 | 9. Casa 9 | 1. Pav. Superior | 6. Revest. Gesso (Parede + Teto) 1 | Própria |  |  |  |
| 427 | 1.3.9.2.6 | 8. Contrapiso | 2d | 2021-08-02 | 2021-08-03 | 16d | aplicador de manta | 17.6h | 2,046.85 | 9. Casa 9 | 1. Pav. Superior | 7. Impermeabilização 1 | Própria |  |  |  |
| 428 | 1.3.9.2.7 | 9. Fachada | 1d? | 2021-08-02 | 2021-08-02 | 17d | pedreiro [200%]; servente | 26.4h | 2,476.11 | 9. Casa 9 | 1. Pav. Superior | 8. Contrapiso 1 | Própria |  |  |  |
| 429 | 1.3.9.2.8 | 9.1. Chapisco | 0.5d | 2021-08-02 | 2021-08-02 | 17.5d |  |  |  | 9. Casa 9 | 1. Pav. Superior | 9. Fachada 1 | Própria |  |  |  |
| 430 | 1.3.9.2.9 | 9.2. Emboço | 1.5d | 2021-08-02 | 2021-08-03 | 16.5d | pedreiro [600%]; servente [400%] | 132h | 5,131.51 | 9. Casa 9 | 1. Pav. Superior | 9. Fachada 1 | Própria |  |  |  |
| 431 | 1.3.9.2.10 | 9.3. Pint. 1 Demão | 1d | 2021-08-02 | 2021-08-02 | 17d | pedreiro [600%]; servente [400%] | 88h | 7,697.26 | 9. Casa 9 | 1. Pav. Superior | 9. Fachada 1 | Própria |  |  |  |
| 432 | 1.3.9.2.11 | 9.4. Pint. 2 Demão | 2d | 2021-08-02 | 2021-08-03 | 16d | pintor [400%]; aux.pintor [200%] | 105.6h | 1,135.92 | 9. Casa 9 | 1. Pav. Superior | 9. Fachada 1 | Própria |  |  |  |
| 433 | 1.3.9.2.12 | 10. Cer. Piso | 8d | 2021-08-02 | 2021-08-11 | 10d | pintor [400%]; aux.pintor [200%] | 422.4h | 757.28 | 9. Casa 9 | 1. Pav. Superior | 9. Fachada 1 | Própria |  |  |  |
| 434 | 1.3.9.2.13 | 11. Cer. Parede | 2d | 2021-08-02 | 2021-08-03 | 16d | pedreiro [200%]; servente | 52.8h | 19,807.17 | 9. Casa 9 | 1. Pav. Superior | 10. Cer. Piso 1 | Própria | 10 | 10 | 10 |
| 435 | 1.3.9.2.14 | 12. Forro (WC's e cozinha) | 1d | 2021-08-02 | 2021-08-02 | 17d | pedreiro [200%]; servente | 26.4h | 4,238.82 | 9. Casa 9 | 1. Pav. Superior | 11. Cer. Parede 1 | Própria | 11 | 11 | 11 |
| 436 | 1.3.9.2.15 | 13. Esq. Alumínio | 1d | 2021-08-02 | 2021-08-02 | 17d | gesseiro; servente | 17.6h | 895 | 9. Casa 9 | 1. Pav. Superior | 12. Forro (WC's e cozinha) 1 | Própria | 12 | 12 | 12 |
| 437 | 1.3.9.2.16 | 14. Portas | 2d | 2021-08-02 | 2021-08-03 | 16d | montador esquadrias [200%] | 35.2h | 8,489.61 | 9. Casa 9 | 1. Pav. Superior | 13. Esq. Alumínio 1 | Própria | 13 | 13 | 13 |
| 438 | 1.3.9.2.17 | 15. Pintura (1ª Demão) | 6d | 2021-08-02 | 2021-08-09 | 12d | marceneiro [200%] | 105.6h | 1,858.35 | 9. Casa 9 | 1. Pav. Superior | 14. Portas 1 | Própria | 14 | 14 | 14 |
| 439 | 1.3.9.2.18 | 16. Bancadas | 1d | 2021-08-02 | 2021-08-02 | 17d | pintor [400%]; aux.pintor [200%] | 52.8h | 3,764.82 | 9. Casa 9 | 1. Pav. Superior | 15. Pintura (1ª Demão) 1 | Própria | 15 | 15 | 15 |
| 440 | 1.3.9.2.19 | 17. Pintura (2ª Demão) | 4d | 2021-08-02 | 2021-08-05 | 14d | pedreiro [200%]; servente | 105.6h | 6,972.08 | 9. Casa 9 | 1. Pav. Superior | 16. Bancadas 1 | Própria | 16 | 16 | 16 |
| 441 | 1.3.9.2.20 | 18. Limp. Interna | 1d | 2021-08-02 | 2021-08-02 | 17d | pintor [400%]; aux.pintor [200%] | 52.8h | 1,563.98 | 9. Casa 9 | 1. Pav. Superior | 17. Pintura (2ª Demão) 1 | Própria | 17 | 17 | 17 |
| 442 | 1.3.9.3 | **2. Coberta** | 6d | 2021-08-02 | 2021-08-09 | 12d |  | 536.8h | 35,295.19 |  |  |  |  |  |  |  |
| 443 | 1.3.9.3.1 | 1. Alvenarias | 6d | 2021-08-02 | 2021-08-09 | 12d | pedreiro [200%]; servente [200%] | 211.2h | 9,834.12 | 9. Casa 9 | 2. Coberta | 3. Alvenarias 1 | Própria |  |  |  |
| 444 | 1.3.9.3.2 | 2. Impermeabilização | 1d | 2021-08-02 | 2021-08-02 | 17d | aplicador de manta | 8.8h | 1,296.54 | 9. Casa 9 | 2. Coberta | 7. Impermeabilização 1 | Própria |  |  |  |
| 445 | 1.3.9.3.3 | 3. Coberta | 6d | 2021-08-02 | 2021-08-09 | 12d | carpinteiro [400%]; aux. Carpinteiro [200%] | 316.8h | 24,164.53 | 9. Casa 9 | 2. Coberta | 4. Coberta 1 | Própria |  |  |  |

| ID | WBS | Task | Duration | Start | Finish | Total slack | Resources | Work | Cost | Casa | Pav | Equipe | Empresa | Pacote | Cor | LB |
| --- | --- | --- | --- | --- | --- | --- | --- | --- | --- | --- | --- | --- | --- | --- | --- | --- |
| 446 | 1.3.10 | **10. Casa 10** | 18d? | 2021-08-02 | 2021-08-25 | 0d |  | 8668h | 315,265.59 |  |  |  |  |  |  |  |
| 447 | 1.3.10.1 | **0. Térreo** | 16d? | 2021-08-02 | 2021-08-23 | 2d |  | 4496.8h | 165,509.25 |  |  |  |  |  |  |  |
| 448 | 1.3.10.1.1 | 0. Locação | 2d | 2021-08-02 | 2021-08-03 | 16d | carpinteiro; aux. Carpinteiro | 35.2h | 456.99 | 10. Casa 10 | 0. Térreo | 0. Locação 1 | Própria |  |  |  |
| 449 | 1.3.10.1.2 | 1. Fundação | 9d | 2021-08-02 | 2021-08-12 | 9d | servente estrutura [300%]; aux. Carpinteiro; aux. ferreiro; ferreiro; carpinteiro [200%] | 633.6h | 19,882.86 | 10. Casa 10 | 0. Térreo | 1. Fundação 1 | Própria |  |  |  |
| 450 | 1.3.10.1.3 | 2. Estrutura | 7d | 2021-08-02 | 2021-08-10 | 11d | servente estrutura [300%]; aux. Carpinteiro [200%]; aux. ferreiro [200%]; ferreiro [500%]; carpinteiro [200%] | 862.4h | 46,439.03 | 10. Casa 10 | 0. Térreo | 2. Estrutura 1 | Própria |  |  |  |
| 451 | 1.3.10.1.4 | 3. Alvenarias | 10d | 2021-08-02 | 2021-08-13 | 8d | pedreiro [200%]; servente [200%] | 352h | 8,388.41 | 10. Casa 10 | 0. Térreo | 3. Alvenarias 1 | Própria |  |  |  |
| 452 | 1.3.10.1.5 | 5. Ref. Inter. Arg (Parede) | 16d | 2021-08-02 | 2021-08-23 | 2d | pedreiro [400%]; servente [400%] | 1126.4h | 5,776 | 10. Casa 10 | 0. Térreo | 5. Ref. Inter. Arg (Parede) 1 | Própria |  |  |  |
| 453 | 1.3.10.1.6 | 6. Revest. Gesso (Parede + Teto) | 5d | 2021-08-02 | 2021-08-06 | 13d | gesseiro [300%]; servente | 176h | 2,119.41 | 10. Casa 10 | 0. Térreo | 6. Revest. Gesso (Parede + Teto) 1 | Própria |  |  |  |
| 454 | 1.3.10.1.7 | 7. Impermeabilização | 2d | 2021-08-02 | 2021-08-03 | 16d | aplicador de manta | 17.6h | 3,288.15 | 10. Casa 10 | 0. Térreo | 7. Impermeabilização 1 | Própria |  |  |  |
| 455 | 1.3.10.1.8 | 8. Contrapiso | 2d | 2021-08-02 | 2021-08-03 | 16d | pedreiro [200%]; servente | 52.8h | 3,735.07 | 10. Casa 10 | 0. Térreo | 8. Contrapiso 1 | Própria |  |  |  |
| 456 | 1.3.10.1.9 | 9. Fachada | 1d? | 2021-08-02 | 2021-08-02 | 17d |  |  |  | 10. Casa 10 | 0. Térreo | 9. Fachada 1 | Própria |  |  |  |
| 457 | 1.3.10.1.10 | 9.1. Chapisco | 0.5d | 2021-08-02 | 2021-08-02 | 17.5d | pedreiro [600%]; servente [400%] | 44h | 5,131.51 | 10. Casa 10 | 0. Térreo | 9. Fachada 1 | Própria |  |  |  |
| 458 | 1.3.10.1.11 | 9.2. Emboço | 1.5d | 2021-08-02 | 2021-08-03 | 16.5d | pedreiro [600%]; servente [400%] | 132h | 7,697.26 | 10. Casa 10 | 0. Térreo | 9. Fachada 1 | Própria |  |  |  |
| 459 | 1.3.10.1.12 | 9.3. Pint. 1 Demão | 1d | 2021-08-02 | 2021-08-02 | 17d | pintor [400%]; aux.pintor [200%] | 52.8h | 1,135.92 | 10. Casa 10 | 0. Térreo | 9. Fachada 1 | Própria |  |  |  |
| 460 | 1.3.10.1.13 | 9.4. Pint. 2 Demão | 2d | 2021-08-02 | 2021-08-03 | 16d | pintor [400%]; aux.pintor [200%] | 105.6h | 757.28 | 10. Casa 10 | 0. Térreo | 9. Fachada 1 | Própria |  |  |  |
| 461 | 1.3.10.1.14 | 10. Cer. Piso | 7d | 2021-08-02 | 2021-08-10 | 11d | pedreiro [200%]; servente | 184.8h | 25,485.98 | 10. Casa 10 | 0. Térreo | 10. Cer. Piso 1 | Própria | 10 | 10 | 10 |
| 462 | 1.3.10.1.15 | 11. Cer. Parede | 3d | 2021-08-02 | 2021-08-04 | 15d | pedreiro [200%]; servente | 79.2h | 4,238.82 | 10. Casa 10 | 0. Térreo | 11. Cer. Parede 1 | Própria | 11 | 11 | 11 |
| 463 | 1.3.10.1.16 | 12. Forro (WC's e cozinha) | 1d | 2021-08-02 | 2021-08-02 | 17d | gesseiro; servente | 17.6h | 635.82 | 10. Casa 10 | 0. Térreo | 12. Forro (WC's e cozinha) 1 | Própria | 12 | 12 | 12 |
| 464 | 1.3.10.1.17 | 13. Esq. Alumínio | 1d | 2021-08-02 | 2021-08-02 | 17d | montador esquadrias [200%] | 17.6h | 11,307.22 | 10. Casa 10 | 0. Térreo | 13. Esq. Alumínio 1 | Própria | 13 | 13 | 13 |
| 465 | 1.3.10.1.18 | 14. Portas | 2d | 2021-08-02 | 2021-08-03 | 16d | marceneiro [200%] | 35.2h | 2,827.85 | 10. Casa 10 | 0. Térreo | 14. Portas 1 | Própria | 14 | 14 | 14 |
| 466 | 1.3.10.1.19 | 15. Pintura (1ª Demão) | 6d | 2021-08-02 | 2021-08-09 | 12d | pintor [400%]; aux.pintor [200%] | 316.8h | 3,764.82 | 10. Casa 10 | 0. Térreo | 15. Pintura (1ª Demão) 1 | Própria | 15 | 15 | 15 |
| 467 | 1.3.10.1.20 | 16. Bancadas | 1d | 2021-08-02 | 2021-08-02 | 17d | pedreiro [200%]; servente | 26.4h | 10,458.12 | 10. Casa 10 | 0. Térreo | 16. Bancadas 1 | Própria | 16 | 16 | 16 |
| 468 | 1.3.10.1.21 | 17. Pintura (2ª Demão) | 4d | 2021-08-02 | 2021-08-05 | 14d | pintor [400%]; aux.pintor [200%] | 211.2h | 1,563.98 | 10. Casa 10 | 0. Térreo | 17. Pintura (2ª Demão) 1 | Própria | 17 | 17 | 17 |
| 469 | 1.3.10.1.22 | 18. Limp. Interna | 1d | 2021-08-02 | 2021-08-02 | 17d | Diarista [200%] | 17.6h | 418.75 | 10. Casa 10 | 0. Térreo | 18. Limp. Interna 1 | Própria | 18 | 18 | 18 |

| ID | WBS | Task | Duration | Start | Finish | Total slack | Resources | Work | Cost | Casa | Pav | Equipe | Empresa | Pacote | Cor | LB |
| --- | --- | --- | --- | --- | --- | --- | --- | --- | --- | --- | --- | --- | --- | --- | --- | --- |
| 470 | 1.3.10.2 | **1. Pav. Superior** | 18d? | 2021-08-02 | 2021-08-25 | 0d |  | 3634.4h | 114,461.15 |  |  |  |  |  |  |  |
| 471 | 1.3.10.2.1 | 2. Estrutura | 7d | 2021-08-02 | 2021-08-10 | 11d |  |  |  | 10. Casa 10 |  |  |  |  |  |  |
| 472 | 1.3.10.2.2 | 3. Alvenarias | 10d | 2021-08-02 | 2021-08-13 | 8d | servente estrutura [300%]; aux. Carpinteiro [200%]; aux. ferreiro [200%]; ferreiro [500%]; carpinteiro [200%] | 1232h | 30,006.55 | 10. Casa 10 | 1. Pav. Superior | 2. Estrutura 1 | Própria |  |  |  |
| 473 | 1.3.10.2.3 | 5. Ref. Inter. Arg (Parede) | 18d | 2021-08-02 | 2021-08-25 | 0d | pedreiro [200%]; servente [200%] | 633.6h | 10,101.74 | 10. Casa 10 | 1. Pav. Superior | 3. Alvenarias 1 | Própria |  |  |  |
| 474 | 1.3.10.2.4 | 6. Revest. Gesso (Parede + Teto) | 7d | 2021-08-02 | 2021-08-10 | 11d | pedreiro [400%]; servente [400%] | 492.8h | 5,398.69 | 10. Casa 10 | 1. Pav. Superior | 5. Ref. Inter. Arg (Parede) 1 | Própria |  |  |  |
| 475 | 1.3.10.2.5 | 7. Impermeabilização | 1d | 2021-08-02 | 2021-08-02 | 17d | gesseiro [300%]; servente | 35.2h | 2,119.41 | 10. Casa 10 | 1. Pav. Superior | 6. Revest. Gesso (Parede + Teto) 1 | Própria |  |  |  |
| 476 | 1.3.10.2.6 | 8. Contrapiso | 2d | 2021-08-02 | 2021-08-03 | 16d | aplicador de manta | 17.6h | 2,046.85 | 10. Casa 10 | 1. Pav. Superior | 7. Impermeabilização 1 | Própria |  |  |  |
| 477 | 1.3.10.2.7 | 9. Fachada | 1d? | 2021-08-02 | 2021-08-02 | 17d | pedreiro [200%]; servente | 26.4h | 2,476.11 | 10. Casa 10 | 1. Pav. Superior | 8. Contrapiso 1 | Própria |  |  |  |
| 478 | 1.3.10.2.8 | 9.1. Chapisco | 0.5d | 2021-08-02 | 2021-08-02 | 17.5d |  |  |  | 10. Casa 10 | 1. Pav. Superior | 9. Fachada 1 | Própria |  |  |  |
| 479 | 1.3.10.2.9 | 9.2. Emboço | 1.5d | 2021-08-02 | 2021-08-03 | 16.5d | pedreiro [600%]; servente [400%] | 132h | 5,131.51 | 10. Casa 10 | 1. Pav. Superior | 9. Fachada 1 | Própria |  |  |  |
| 480 | 1.3.10.2.10 | 9.3. Pint. 1 Demão | 1d | 2021-08-02 | 2021-08-02 | 17d | pedreiro [600%]; servente [400%] | 88h | 7,697.26 | 10. Casa 10 | 1. Pav. Superior | 9. Fachada 1 | Própria |  |  |  |
| 481 | 1.3.10.2.11 | 9.4. Pint. 2 Demão | 2d | 2021-08-02 | 2021-08-03 | 16d | pintor [400%]; aux.pintor [200%] | 105.6h | 1,135.92 | 10. Casa 10 | 1. Pav. Superior | 9. Fachada 1 | Própria |  |  |  |
| 482 | 1.3.10.2.12 | 10. Cer. Piso | 8d | 2021-08-02 | 2021-08-11 | 10d | pintor [400%]; aux.pintor [200%] | 422.4h | 757.28 | 10. Casa 10 | 1. Pav. Superior | 9. Fachada 1 | Própria |  |  |  |
| 483 | 1.3.10.2.13 | 11. Cer. Parede | 2d | 2021-08-02 | 2021-08-03 | 16d | pedreiro [200%]; servente | 52.8h | 19,807.17 | 10. Casa 10 | 1. Pav. Superior | 10. Cer. Piso 1 | Própria | 10 | 10 | 10 |
| 484 | 1.3.10.2.14 | 12. Forro (WC's e cozinha) | 1d | 2021-08-02 | 2021-08-02 | 17d | pedreiro [200%]; servente | 26.4h | 4,238.82 | 10. Casa 10 | 1. Pav. Superior | 11. Cer. Parede 1 | Própria | 11 | 11 | 11 |
| 485 | 1.3.10.2.15 | 13. Esq. Alumínio | 1d | 2021-08-02 | 2021-08-02 | 17d | gesseiro; servente | 17.6h | 895 | 10. Casa 10 | 1. Pav. Superior | 12. Forro (WC's e cozinha) 1 | Própria | 12 | 12 | 12 |
| 486 | 1.3.10.2.16 | 14. Portas | 2d | 2021-08-02 | 2021-08-03 | 16d | montador esquadrias [200%] | 35.2h | 8,489.61 | 10. Casa 10 | 1. Pav. Superior | 13. Esq. Alumínio 1 | Própria | 13 | 13 | 13 |
| 487 | 1.3.10.2.17 | 15. Pintura (1ª Demão) | 6d | 2021-08-02 | 2021-08-09 | 12d | marceneiro [200%] | 105.6h | 1,858.35 | 10. Casa 10 | 1. Pav. Superior | 14. Portas 1 | Própria | 14 | 14 | 14 |
| 488 | 1.3.10.2.18 | 16. Bancadas | 1d | 2021-08-02 | 2021-08-02 | 17d | pintor [400%]; aux.pintor [200%] | 52.8h | 3,764.82 | 10. Casa 10 | 1. Pav. Superior | 15. Pintura (1ª Demão) 1 | Própria | 15 | 15 | 15 |
| 489 | 1.3.10.2.19 | 17. Pintura (2ª Demão) | 4d | 2021-08-02 | 2021-08-05 | 14d | pedreiro [200%]; servente | 105.6h | 6,972.08 | 10. Casa 10 | 1. Pav. Superior | 16. Bancadas 1 | Própria | 16 | 16 | 16 |
| 490 | 1.3.10.2.20 | 18. Limp. Interna | 1d | 2021-08-02 | 2021-08-02 | 17d | pintor [400%]; aux.pintor [200%] | 52.8h | 1,563.98 | 10. Casa 10 | 1. Pav. Superior | 17. Pintura (2ª Demão) 1 | Própria | 17 | 17 | 17 |
| 491 | 1.3.10.3 | **2. Coberta** | 6d | 2021-08-02 | 2021-08-09 | 12d |  | 536.8h | 35,295.19 |  |  |  |  |  |  |  |
| 492 | 1.3.10.3.1 | 1. Alvenarias | 6d | 2021-08-02 | 2021-08-09 | 12d | pedreiro [200%]; servente [200%] | 211.2h | 9,834.12 | 10. Casa 10 | 2. Coberta | 3. Alvenarias 1 | Própria |  |  |  |
| 493 | 1.3.10.3.2 | 2. Impermeabilização | 1d | 2021-08-02 | 2021-08-02 | 17d | aplicador de manta | 8.8h | 1,296.54 | 10. Casa 10 | 2. Coberta | 7. Impermeabilização 1 | Própria |  |  |  |
| 494 | 1.3.10.3.3 | 3. Coberta | 6d | 2021-08-02 | 2021-08-09 | 12d | carpinteiro [400%]; aux. Carpinteiro [200%] | 316.8h | 24,164.53 | 10. Casa 10 | 2. Coberta | 4. Coberta 1 | Própria |  |  |  |

| ID | WBS | Task | Duration | Start | Finish | Total slack | Resources | Work | Cost | Casa | Pav | Equipe | Empresa | Pacote | Cor | LB |
| --- | --- | --- | --- | --- | --- | --- | --- | --- | --- | --- | --- | --- | --- | --- | --- | --- |
| 495 | 1.3.11 | **11. Casa 11** | 18d? | 2021-08-02 | 2021-08-25 | 0d |  | 8668h | 315,265.59 |  |  |  |  |  |  |  |
| 496 | 1.3.11.1 | **0. Térreo** | 16d? | 2021-08-02 | 2021-08-23 | 2d |  | 4496.8h | 165,509.25 |  |  |  |  |  |  |  |
| 497 | 1.3.11.1.1 | 0. Locação | 2d | 2021-08-02 | 2021-08-03 | 16d | carpinteiro; aux. Carpinteiro | 35.2h | 456.99 | 11. Casa 11 | 0. Térreo | 0. Locação 1 | Própria |  |  |  |
| 498 | 1.3.11.1.2 | 1. Fundação | 9d | 2021-08-02 | 2021-08-12 | 9d | servente estrutura [300%]; aux. Carpinteiro; aux. ferreiro; ferreiro; carpinteiro [200%] | 633.6h | 19,882.86 | 11. Casa 11 | 0. Térreo | 1. Fundação 1 | Própria |  |  |  |
| 499 | 1.3.11.1.3 | 2. Estrutura | 7d | 2021-08-02 | 2021-08-10 | 11d | servente estrutura [300%]; aux. Carpinteiro [200%]; aux. ferreiro [200%]; ferreiro [500%]; carpinteiro [200%] | 862.4h | 46,439.03 | 11. Casa 11 | 0. Térreo | 2. Estrutura 1 | Própria |  |  |  |
| 500 | 1.3.11.1.4 | 3. Alvenarias | 10d | 2021-08-02 | 2021-08-13 | 8d | pedreiro [200%]; servente [200%] | 352h | 8,388.41 | 11. Casa 11 | 0. Térreo | 3. Alvenarias 1 | Própria |  |  |  |
| 501 | 1.3.11.1.5 | 5. Ref. Inter. Arg (Parede) | 16d | 2021-08-02 | 2021-08-23 | 2d | pedreiro [400%]; servente [400%] | 1126.4h | 5,776 | 11. Casa 11 | 0. Térreo | 5. Ref. Inter. Arg (Parede) 1 | Própria |  |  |  |
| 502 | 1.3.11.1.6 | 6. Revest. Gesso (Parede + Teto) | 5d | 2021-08-02 | 2021-08-06 | 13d | gesseiro [300%]; servente | 176h | 2,119.41 | 11. Casa 11 | 0. Térreo | 6. Revest. Gesso (Parede + Teto) 1 | Própria |  |  |  |
| 503 | 1.3.11.1.7 | 7. Impermeabilização | 2d | 2021-08-02 | 2021-08-03 | 16d | aplicador de manta | 17.6h | 3,288.15 | 11. Casa 11 | 0. Térreo | 7. Impermeabilização 1 | Própria |  |  |  |
| 504 | 1.3.11.1.8 | 8. Contrapiso | 2d | 2021-08-02 | 2021-08-03 | 16d | pedreiro [200%]; servente | 52.8h | 3,735.07 | 11. Casa 11 | 0. Térreo | 8. Contrapiso 1 | Própria |  |  |  |
| 505 | 1.3.11.1.9 | 9. Fachada | 1d? | 2021-08-02 | 2021-08-02 | 17d |  |  |  | 11. Casa 11 | 0. Térreo | 9. Fachada 1 | Própria |  |  |  |
| 506 | 1.3.11.1.10 | 9.1. Chapisco | 0.5d | 2021-08-02 | 2021-08-02 | 17.5d | pedreiro [600%]; servente [400%] | 44h | 5,131.51 | 11. Casa 11 | 0. Térreo | 9. Fachada 1 | Própria |  |  |  |
| 507 | 1.3.11.1.11 | 9.2. Emboço | 1.5d | 2021-08-02 | 2021-08-03 | 16.5d | pedreiro [600%]; servente [400%] | 132h | 7,697.26 | 11. Casa 11 | 0. Térreo | 9. Fachada 1 | Própria |  |  |  |
| 508 | 1.3.11.1.12 | 9.3. Pint. 1 Demão | 1d | 2021-08-02 | 2021-08-02 | 17d | pintor [400%]; aux.pintor [200%] | 52.8h | 1,135.92 | 11. Casa 11 | 0. Térreo | 9. Fachada 1 | Própria |  |  |  |
| 509 | 1.3.11.1.13 | 9.4. Pint. 2 Demão | 2d | 2021-08-02 | 2021-08-03 | 16d | pintor [400%]; aux.pintor [200%] | 105.6h | 757.28 | 11. Casa 11 | 0. Térreo | 9. Fachada 1 | Própria |  |  |  |
| 510 | 1.3.11.1.14 | 10. Cer. Piso | 7d | 2021-08-02 | 2021-08-10 | 11d | pedreiro [200%]; servente | 184.8h | 25,485.98 | 11. Casa 11 | 0. Térreo | 10. Cer. Piso 1 | Própria | 10 | 10 | 10 |
| 511 | 1.3.11.1.15 | 11. Cer. Parede | 3d | 2021-08-02 | 2021-08-04 | 15d | pedreiro [200%]; servente | 79.2h | 4,238.82 | 11. Casa 11 | 0. Térreo | 11. Cer. Parede 1 | Própria | 11 | 11 | 11 |
| 512 | 1.3.11.1.16 | 12. Forro (WC's e cozinha) | 1d | 2021-08-02 | 2021-08-02 | 17d | gesseiro; servente | 17.6h | 635.82 | 11. Casa 11 | 0. Térreo | 12. Forro (WC's e cozinha) 1 | Própria | 12 | 12 | 12 |
| 513 | 1.3.11.1.17 | 13. Esq. Alumínio | 1d | 2021-08-02 | 2021-08-02 | 17d | montador esquadrias [200%] | 17.6h | 11,307.22 | 11. Casa 11 | 0. Térreo | 13. Esq. Alumínio 1 | Própria | 13 | 13 | 13 |
| 514 | 1.3.11.1.18 | 14. Portas | 2d | 2021-08-02 | 2021-08-03 | 16d | marceneiro [200%] | 35.2h | 2,827.85 | 11. Casa 11 | 0. Térreo | 14. Portas 1 | Própria | 14 | 14 | 14 |
| 515 | 1.3.11.1.19 | 15. Pintura (1ª Demão) | 6d | 2021-08-02 | 2021-08-09 | 12d | pintor [400%]; aux.pintor [200%] | 316.8h | 3,764.82 | 11. Casa 11 | 0. Térreo | 15. Pintura (1ª Demão) 1 | Própria | 15 | 15 | 15 |
| 516 | 1.3.11.1.20 | 16. Bancadas | 1d | 2021-08-02 | 2021-08-02 | 17d | pedreiro [200%]; servente | 26.4h | 10,458.12 | 11. Casa 11 | 0. Térreo | 16. Bancadas 1 | Própria | 16 | 16 | 16 |
| 517 | 1.3.11.1.21 | 17. Pintura (2ª Demão) | 4d | 2021-08-02 | 2021-08-05 | 14d | pintor [400%]; aux.pintor [200%] | 211.2h | 1,563.98 | 11. Casa 11 | 0. Térreo | 17. Pintura (2ª Demão) 1 | Própria | 17 | 17 | 17 |
| 518 | 1.3.11.1.22 | 18. Limp. Interna | 1d | 2021-08-02 | 2021-08-02 | 17d | Diarista [200%] | 17.6h | 418.75 | 11. Casa 11 | 0. Térreo | 18. Limp. Interna 1 | Própria | 18 | 18 | 18 |

| ID | WBS | Task | Duration | Start | Finish | Total slack | Resources | Work | Cost | Casa | Pav | Equipe | Empresa | Pacote | Cor | LB |
| --- | --- | --- | --- | --- | --- | --- | --- | --- | --- | --- | --- | --- | --- | --- | --- | --- |
| 519 | 1.3.11.2 | **1. Pav. Superior** | 18d? | 2021-08-02 | 2021-08-25 | 0d |  | 3634.4h | 114,461.15 |  |  |  |  |  |  |  |
| 520 | 1.3.11.2.1 | 2. Estrutura | 7d | 2021-08-02 | 2021-08-10 | 11d |  |  |  | 11. Casa 11 |  |  |  |  |  |  |
| 521 | 1.3.11.2.2 | 3. Alvenarias | 10d | 2021-08-02 | 2021-08-13 | 8d | servente estrutura [300%]; aux. Carpinteiro [200%]; aux. ferreiro [200%]; ferreiro [500%]; carpinteiro [200%] | 1232h | 30,006.55 | 11. Casa 11 | 1. Pav. Superior | 2. Estrutura 1 | Própria |  |  |  |
| 522 | 1.3.11.2.3 | 5. Ref. Inter. Arg (Parede) | 18d | 2021-08-02 | 2021-08-25 | 0d | pedreiro [200%]; servente [200%] | 633.6h | 10,101.74 | 11. Casa 11 | 1. Pav. Superior | 3. Alvenarias 1 | Própria |  |  |  |
| 523 | 1.3.11.2.4 | 6. Revest. Gesso (Parede + Teto) | 7d | 2021-08-02 | 2021-08-10 | 11d | pedreiro [400%]; servente [400%] | 492.8h | 5,398.69 | 11. Casa 11 | 1. Pav. Superior | 5. Ref. Inter. Arg (Parede) 1 | Própria |  |  |  |
| 524 | 1.3.11.2.5 | 7. Impermeabilização | 1d | 2021-08-02 | 2021-08-02 | 17d | gesseiro [300%]; servente | 35.2h | 2,119.41 | 11. Casa 11 | 1. Pav. Superior | 6. Revest. Gesso (Parede + Teto) 1 | Própria |  |  |  |
| 525 | 1.3.11.2.6 | 8. Contrapiso | 2d | 2021-08-02 | 2021-08-03 | 16d | aplicador de manta | 17.6h | 2,046.85 | 11. Casa 11 | 1. Pav. Superior | 7. Impermeabilização 1 | Própria |  |  |  |
| 526 | 1.3.11.2.7 | 9. Fachada | 1d? | 2021-08-02 | 2021-08-02 | 17d | pedreiro [200%]; servente | 26.4h | 2,476.11 | 11. Casa 11 | 1. Pav. Superior | 8. Contrapiso 1 | Própria |  |  |  |
| 527 | 1.3.11.2.8 | 9.1. Chapisco | 0.5d | 2021-08-02 | 2021-08-02 | 17.5d |  |  |  | 11. Casa 11 | 1. Pav. Superior | 9. Fachada 1 | Própria |  |  |  |
| 528 | 1.3.11.2.9 | 9.2. Emboço | 1.5d | 2021-08-02 | 2021-08-03 | 16.5d | pedreiro [600%]; servente [400%] | 132h | 5,131.51 | 11. Casa 11 | 1. Pav. Superior | 9. Fachada 1 | Própria |  |  |  |
| 529 | 1.3.11.2.10 | 9.3. Pint. 1 Demão | 1d | 2021-08-02 | 2021-08-02 | 17d | pedreiro [600%]; servente [400%] | 88h | 7,697.26 | 11. Casa 11 | 1. Pav. Superior | 9. Fachada 1 | Própria |  |  |  |
| 530 | 1.3.11.2.11 | 9.4. Pint. 2 Demão | 2d | 2021-08-02 | 2021-08-03 | 16d | pintor [400%]; aux.pintor [200%] | 105.6h | 1,135.92 | 11. Casa 11 | 1. Pav. Superior | 9. Fachada 1 | Própria |  |  |  |
| 531 | 1.3.11.2.12 | 10. Cer. Piso | 8d | 2021-08-02 | 2021-08-11 | 10d | pintor [400%]; aux.pintor [200%] | 422.4h | 757.28 | 11. Casa 11 | 1. Pav. Superior | 9. Fachada 1 | Própria |  |  |  |
| 532 | 1.3.11.2.13 | 11. Cer. Parede | 2d | 2021-08-02 | 2021-08-03 | 16d | pedreiro [200%]; servente | 52.8h | 19,807.17 | 11. Casa 11 | 1. Pav. Superior | 10. Cer. Piso 1 | Própria | 10 | 10 | 10 |
| 533 | 1.3.11.2.14 | 12. Forro (WC's e cozinha) | 1d | 2021-08-02 | 2021-08-02 | 17d | pedreiro [200%]; servente | 26.4h | 4,238.82 | 11. Casa 11 | 1. Pav. Superior | 11. Cer. Parede 1 | Própria | 11 | 11 | 11 |
| 534 | 1.3.11.2.15 | 13. Esq. Alumínio | 1d | 2021-08-02 | 2021-08-02 | 17d | gesseiro; servente | 17.6h | 895 | 11. Casa 11 | 1. Pav. Superior | 12. Forro (WC's e cozinha) 1 | Própria | 12 | 12 | 12 |
| 535 | 1.3.11.2.16 | 14. Portas | 2d | 2021-08-02 | 2021-08-03 | 16d | montador esquadrias [200%] | 35.2h | 8,489.61 | 11. Casa 11 | 1. Pav. Superior | 13. Esq. Alumínio 1 | Própria | 13 | 13 | 13 |
| 536 | 1.3.11.2.17 | 15. Pintura (1ª Demão) | 6d | 2021-08-02 | 2021-08-09 | 12d | marceneiro [200%] | 105.6h | 1,858.35 | 11. Casa 11 | 1. Pav. Superior | 14. Portas 1 | Própria | 14 | 14 | 14 |
| 537 | 1.3.11.2.18 | 16. Bancadas | 1d | 2021-08-02 | 2021-08-02 | 17d | pintor [400%]; aux.pintor [200%] | 52.8h | 3,764.82 | 11. Casa 11 | 1. Pav. Superior | 15. Pintura (1ª Demão) 1 | Própria | 15 | 15 | 15 |
| 538 | 1.3.11.2.19 | 17. Pintura (2ª Demão) | 4d | 2021-08-02 | 2021-08-05 | 14d | pedreiro [200%]; servente | 105.6h | 6,972.08 | 11. Casa 11 | 1. Pav. Superior | 16. Bancadas 1 | Própria | 16 | 16 | 16 |
| 539 | 1.3.11.2.20 | 18. Limp. Interna | 1d | 2021-08-02 | 2021-08-02 | 17d | pintor [400%]; aux.pintor [200%] | 52.8h | 1,563.98 | 11. Casa 11 | 1. Pav. Superior | 17. Pintura (2ª Demão) 1 | Própria | 17 | 17 | 17 |
| 540 | 1.3.11.3 | **2. Coberta** | 6d | 2021-08-02 | 2021-08-09 | 12d |  | 536.8h | 35,295.19 |  |  |  |  |  |  |  |
| 541 | 1.3.11.3.1 | 1. Alvenarias | 6d | 2021-08-02 | 2021-08-09 | 12d | pedreiro [200%]; servente [200%] | 211.2h | 9,834.12 | 11. Casa 11 | 2. Coberta | 3. Alvenarias 1 | Própria |  |  |  |
| 542 | 1.3.11.3.2 | 2. Impermeabilização | 1d | 2021-08-02 | 2021-08-02 | 17d | aplicador de manta | 8.8h | 1,296.54 | 11. Casa 11 | 2. Coberta | 7. Impermeabilização 1 | Própria |  |  |  |
| 543 | 1.3.11.3.3 | 3. Coberta | 6d | 2021-08-02 | 2021-08-09 | 12d | carpinteiro [400%]; aux. Carpinteiro [200%] | 316.8h | 24,164.53 | 11. Casa 11 | 2. Coberta | 4. Coberta 1 | Própria |  |  |  |

| ID | WBS | Task | Duration | Start | Finish | Total slack | Resources | Work | Cost | Casa | Pav | Equipe | Empresa | Pacote | Cor | LB |
| --- | --- | --- | --- | --- | --- | --- | --- | --- | --- | --- | --- | --- | --- | --- | --- | --- |
| 544 | 1.3.12 | **12. Casa 12** | 18d? | 2021-08-02 | 2021-08-25 | 0d |  | 8668h | 315,265.59 |  |  |  |  |  |  |  |
| 545 | 1.3.12.1 | **0. Térreo** | 16d? | 2021-08-02 | 2021-08-23 | 2d |  | 4496.8h | 165,509.25 |  |  |  |  |  |  |  |
| 546 | 1.3.12.1.1 | 0. Locação | 2d | 2021-08-02 | 2021-08-03 | 16d | carpinteiro; aux. Carpinteiro | 35.2h | 456.99 | 12. Casa 12 | 0. Térreo | 0. Locação 1 | Própria |  |  |  |
| 547 | 1.3.12.1.2 | 1. Fundação | 9d | 2021-08-02 | 2021-08-12 | 9d | servente estrutura [300%]; aux. Carpinteiro; aux. ferreiro; ferreiro; carpinteiro [200%] | 633.6h | 19,882.86 | 12. Casa 12 | 0. Térreo | 1. Fundação 1 | Própria |  |  |  |
| 548 | 1.3.12.1.3 | 2. Estrutura | 7d | 2021-08-02 | 2021-08-10 | 11d | servente estrutura [300%]; aux. Carpinteiro [200%]; aux. ferreiro [200%]; ferreiro [500%]; carpinteiro [200%] | 862.4h | 46,439.03 | 12. Casa 12 | 0. Térreo | 2. Estrutura 1 | Própria |  |  |  |
| 549 | 1.3.12.1.4 | 3. Alvenarias | 10d | 2021-08-02 | 2021-08-13 | 8d | pedreiro [200%]; servente [200%] | 352h | 8,388.41 | 12. Casa 12 | 0. Térreo | 3. Alvenarias 1 | Própria |  |  |  |
| 550 | 1.3.12.1.5 | 5. Ref. Inter. Arg (Parede) | 16d | 2021-08-02 | 2021-08-23 | 2d | pedreiro [400%]; servente [400%] | 1126.4h | 5,776 | 12. Casa 12 | 0. Térreo | 5. Ref. Inter. Arg (Parede) 1 | Própria |  |  |  |
| 551 | 1.3.12.1.6 | 6. Revest. Gesso (Parede + Teto) | 5d | 2021-08-02 | 2021-08-06 | 13d | gesseiro [300%]; servente | 176h | 2,119.41 | 12. Casa 12 | 0. Térreo | 6. Revest. Gesso (Parede + Teto) 1 | Própria |  |  |  |
| 552 | 1.3.12.1.7 | 7. Impermeabilização | 2d | 2021-08-02 | 2021-08-03 | 16d | aplicador de manta | 17.6h | 3,288.15 | 12. Casa 12 | 0. Térreo | 7. Impermeabilização 1 | Própria |  |  |  |
| 553 | 1.3.12.1.8 | 8. Contrapiso | 2d | 2021-08-02 | 2021-08-03 | 16d | pedreiro [200%]; servente | 52.8h | 3,735.07 | 12. Casa 12 | 0. Térreo | 8. Contrapiso 1 | Própria |  |  |  |
| 554 | 1.3.12.1.9 | 9. Fachada | 1d? | 2021-08-02 | 2021-08-02 | 17d |  |  |  | 12. Casa 12 | 0. Térreo | 9. Fachada 1 | Própria |  |  |  |
| 555 | 1.3.12.1.10 | 9.1. Chapisco | 0.5d | 2021-08-02 | 2021-08-02 | 17.5d | pedreiro [600%]; servente [400%] | 44h | 5,131.51 | 12. Casa 12 | 0. Térreo | 9. Fachada 1 | Própria |  |  |  |
| 556 | 1.3.12.1.11 | 9.2. Emboço | 1.5d | 2021-08-02 | 2021-08-03 | 16.5d | pedreiro [600%]; servente [400%] | 132h | 7,697.26 | 12. Casa 12 | 0. Térreo | 9. Fachada 1 | Própria |  |  |  |
| 557 | 1.3.12.1.12 | 9.3. Pint. 1 Demão | 1d | 2021-08-02 | 2021-08-02 | 17d | pintor [400%]; aux.pintor [200%] | 52.8h | 1,135.92 | 12. Casa 12 | 0. Térreo | 9. Fachada 1 | Própria |  |  |  |
| 558 | 1.3.12.1.13 | 9.4. Pint. 2 Demão | 2d | 2021-08-02 | 2021-08-03 | 16d | pintor [400%]; aux.pintor [200%] | 105.6h | 757.28 | 12. Casa 12 | 0. Térreo | 9. Fachada 1 | Própria |  |  |  |
| 559 | 1.3.12.1.14 | 10. Cer. Piso | 7d | 2021-08-02 | 2021-08-10 | 11d | pedreiro [200%]; servente | 184.8h | 25,485.98 | 12. Casa 12 | 0. Térreo | 10. Cer. Piso 1 | Própria | 10 | 10 | 10 |
| 560 | 1.3.12.1.15 | 11. Cer. Parede | 3d | 2021-08-02 | 2021-08-04 | 15d | pedreiro [200%]; servente | 79.2h | 4,238.82 | 12. Casa 12 | 0. Térreo | 11. Cer. Parede 1 | Própria | 11 | 11 | 11 |
| 561 | 1.3.12.1.16 | 12. Forro (WC's e cozinha) | 1d | 2021-08-02 | 2021-08-02 | 17d | gesseiro; servente | 17.6h | 635.82 | 12. Casa 12 | 0. Térreo | 12. Forro (WC's e cozinha) 1 | Própria | 12 | 12 | 12 |
| 562 | 1.3.12.1.17 | 13. Esq. Alumínio | 1d | 2021-08-02 | 2021-08-02 | 17d | montador esquadrias [200%] | 17.6h | 11,307.22 | 12. Casa 12 | 0. Térreo | 13. Esq. Alumínio 1 | Própria | 13 | 13 | 13 |
| 563 | 1.3.12.1.18 | 14. Portas | 2d | 2021-08-02 | 2021-08-03 | 16d | marceneiro [200%] | 35.2h | 2,827.85 | 12. Casa 12 | 0. Térreo | 14. Portas 1 | Própria | 14 | 14 | 14 |
| 564 | 1.3.12.1.19 | 15. Pintura (1ª Demão) | 6d | 2021-08-02 | 2021-08-09 | 12d | pintor [400%]; aux.pintor [200%] | 316.8h | 3,764.82 | 12. Casa 12 | 0. Térreo | 15. Pintura (1ª Demão) 1 | Própria | 15 | 15 | 15 |
| 565 | 1.3.12.1.20 | 16. Bancadas | 1d | 2021-08-02 | 2021-08-02 | 17d | pedreiro [200%]; servente | 26.4h | 10,458.12 | 12. Casa 12 | 0. Térreo | 16. Bancadas 1 | Própria | 16 | 16 | 16 |
| 566 | 1.3.12.1.21 | 17. Pintura (2ª Demão) | 4d | 2021-08-02 | 2021-08-05 | 14d | pintor [400%]; aux.pintor [200%] | 211.2h | 1,563.98 | 12. Casa 12 | 0. Térreo | 17. Pintura (2ª Demão) 1 | Própria | 17 | 17 | 17 |
| 567 | 1.3.12.1.22 | 18. Limp. Interna | 1d | 2021-08-02 | 2021-08-02 | 17d | Diarista [200%] | 17.6h | 418.75 | 12. Casa 12 | 0. Térreo | 18. Limp. Interna 1 | Própria | 18 | 18 | 18 |

| ID | WBS | Task | Duration | Start | Finish | Total slack | Resources | Work | Cost | Casa | Pav | Equipe | Empresa | Pacote | Cor | LB |
| --- | --- | --- | --- | --- | --- | --- | --- | --- | --- | --- | --- | --- | --- | --- | --- | --- |
| 568 | 1.3.12.2 | **1. Pav. Superior** | 18d? | 2021-08-02 | 2021-08-25 | 0d |  | 3634.4h | 114,461.15 |  |  |  |  |  |  |  |
| 569 | 1.3.12.2.1 | 2. Estrutura | 7d | 2021-08-02 | 2021-08-10 | 11d |  |  |  | 12. Casa 12 |  |  |  |  |  |  |
| 570 | 1.3.12.2.2 | 3. Alvenarias | 10d | 2021-08-02 | 2021-08-13 | 8d | servente estrutura [300%]; aux. Carpinteiro [200%]; aux. ferreiro [200%]; ferreiro [500%]; carpinteiro [200%] | 1232h | 30,006.55 | 12. Casa 12 | 1. Pav. Superior | 2. Estrutura 1 | Própria |  |  |  |
| 571 | 1.3.12.2.3 | 5. Ref. Inter. Arg (Parede) | 18d | 2021-08-02 | 2021-08-25 | 0d | pedreiro [200%]; servente [200%] | 633.6h | 10,101.74 | 12. Casa 12 | 1. Pav. Superior | 3. Alvenarias 1 | Própria |  |  |  |
| 572 | 1.3.12.2.4 | 6. Revest. Gesso (Parede + Teto) | 7d | 2021-08-02 | 2021-08-10 | 11d | pedreiro [400%]; servente [400%] | 492.8h | 5,398.69 | 12. Casa 12 | 1. Pav. Superior | 5. Ref. Inter. Arg (Parede) 1 | Própria |  |  |  |
| 573 | 1.3.12.2.5 | 7. Impermeabilização | 1d | 2021-08-02 | 2021-08-02 | 17d | gesseiro [300%]; servente | 35.2h | 2,119.41 | 12. Casa 12 | 1. Pav. Superior | 6. Revest. Gesso (Parede + Teto) 1 | Própria |  |  |  |
| 574 | 1.3.12.2.6 | 8. Contrapiso | 2d | 2021-08-02 | 2021-08-03 | 16d | aplicador de manta | 17.6h | 2,046.85 | 12. Casa 12 | 1. Pav. Superior | 7. Impermeabilização 1 | Própria |  |  |  |
| 575 | 1.3.12.2.7 | 9. Fachada | 1d? | 2021-08-02 | 2021-08-02 | 17d | pedreiro [200%]; servente | 26.4h | 2,476.11 | 12. Casa 12 | 1. Pav. Superior | 8. Contrapiso 1 | Própria |  |  |  |
| 576 | 1.3.12.2.8 | 9.1. Chapisco | 0.5d | 2021-08-02 | 2021-08-02 | 17.5d |  |  |  | 12. Casa 12 | 1. Pav. Superior | 9. Fachada 1 | Própria |  |  |  |
| 577 | 1.3.12.2.9 | 9.2. Emboço | 1.5d | 2021-08-02 | 2021-08-03 | 16.5d | pedreiro [600%]; servente [400%] | 132h | 5,131.51 | 12. Casa 12 | 1. Pav. Superior | 9. Fachada 1 | Própria |  |  |  |
| 578 | 1.3.12.2.10 | 9.3. Pint. 1 Demão | 1d | 2021-08-02 | 2021-08-02 | 17d | pedreiro [600%]; servente [400%] | 88h | 7,697.26 | 12. Casa 12 | 1. Pav. Superior | 9. Fachada 1 | Própria |  |  |  |
| 579 | 1.3.12.2.11 | 9.4. Pint. 2 Demão | 2d | 2021-08-02 | 2021-08-03 | 16d | pintor [400%]; aux.pintor [200%] | 105.6h | 1,135.92 | 12. Casa 12 | 1. Pav. Superior | 9. Fachada 1 | Própria |  |  |  |
| 580 | 1.3.12.2.12 | 10. Cer. Piso | 8d | 2021-08-02 | 2021-08-11 | 10d | pintor [400%]; aux.pintor [200%] | 422.4h | 757.28 | 12. Casa 12 | 1. Pav. Superior | 9. Fachada 1 | Própria |  |  |  |
| 581 | 1.3.12.2.13 | 11. Cer. Parede | 2d | 2021-08-02 | 2021-08-03 | 16d | pedreiro [200%]; servente | 52.8h | 19,807.17 | 12. Casa 12 | 1. Pav. Superior | 10. Cer. Piso 1 | Própria | 10 | 10 | 10 |
| 582 | 1.3.12.2.14 | 12. Forro (WC's e cozinha) | 1d | 2021-08-02 | 2021-08-02 | 17d | pedreiro [200%]; servente | 26.4h | 4,238.82 | 12. Casa 12 | 1. Pav. Superior | 11. Cer. Parede 1 | Própria | 11 | 11 | 11 |
| 583 | 1.3.12.2.15 | 13. Esq. Alumínio | 1d | 2021-08-02 | 2021-08-02 | 17d | gesseiro; servente | 17.6h | 895 | 12. Casa 12 | 1. Pav. Superior | 12. Forro (WC's e cozinha) 1 | Própria | 12 | 12 | 12 |
| 584 | 1.3.12.2.16 | 14. Portas | 2d | 2021-08-02 | 2021-08-03 | 16d | montador esquadrias [200%] | 35.2h | 8,489.61 | 12. Casa 12 | 1. Pav. Superior | 13. Esq. Alumínio 1 | Própria | 13 | 13 | 13 |
| 585 | 1.3.12.2.17 | 15. Pintura (1ª Demão) | 6d | 2021-08-02 | 2021-08-09 | 12d | marceneiro [200%] | 105.6h | 1,858.35 | 12. Casa 12 | 1. Pav. Superior | 14. Portas 1 | Própria | 14 | 14 | 14 |
| 586 | 1.3.12.2.18 | 16. Bancadas | 1d | 2021-08-02 | 2021-08-02 | 17d | pintor [400%]; aux.pintor [200%] | 52.8h | 3,764.82 | 12. Casa 12 | 1. Pav. Superior | 15. Pintura (1ª Demão) 1 | Própria | 15 | 15 | 15 |
| 587 | 1.3.12.2.19 | 17. Pintura (2ª Demão) | 4d | 2021-08-02 | 2021-08-05 | 14d | pedreiro [200%]; servente | 105.6h | 6,972.08 | 12. Casa 12 | 1. Pav. Superior | 16. Bancadas 1 | Própria | 16 | 16 | 16 |
| 588 | 1.3.12.2.20 | 18. Limp. Interna | 1d | 2021-08-02 | 2021-08-02 | 17d | pintor [400%]; aux.pintor [200%] | 52.8h | 1,563.98 | 12. Casa 12 | 1. Pav. Superior | 17. Pintura (2ª Demão) 1 | Própria | 17 | 17 | 17 |
| 589 | 1.3.12.3 | **2. Coberta** | 6d | 2021-08-02 | 2021-08-09 | 12d |  | 536.8h | 35,295.19 |  |  |  |  |  |  |  |
| 590 | 1.3.12.3.1 | 1. Alvenarias | 6d | 2021-08-02 | 2021-08-09 | 12d | pedreiro [200%]; servente [200%] | 211.2h | 9,834.12 | 12. Casa 12 | 2. Coberta | 3. Alvenarias 1 | Própria |  |  |  |
| 591 | 1.3.12.3.2 | 2. Impermeabilização | 1d | 2021-08-02 | 2021-08-02 | 17d | aplicador de manta | 8.8h | 1,296.54 | 12. Casa 12 | 2. Coberta | 7. Impermeabilização 1 | Própria |  |  |  |
| 592 | 1.3.12.3.3 | 3. Coberta | 6d | 2021-08-02 | 2021-08-09 | 12d | carpinteiro [400%]; aux. Carpinteiro [200%] | 316.8h | 24,164.53 | 12. Casa 12 | 2. Coberta | 4. Coberta 1 | Própria |  |  |  |

| ID | WBS | Task | Duration | Start | Finish | Total slack | Resources | Work | Cost | Casa | Pav | Equipe | Empresa | Pacote | Cor | LB |
| --- | --- | --- | --- | --- | --- | --- | --- | --- | --- | --- | --- | --- | --- | --- | --- | --- |
| 593 | 1.3.13 | **13. Casa 13** | 18d? | 2021-08-02 | 2021-08-25 | 0d |  | 8668h | 315,265.59 |  |  |  |  |  |  |  |
| 594 | 1.3.13.1 | **0. Térreo** | 16d? | 2021-08-02 | 2021-08-23 | 2d |  | 4496.8h | 165,509.25 |  |  |  |  |  |  |  |
| 595 | 1.3.13.1.1 | 0. Locação | 2d | 2021-08-02 | 2021-08-03 | 16d | carpinteiro; aux. Carpinteiro | 35.2h | 456.99 | 13. Casa 13 | 0. Térreo | 0. Locação 1 | Própria |  |  |  |
| 596 | 1.3.13.1.2 | 1. Fundação | 9d | 2021-08-02 | 2021-08-12 | 9d | servente estrutura [300%]; aux. Carpinteiro; aux. ferreiro; ferreiro; carpinteiro [200%] | 633.6h | 19,882.86 | 13. Casa 13 | 0. Térreo | 1. Fundação 1 | Própria |  |  |  |
| 597 | 1.3.13.1.3 | 2. Estrutura | 7d | 2021-08-02 | 2021-08-10 | 11d | servente estrutura [300%]; aux. Carpinteiro [200%]; aux. ferreiro [200%]; ferreiro [500%]; carpinteiro [200%] | 862.4h | 46,439.03 | 13. Casa 13 | 0. Térreo | 2. Estrutura 1 | Própria |  |  |  |
| 598 | 1.3.13.1.4 | 3. Alvenarias | 10d | 2021-08-02 | 2021-08-13 | 8d | pedreiro [200%]; servente [200%] | 352h | 8,388.41 | 13. Casa 13 | 0. Térreo | 3. Alvenarias 1 | Própria |  |  |  |
| 599 | 1.3.13.1.5 | 5. Ref. Inter. Arg (Parede) | 16d | 2021-08-02 | 2021-08-23 | 2d | pedreiro [400%]; servente [400%] | 1126.4h | 5,776 | 13. Casa 13 | 0. Térreo | 5. Ref. Inter. Arg (Parede) 1 | Própria |  |  |  |
| 600 | 1.3.13.1.6 | 6. Revest. Gesso (Parede + Teto) | 5d | 2021-08-02 | 2021-08-06 | 13d | gesseiro [300%]; servente | 176h | 2,119.41 | 13. Casa 13 | 0. Térreo | 6. Revest. Gesso (Parede + Teto) 1 | Própria |  |  |  |
| 601 | 1.3.13.1.7 | 7. Impermeabilização | 2d | 2021-08-02 | 2021-08-03 | 16d | aplicador de manta | 17.6h | 3,288.15 | 13. Casa 13 | 0. Térreo | 7. Impermeabilização 1 | Própria |  |  |  |
| 602 | 1.3.13.1.8 | 8. Contrapiso | 2d | 2021-08-02 | 2021-08-03 | 16d | pedreiro [200%]; servente | 52.8h | 3,735.07 | 13. Casa 13 | 0. Térreo | 8. Contrapiso 1 | Própria |  |  |  |
| 603 | 1.3.13.1.9 | 9. Fachada | 1d? | 2021-08-02 | 2021-08-02 | 17d |  |  |  | 13. Casa 13 | 0. Térreo | 9. Fachada 1 | Própria |  |  |  |
| 604 | 1.3.13.1.10 | 9.1. Chapisco | 0.5d | 2021-08-02 | 2021-08-02 | 17.5d | pedreiro [600%]; servente [400%] | 44h | 5,131.51 | 13. Casa 13 | 0. Térreo | 9. Fachada 1 | Própria |  |  |  |
| 605 | 1.3.13.1.11 | 9.2. Emboço | 1.5d | 2021-08-02 | 2021-08-03 | 16.5d | pedreiro [600%]; servente [400%] | 132h | 7,697.26 | 13. Casa 13 | 0. Térreo | 9. Fachada 1 | Própria |  |  |  |
| 606 | 1.3.13.1.12 | 9.3. Pint. 1 Demão | 1d | 2021-08-02 | 2021-08-02 | 17d | pintor [400%]; aux.pintor [200%] | 52.8h | 1,135.92 | 13. Casa 13 | 0. Térreo | 9. Fachada 1 | Própria |  |  |  |
| 607 | 1.3.13.1.13 | 9.4. Pint. 2 Demão | 2d | 2021-08-02 | 2021-08-03 | 16d | pintor [400%]; aux.pintor [200%] | 105.6h | 757.28 | 13. Casa 13 | 0. Térreo | 9. Fachada 1 | Própria |  |  |  |
| 608 | 1.3.13.1.14 | 10. Cer. Piso | 7d | 2021-08-02 | 2021-08-10 | 11d | pedreiro [200%]; servente | 184.8h | 25,485.98 | 13. Casa 13 | 0. Térreo | 10. Cer. Piso 1 | Própria | 10 | 10 | 10 |
| 609 | 1.3.13.1.15 | 11. Cer. Parede | 3d | 2021-08-02 | 2021-08-04 | 15d | pedreiro [200%]; servente | 79.2h | 4,238.82 | 13. Casa 13 | 0. Térreo | 11. Cer. Parede 1 | Própria | 11 | 11 | 11 |
| 610 | 1.3.13.1.16 | 12. Forro (WC's e cozinha) | 1d | 2021-08-02 | 2021-08-02 | 17d | gesseiro; servente | 17.6h | 635.82 | 13. Casa 13 | 0. Térreo | 12. Forro (WC's e cozinha) 1 | Própria | 12 | 12 | 12 |
| 611 | 1.3.13.1.17 | 13. Esq. Alumínio | 1d | 2021-08-02 | 2021-08-02 | 17d | montador esquadrias [200%] | 17.6h | 11,307.22 | 13. Casa 13 | 0. Térreo | 13. Esq. Alumínio 1 | Própria | 13 | 13 | 13 |
| 612 | 1.3.13.1.18 | 14. Portas | 2d | 2021-08-02 | 2021-08-03 | 16d | marceneiro [200%] | 35.2h | 2,827.85 | 13. Casa 13 | 0. Térreo | 14. Portas 1 | Própria | 14 | 14 | 14 |
| 613 | 1.3.13.1.19 | 15. Pintura (1ª Demão) | 6d | 2021-08-02 | 2021-08-09 | 12d | pintor [400%]; aux.pintor [200%] | 316.8h | 3,764.82 | 13. Casa 13 | 0. Térreo | 15. Pintura (1ª Demão) 1 | Própria | 15 | 15 | 15 |
| 614 | 1.3.13.1.20 | 16. Bancadas | 1d | 2021-08-02 | 2021-08-02 | 17d | pedreiro [200%]; servente | 26.4h | 10,458.12 | 13. Casa 13 | 0. Térreo | 16. Bancadas 1 | Própria | 16 | 16 | 16 |
| 615 | 1.3.13.1.21 | 17. Pintura (2ª Demão) | 4d | 2021-08-02 | 2021-08-05 | 14d | pintor [400%]; aux.pintor [200%] | 211.2h | 1,563.98 | 13. Casa 13 | 0. Térreo | 17. Pintura (2ª Demão) 1 | Própria | 17 | 17 | 17 |
| 616 | 1.3.13.1.22 | 18. Limp. Interna | 1d | 2021-08-02 | 2021-08-02 | 17d | Diarista [200%] | 17.6h | 418.75 | 13. Casa 13 | 0. Térreo | 18. Limp. Interna 1 | Própria | 18 | 18 | 18 |

| ID | WBS | Task | Duration | Start | Finish | Total slack | Resources | Work | Cost | Casa | Pav | Equipe | Empresa | Pacote | Cor | LB |
| --- | --- | --- | --- | --- | --- | --- | --- | --- | --- | --- | --- | --- | --- | --- | --- | --- |
| 617 | 1.3.13.2 | **1. Pav. Superior** | 18d? | 2021-08-02 | 2021-08-25 | 0d |  | 3634.4h | 114,461.15 |  |  |  |  |  |  |  |
| 618 | 1.3.13.2.1 | 2. Estrutura | 7d | 2021-08-02 | 2021-08-10 | 11d |  |  |  | 13. Casa 13 |  |  |  |  |  |  |
| 619 | 1.3.13.2.2 | 3. Alvenarias | 10d | 2021-08-02 | 2021-08-13 | 8d | servente estrutura [300%]; aux. Carpinteiro [200%]; aux. ferreiro [200%]; ferreiro [500%]; carpinteiro [200%] | 1232h | 30,006.55 | 13. Casa 13 | 1. Pav. Superior | 2. Estrutura 1 | Própria |  |  |  |
| 620 | 1.3.13.2.3 | 5. Ref. Inter. Arg (Parede) | 18d | 2021-08-02 | 2021-08-25 | 0d | pedreiro [200%]; servente [200%] | 633.6h | 10,101.74 | 13. Casa 13 | 1. Pav. Superior | 3. Alvenarias 1 | Própria |  |  |  |
| 621 | 1.3.13.2.4 | 6. Revest. Gesso (Parede + Teto) | 7d | 2021-08-02 | 2021-08-10 | 11d | pedreiro [400%]; servente [400%] | 492.8h | 5,398.69 | 13. Casa 13 | 1. Pav. Superior | 5. Ref. Inter. Arg (Parede) 1 | Própria |  |  |  |
| 622 | 1.3.13.2.5 | 7. Impermeabilização | 1d | 2021-08-02 | 2021-08-02 | 17d | gesseiro [300%]; servente | 35.2h | 2,119.41 | 13. Casa 13 | 1. Pav. Superior | 6. Revest. Gesso (Parede + Teto) 1 | Própria |  |  |  |
| 623 | 1.3.13.2.6 | 8. Contrapiso | 2d | 2021-08-02 | 2021-08-03 | 16d | aplicador de manta | 17.6h | 2,046.85 | 13. Casa 13 | 1. Pav. Superior | 7. Impermeabilização 1 | Própria |  |  |  |
| 624 | 1.3.13.2.7 | 9. Fachada | 1d? | 2021-08-02 | 2021-08-02 | 17d | pedreiro [200%]; servente | 26.4h | 2,476.11 | 13. Casa 13 | 1. Pav. Superior | 8. Contrapiso 1 | Própria |  |  |  |
| 625 | 1.3.13.2.8 | 9.1. Chapisco | 0.5d | 2021-08-02 | 2021-08-02 | 17.5d |  |  |  | 13. Casa 13 | 1. Pav. Superior | 9. Fachada 1 | Própria |  |  |  |
| 626 | 1.3.13.2.9 | 9.2. Emboço | 1.5d | 2021-08-02 | 2021-08-03 | 16.5d | pedreiro [600%]; servente [400%] | 132h | 5,131.51 | 13. Casa 13 | 1. Pav. Superior | 9. Fachada 1 | Própria |  |  |  |
| 627 | 1.3.13.2.10 | 9.3. Pint. 1 Demão | 1d | 2021-08-02 | 2021-08-02 | 17d | pedreiro [600%]; servente [400%] | 88h | 7,697.26 | 13. Casa 13 | 1. Pav. Superior | 9. Fachada 1 | Própria |  |  |  |
| 628 | 1.3.13.2.11 | 9.4. Pint. 2 Demão | 2d | 2021-08-02 | 2021-08-03 | 16d | pintor [400%]; aux.pintor [200%] | 105.6h | 1,135.92 | 13. Casa 13 | 1. Pav. Superior | 9. Fachada 1 | Própria |  |  |  |
| 629 | 1.3.13.2.12 | 10. Cer. Piso | 8d | 2021-08-02 | 2021-08-11 | 10d | pintor [400%]; aux.pintor [200%] | 422.4h | 757.28 | 13. Casa 13 | 1. Pav. Superior | 9. Fachada 1 | Própria |  |  |  |
| 630 | 1.3.13.2.13 | 11. Cer. Parede | 2d | 2021-08-02 | 2021-08-03 | 16d | pedreiro [200%]; servente | 52.8h | 19,807.17 | 13. Casa 13 | 1. Pav. Superior | 10. Cer. Piso 1 | Própria | 10 | 10 | 10 |
| 631 | 1.3.13.2.14 | 12. Forro (WC's e cozinha) | 1d | 2021-08-02 | 2021-08-02 | 17d | pedreiro [200%]; servente | 26.4h | 4,238.82 | 13. Casa 13 | 1. Pav. Superior | 11. Cer. Parede 1 | Própria | 11 | 11 | 11 |
| 632 | 1.3.13.2.15 | 13. Esq. Alumínio | 1d | 2021-08-02 | 2021-08-02 | 17d | gesseiro; servente | 17.6h | 895 | 13. Casa 13 | 1. Pav. Superior | 12. Forro (WC's e cozinha) 1 | Própria | 12 | 12 | 12 |
| 633 | 1.3.13.2.16 | 14. Portas | 2d | 2021-08-02 | 2021-08-03 | 16d | montador esquadrias [200%] | 35.2h | 8,489.61 | 13. Casa 13 | 1. Pav. Superior | 13. Esq. Alumínio 1 | Própria | 13 | 13 | 13 |
| 634 | 1.3.13.2.17 | 15. Pintura (1ª Demão) | 6d | 2021-08-02 | 2021-08-09 | 12d | marceneiro [200%] | 105.6h | 1,858.35 | 13. Casa 13 | 1. Pav. Superior | 14. Portas 1 | Própria | 14 | 14 | 14 |
| 635 | 1.3.13.2.18 | 16. Bancadas | 1d | 2021-08-02 | 2021-08-02 | 17d | pintor [400%]; aux.pintor [200%] | 52.8h | 3,764.82 | 13. Casa 13 | 1. Pav. Superior | 15. Pintura (1ª Demão) 1 | Própria | 15 | 15 | 15 |
| 636 | 1.3.13.2.19 | 17. Pintura (2ª Demão) | 4d | 2021-08-02 | 2021-08-05 | 14d | pedreiro [200%]; servente | 105.6h | 6,972.08 | 13. Casa 13 | 1. Pav. Superior | 16. Bancadas 1 | Própria | 16 | 16 | 16 |
| 637 | 1.3.13.2.20 | 18. Limp. Interna | 1d | 2021-08-02 | 2021-08-02 | 17d | pintor [400%]; aux.pintor [200%] | 52.8h | 1,563.98 | 13. Casa 13 | 1. Pav. Superior | 17. Pintura (2ª Demão) 1 | Própria | 17 | 17 | 17 |
| 638 | 1.3.13.3 | **2. Coberta** | 6d | 2021-08-02 | 2021-08-09 | 12d |  | 536.8h | 35,295.19 |  |  |  |  |  |  |  |
| 639 | 1.3.13.3.1 | 1. Alvenarias | 6d | 2021-08-02 | 2021-08-09 | 12d | pedreiro [200%]; servente [200%] | 211.2h | 9,834.12 | 13. Casa 13 | 2. Coberta | 3. Alvenarias 1 | Própria |  |  |  |
| 640 | 1.3.13.3.2 | 2. Impermeabilização | 1d | 2021-08-02 | 2021-08-02 | 17d | aplicador de manta | 8.8h | 1,296.54 | 13. Casa 13 | 2. Coberta | 7. Impermeabilização 1 | Própria |  |  |  |
| 641 | 1.3.13.3.3 | 3. Coberta | 6d | 2021-08-02 | 2021-08-09 | 12d | carpinteiro [400%]; aux. Carpinteiro [200%] | 316.8h | 24,164.53 | 13. Casa 13 | 2. Coberta | 4. Coberta 1 | Própria |  |  |  |

| ID | WBS | Task | Duration | Start | Finish | Total slack | Resources | Work | Cost | Casa | Pav | Equipe | Empresa | Pacote | Cor | LB |
| --- | --- | --- | --- | --- | --- | --- | --- | --- | --- | --- | --- | --- | --- | --- | --- | --- |
| 642 | 1.3.14 | **14. Casa 14** | 18d? | 2021-08-02 | 2021-08-25 | 0d |  | 8668h | 315,265.59 |  |  |  |  |  |  |  |
| 643 | 1.3.14.1 | **0. Térreo** | 16d? | 2021-08-02 | 2021-08-23 | 2d |  | 4496.8h | 165,509.25 |  |  |  |  |  |  |  |
| 644 | 1.3.14.1.1 | 0. Locação | 2d | 2021-08-02 | 2021-08-03 | 16d | carpinteiro; aux. Carpinteiro | 35.2h | 456.99 | 14. Casa 14 | 0. Térreo | 0. Locação 1 | Própria |  |  |  |
| 645 | 1.3.14.1.2 | 1. Fundação | 9d | 2021-08-02 | 2021-08-12 | 9d | servente estrutura [300%]; aux. Carpinteiro; aux. ferreiro; ferreiro; carpinteiro [200%] | 633.6h | 19,882.86 | 14. Casa 14 | 0. Térreo | 1. Fundação 1 | Própria |  |  |  |
| 646 | 1.3.14.1.3 | 2. Estrutura | 7d | 2021-08-02 | 2021-08-10 | 11d | servente estrutura [300%]; aux. Carpinteiro [200%]; aux. ferreiro [200%]; ferreiro [500%]; carpinteiro [200%] | 862.4h | 46,439.03 | 14. Casa 14 | 0. Térreo | 2. Estrutura 1 | Própria |  |  |  |
| 647 | 1.3.14.1.4 | 3. Alvenarias | 10d | 2021-08-02 | 2021-08-13 | 8d | pedreiro [200%]; servente [200%] | 352h | 8,388.41 | 14. Casa 14 | 0. Térreo | 3. Alvenarias 1 | Própria |  |  |  |
| 648 | 1.3.14.1.5 | 5. Ref. Inter. Arg (Parede) | 16d | 2021-08-02 | 2021-08-23 | 2d | pedreiro [400%]; servente [400%] | 1126.4h | 5,776 | 14. Casa 14 | 0. Térreo | 5. Ref. Inter. Arg (Parede) 1 | Própria |  |  |  |
| 649 | 1.3.14.1.6 | 6. Revest. Gesso (Parede + Teto) | 5d | 2021-08-02 | 2021-08-06 | 13d | gesseiro [300%]; servente | 176h | 2,119.41 | 14. Casa 14 | 0. Térreo | 6. Revest. Gesso (Parede + Teto) 1 | Própria |  |  |  |
| 650 | 1.3.14.1.7 | 7. Impermeabilização | 2d | 2021-08-02 | 2021-08-03 | 16d | aplicador de manta | 17.6h | 3,288.15 | 14. Casa 14 | 0. Térreo | 7. Impermeabilização 1 | Própria |  |  |  |
| 651 | 1.3.14.1.8 | 8. Contrapiso | 2d | 2021-08-02 | 2021-08-03 | 16d | pedreiro [200%]; servente | 52.8h | 3,735.07 | 14. Casa 14 | 0. Térreo | 8. Contrapiso 1 | Própria |  |  |  |
| 652 | 1.3.14.1.9 | 9. Fachada | 1d? | 2021-08-02 | 2021-08-02 | 17d |  |  |  | 14. Casa 14 | 0. Térreo | 9. Fachada 1 | Própria |  |  |  |
| 653 | 1.3.14.1.10 | 9.1. Chapisco | 0.5d | 2021-08-02 | 2021-08-02 | 17.5d | pedreiro [600%]; servente [400%] | 44h | 5,131.51 | 14. Casa 14 | 0. Térreo | 9. Fachada 1 | Própria |  |  |  |
| 654 | 1.3.14.1.11 | 9.2. Emboço | 1.5d | 2021-08-02 | 2021-08-03 | 16.5d | pedreiro [600%]; servente [400%] | 132h | 7,697.26 | 14. Casa 14 | 0. Térreo | 9. Fachada 1 | Própria |  |  |  |
| 655 | 1.3.14.1.12 | 9.3. Pint. 1 Demão | 1d | 2021-08-02 | 2021-08-02 | 17d | pintor [400%]; aux.pintor [200%] | 52.8h | 1,135.92 | 14. Casa 14 | 0. Térreo | 9. Fachada 1 | Própria |  |  |  |
| 656 | 1.3.14.1.13 | 9.4. Pint. 2 Demão | 2d | 2021-08-02 | 2021-08-03 | 16d | pintor [400%]; aux.pintor [200%] | 105.6h | 757.28 | 14. Casa 14 | 0. Térreo | 9. Fachada 1 | Própria |  |  |  |
| 657 | 1.3.14.1.14 | 10. Cer. Piso | 7d | 2021-08-02 | 2021-08-10 | 11d | pedreiro [200%]; servente | 184.8h | 25,485.98 | 14. Casa 14 | 0. Térreo | 10. Cer. Piso 1 | Própria | 10 | 10 | 10 |
| 658 | 1.3.14.1.15 | 11. Cer. Parede | 3d | 2021-08-02 | 2021-08-04 | 15d | pedreiro [200%]; servente | 79.2h | 4,238.82 | 14. Casa 14 | 0. Térreo | 11. Cer. Parede 1 | Própria | 11 | 11 | 11 |
| 659 | 1.3.14.1.16 | 12. Forro (WC's e cozinha) | 1d | 2021-08-02 | 2021-08-02 | 17d | gesseiro; servente | 17.6h | 635.82 | 14. Casa 14 | 0. Térreo | 12. Forro (WC's e cozinha) 1 | Própria | 12 | 12 | 12 |
| 660 | 1.3.14.1.17 | 13. Esq. Alumínio | 1d | 2021-08-02 | 2021-08-02 | 17d | montador esquadrias [200%] | 17.6h | 11,307.22 | 14. Casa 14 | 0. Térreo | 13. Esq. Alumínio 1 | Própria | 13 | 13 | 13 |
| 661 | 1.3.14.1.18 | 14. Portas | 2d | 2021-08-02 | 2021-08-03 | 16d | marceneiro [200%] | 35.2h | 2,827.85 | 14. Casa 14 | 0. Térreo | 14. Portas 1 | Própria | 14 | 14 | 14 |
| 662 | 1.3.14.1.19 | 15. Pintura (1ª Demão) | 6d | 2021-08-02 | 2021-08-09 | 12d | pintor [400%]; aux.pintor [200%] | 316.8h | 3,764.82 | 14. Casa 14 | 0. Térreo | 15. Pintura (1ª Demão) 1 | Própria | 15 | 15 | 15 |
| 663 | 1.3.14.1.20 | 16. Bancadas | 1d | 2021-08-02 | 2021-08-02 | 17d | pedreiro [200%]; servente | 26.4h | 10,458.12 | 14. Casa 14 | 0. Térreo | 16. Bancadas 1 | Própria | 16 | 16 | 16 |
| 664 | 1.3.14.1.21 | 17. Pintura (2ª Demão) | 4d | 2021-08-02 | 2021-08-05 | 14d | pintor [400%]; aux.pintor [200%] | 211.2h | 1,563.98 | 14. Casa 14 | 0. Térreo | 17. Pintura (2ª Demão) 1 | Própria | 17 | 17 | 17 |
| 665 | 1.3.14.1.22 | 18. Limp. Interna | 1d | 2021-08-02 | 2021-08-02 | 17d | Diarista [200%] | 17.6h | 418.75 | 14. Casa 14 | 0. Térreo | 18. Limp. Interna 1 | Própria | 18 | 18 | 18 |

| ID | WBS | Task | Duration | Start | Finish | Total slack | Resources | Work | Cost | Casa | Pav | Equipe | Empresa | Pacote | Cor | LB |
| --- | --- | --- | --- | --- | --- | --- | --- | --- | --- | --- | --- | --- | --- | --- | --- | --- |
| 666 | 1.3.14.2 | **1. Pav. Superior** | 18d? | 2021-08-02 | 2021-08-25 | 0d |  | 3634.4h | 114,461.15 |  |  |  |  |  |  |  |
| 667 | 1.3.14.2.1 | 2. Estrutura | 7d | 2021-08-02 | 2021-08-10 | 11d |  |  |  | 14. Casa 14 |  |  |  |  |  |  |
| 668 | 1.3.14.2.2 | 3. Alvenarias | 10d | 2021-08-02 | 2021-08-13 | 8d | servente estrutura [300%]; aux. Carpinteiro [200%]; aux. ferreiro [200%]; ferreiro [500%]; carpinteiro [200%] | 1232h | 30,006.55 | 14. Casa 14 | 1. Pav. Superior | 2. Estrutura 1 | Própria |  |  |  |
| 669 | 1.3.14.2.3 | 5. Ref. Inter. Arg (Parede) | 18d | 2021-08-02 | 2021-08-25 | 0d | pedreiro [200%]; servente [200%] | 633.6h | 10,101.74 | 14. Casa 14 | 1. Pav. Superior | 3. Alvenarias 1 | Própria |  |  |  |
| 670 | 1.3.14.2.4 | 6. Revest. Gesso (Parede + Teto) | 7d | 2021-08-02 | 2021-08-10 | 11d | pedreiro [400%]; servente [400%] | 492.8h | 5,398.69 | 14. Casa 14 | 1. Pav. Superior | 5. Ref. Inter. Arg (Parede) 1 | Própria |  |  |  |
| 671 | 1.3.14.2.5 | 7. Impermeabilização | 1d | 2021-08-02 | 2021-08-02 | 17d | gesseiro [300%]; servente | 35.2h | 2,119.41 | 14. Casa 14 | 1. Pav. Superior | 6. Revest. Gesso (Parede + Teto) 1 | Própria |  |  |  |
| 672 | 1.3.14.2.6 | 8. Contrapiso | 2d | 2021-08-02 | 2021-08-03 | 16d | aplicador de manta | 17.6h | 2,046.85 | 14. Casa 14 | 1. Pav. Superior | 7. Impermeabilização 1 | Própria |  |  |  |
| 673 | 1.3.14.2.7 | 9. Fachada | 1d? | 2021-08-02 | 2021-08-02 | 17d | pedreiro [200%]; servente | 26.4h | 2,476.11 | 14. Casa 14 | 1. Pav. Superior | 8. Contrapiso 1 | Própria |  |  |  |
| 674 | 1.3.14.2.8 | 9.1. Chapisco | 0.5d | 2021-08-02 | 2021-08-02 | 17.5d |  |  |  | 14. Casa 14 | 1. Pav. Superior | 9. Fachada 1 | Própria |  |  |  |
| 675 | 1.3.14.2.9 | 9.2. Emboço | 1.5d | 2021-08-02 | 2021-08-03 | 16.5d | pedreiro [600%]; servente [400%] | 132h | 5,131.51 | 14. Casa 14 | 1. Pav. Superior | 9. Fachada 1 | Própria |  |  |  |
| 676 | 1.3.14.2.10 | 9.3. Pint. 1 Demão | 1d | 2021-08-02 | 2021-08-02 | 17d | pedreiro [600%]; servente [400%] | 88h | 7,697.26 | 14. Casa 14 | 1. Pav. Superior | 9. Fachada 1 | Própria |  |  |  |
| 677 | 1.3.14.2.11 | 9.4. Pint. 2 Demão | 2d | 2021-08-02 | 2021-08-03 | 16d | pintor [400%]; aux.pintor [200%] | 105.6h | 1,135.92 | 14. Casa 14 | 1. Pav. Superior | 9. Fachada 1 | Própria |  |  |  |
| 678 | 1.3.14.2.12 | 10. Cer. Piso | 8d | 2021-08-02 | 2021-08-11 | 10d | pintor [400%]; aux.pintor [200%] | 422.4h | 757.28 | 14. Casa 14 | 1. Pav. Superior | 9. Fachada 1 | Própria |  |  |  |
| 679 | 1.3.14.2.13 | 11. Cer. Parede | 2d | 2021-08-02 | 2021-08-03 | 16d | pedreiro [200%]; servente | 52.8h | 19,807.17 | 14. Casa 14 | 1. Pav. Superior | 10. Cer. Piso 1 | Própria | 10 | 10 | 10 |
| 680 | 1.3.14.2.14 | 12. Forro (WC's e cozinha) | 1d | 2021-08-02 | 2021-08-02 | 17d | pedreiro [200%]; servente | 26.4h | 4,238.82 | 14. Casa 14 | 1. Pav. Superior | 11. Cer. Parede 1 | Própria | 11 | 11 | 11 |
| 681 | 1.3.14.2.15 | 13. Esq. Alumínio | 1d | 2021-08-02 | 2021-08-02 | 17d | gesseiro; servente | 17.6h | 895 | 14. Casa 14 | 1. Pav. Superior | 12. Forro (WC's e cozinha) 1 | Própria | 12 | 12 | 12 |
| 682 | 1.3.14.2.16 | 14. Portas | 2d | 2021-08-02 | 2021-08-03 | 16d | montador esquadrias [200%] | 35.2h | 8,489.61 | 14. Casa 14 | 1. Pav. Superior | 13. Esq. Alumínio 1 | Própria | 13 | 13 | 13 |
| 683 | 1.3.14.2.17 | 15. Pintura (1ª Demão) | 6d | 2021-08-02 | 2021-08-09 | 12d | marceneiro [200%] | 105.6h | 1,858.35 | 14. Casa 14 | 1. Pav. Superior | 14. Portas 1 | Própria | 14 | 14 | 14 |
| 684 | 1.3.14.2.18 | 16. Bancadas | 1d | 2021-08-02 | 2021-08-02 | 17d | pintor [400%]; aux.pintor [200%] | 52.8h | 3,764.82 | 14. Casa 14 | 1. Pav. Superior | 15. Pintura (1ª Demão) 1 | Própria | 15 | 15 | 15 |
| 685 | 1.3.14.2.19 | 17. Pintura (2ª Demão) | 4d | 2021-08-02 | 2021-08-05 | 14d | pedreiro [200%]; servente | 105.6h | 6,972.08 | 14. Casa 14 | 1. Pav. Superior | 16. Bancadas 1 | Própria | 16 | 16 | 16 |
| 686 | 1.3.14.2.20 | 18. Limp. Interna | 1d | 2021-08-02 | 2021-08-02 | 17d | pintor [400%]; aux.pintor [200%] | 52.8h | 1,563.98 | 14. Casa 14 | 1. Pav. Superior | 17. Pintura (2ª Demão) 1 | Própria | 17 | 17 | 17 |
| 687 | 1.3.14.3 | **2. Coberta** | 6d | 2021-08-02 | 2021-08-09 | 12d |  | 536.8h | 35,295.19 |  |  |  |  |  |  |  |
| 688 | 1.3.14.3.1 | 1. Alvenarias | 6d | 2021-08-02 | 2021-08-09 | 12d | pedreiro [200%]; servente [200%] | 211.2h | 9,834.12 | 14. Casa 14 | 2. Coberta | 3. Alvenarias 1 | Própria |  |  |  |
| 689 | 1.3.14.3.2 | 2. Impermeabilização | 1d | 2021-08-02 | 2021-08-02 | 17d | aplicador de manta | 8.8h | 1,296.54 | 14. Casa 14 | 2. Coberta | 7. Impermeabilização 1 | Própria |  |  |  |
| 690 | 1.3.14.3.3 | 3. Coberta | 6d | 2021-08-02 | 2021-08-09 | 12d | carpinteiro [400%]; aux. Carpinteiro [200%] | 316.8h | 24,164.53 | 14. Casa 14 | 2. Coberta | 4. Coberta 1 | Própria |  |  |  |

| ID | WBS | Task | Duration | Start | Finish | Total slack | Resources | Work | Cost | Casa | Pav | Equipe | Empresa | Pacote | Cor | LB |
| --- | --- | --- | --- | --- | --- | --- | --- | --- | --- | --- | --- | --- | --- | --- | --- | --- |
| 691 | 1.3.15 | **15. Casa 15** | 18d? | 2021-08-02 | 2021-08-25 | 0d |  | 8668h | 315,265.59 |  |  |  |  |  |  |  |
| 692 | 1.3.15.1 | **0. Térreo** | 16d? | 2021-08-02 | 2021-08-23 | 2d |  | 4496.8h | 165,509.25 |  |  |  |  |  |  |  |
| 693 | 1.3.15.1.1 | 0. Locação | 2d | 2021-08-02 | 2021-08-03 | 16d | carpinteiro; aux. Carpinteiro | 35.2h | 456.99 | 15. Casa 15 | 0. Térreo | 0. Locação 1 | Própria |  |  |  |
| 694 | 1.3.15.1.2 | 1. Fundação | 9d | 2021-08-02 | 2021-08-12 | 9d | servente estrutura [300%]; aux. Carpinteiro; aux. ferreiro; ferreiro; carpinteiro [200%] | 633.6h | 19,882.86 | 15. Casa 15 | 0. Térreo | 1. Fundação 1 | Própria |  |  |  |
| 695 | 1.3.15.1.3 | 2. Estrutura | 7d | 2021-08-02 | 2021-08-10 | 11d | servente estrutura [300%]; aux. Carpinteiro [200%]; aux. ferreiro [200%]; ferreiro [500%]; carpinteiro [200%] | 862.4h | 46,439.03 | 15. Casa 15 | 0. Térreo | 2. Estrutura 1 | Própria |  |  |  |
| 696 | 1.3.15.1.4 | 3. Alvenarias | 10d | 2021-08-02 | 2021-08-13 | 8d | pedreiro [200%]; servente [200%] | 352h | 8,388.41 | 15. Casa 15 | 0. Térreo | 3. Alvenarias 1 | Própria |  |  |  |
| 697 | 1.3.15.1.5 | 5. Ref. Inter. Arg (Parede) | 16d | 2021-08-02 | 2021-08-23 | 2d | pedreiro [400%]; servente [400%] | 1126.4h | 5,776 | 15. Casa 15 | 0. Térreo | 5. Ref. Inter. Arg (Parede) 1 | Própria |  |  |  |
| 698 | 1.3.15.1.6 | 6. Revest. Gesso (Parede + Teto) | 5d | 2021-08-02 | 2021-08-06 | 13d | gesseiro [300%]; servente | 176h | 2,119.41 | 15. Casa 15 | 0. Térreo | 6. Revest. Gesso (Parede + Teto) 1 | Própria |  |  |  |
| 699 | 1.3.15.1.7 | 7. Impermeabilização | 2d | 2021-08-02 | 2021-08-03 | 16d | aplicador de manta | 17.6h | 3,288.15 | 15. Casa 15 | 0. Térreo | 7. Impermeabilização 1 | Própria |  |  |  |
| 700 | 1.3.15.1.8 | 8. Contrapiso | 2d | 2021-08-02 | 2021-08-03 | 16d | pedreiro [200%]; servente | 52.8h | 3,735.07 | 15. Casa 15 | 0. Térreo | 8. Contrapiso 1 | Própria |  |  |  |
| 701 | 1.3.15.1.9 | 9. Fachada | 1d? | 2021-08-02 | 2021-08-02 | 17d |  |  |  | 15. Casa 15 | 0. Térreo | 9. Fachada 1 | Própria |  |  |  |
| 702 | 1.3.15.1.10 | 9.1. Chapisco | 0.5d | 2021-08-02 | 2021-08-02 | 17.5d | pedreiro [600%]; servente [400%] | 44h | 5,131.51 | 15. Casa 15 | 0. Térreo | 9. Fachada 1 | Própria |  |  |  |
| 703 | 1.3.15.1.11 | 9.2. Emboço | 1.5d | 2021-08-02 | 2021-08-03 | 16.5d | pedreiro [600%]; servente [400%] | 132h | 7,697.26 | 15. Casa 15 | 0. Térreo | 9. Fachada 1 | Própria |  |  |  |
| 704 | 1.3.15.1.12 | 9.3. Pint. 1 Demão | 1d | 2021-08-02 | 2021-08-02 | 17d | pintor [400%]; aux.pintor [200%] | 52.8h | 1,135.92 | 15. Casa 15 | 0. Térreo | 9. Fachada 1 | Própria |  |  |  |
| 705 | 1.3.15.1.13 | 9.4. Pint. 2 Demão | 2d | 2021-08-02 | 2021-08-03 | 16d | pintor [400%]; aux.pintor [200%] | 105.6h | 757.28 | 15. Casa 15 | 0. Térreo | 9. Fachada 1 | Própria |  |  |  |
| 706 | 1.3.15.1.14 | 10. Cer. Piso | 7d | 2021-08-02 | 2021-08-10 | 11d | pedreiro [200%]; servente | 184.8h | 25,485.98 | 15. Casa 15 | 0. Térreo | 10. Cer. Piso 1 | Própria | 10 | 10 | 10 |
| 707 | 1.3.15.1.15 | 11. Cer. Parede | 3d | 2021-08-02 | 2021-08-04 | 15d | pedreiro [200%]; servente | 79.2h | 4,238.82 | 15. Casa 15 | 0. Térreo | 11. Cer. Parede 1 | Própria | 11 | 11 | 11 |
| 708 | 1.3.15.1.16 | 12. Forro (WC's e cozinha) | 1d | 2021-08-02 | 2021-08-02 | 17d | gesseiro; servente | 17.6h | 635.82 | 15. Casa 15 | 0. Térreo | 12. Forro (WC's e cozinha) 1 | Própria | 12 | 12 | 12 |
| 709 | 1.3.15.1.17 | 13. Esq. Alumínio | 1d | 2021-08-02 | 2021-08-02 | 17d | montador esquadrias [200%] | 17.6h | 11,307.22 | 15. Casa 15 | 0. Térreo | 13. Esq. Alumínio 1 | Própria | 13 | 13 | 13 |
| 710 | 1.3.15.1.18 | 14. Portas | 2d | 2021-08-02 | 2021-08-03 | 16d | marceneiro [200%] | 35.2h | 2,827.85 | 15. Casa 15 | 0. Térreo | 14. Portas 1 | Própria | 14 | 14 | 14 |
| 711 | 1.3.15.1.19 | 15. Pintura (1ª Demão) | 6d | 2021-08-02 | 2021-08-09 | 12d | pintor [400%]; aux.pintor [200%] | 316.8h | 3,764.82 | 15. Casa 15 | 0. Térreo | 15. Pintura (1ª Demão) 1 | Própria | 15 | 15 | 15 |
| 712 | 1.3.15.1.20 | 16. Bancadas | 1d | 2021-08-02 | 2021-08-02 | 17d | pedreiro [200%]; servente | 26.4h | 10,458.12 | 15. Casa 15 | 0. Térreo | 16. Bancadas 1 | Própria | 16 | 16 | 16 |
| 713 | 1.3.15.1.21 | 17. Pintura (2ª Demão) | 4d | 2021-08-02 | 2021-08-05 | 14d | pintor [400%]; aux.pintor [200%] | 211.2h | 1,563.98 | 15. Casa 15 | 0. Térreo | 17. Pintura (2ª Demão) 1 | Própria | 17 | 17 | 17 |
| 714 | 1.3.15.1.22 | 18. Limp. Interna | 1d | 2021-08-02 | 2021-08-02 | 17d | Diarista [200%] | 17.6h | 418.75 | 15. Casa 15 | 0. Térreo | 18. Limp. Interna 1 | Própria | 18 | 18 | 18 |

| ID | WBS | Task | Duration | Start | Finish | Total slack | Resources | Work | Cost | Casa | Pav | Equipe | Empresa | Pacote | Cor | LB |
| --- | --- | --- | --- | --- | --- | --- | --- | --- | --- | --- | --- | --- | --- | --- | --- | --- |
| 715 | 1.3.15.2 | **1. Pav. Superior** | 18d? | 2021-08-02 | 2021-08-25 | 0d |  | 3634.4h | 114,461.15 |  |  |  |  |  |  |  |
| 716 | 1.3.15.2.1 | 2. Estrutura | 7d | 2021-08-02 | 2021-08-10 | 11d |  |  |  | 15. Casa 15 |  |  |  |  |  |  |
| 717 | 1.3.15.2.2 | 3. Alvenarias | 10d | 2021-08-02 | 2021-08-13 | 8d | servente estrutura [300%]; aux. Carpinteiro [200%]; aux. ferreiro [200%]; ferreiro [500%]; carpinteiro [200%] | 1232h | 30,006.55 | 15. Casa 15 | 1. Pav. Superior | 2. Estrutura 1 | Própria |  |  |  |
| 718 | 1.3.15.2.3 | 5. Ref. Inter. Arg (Parede) | 18d | 2021-08-02 | 2021-08-25 | 0d | pedreiro [200%]; servente [200%] | 633.6h | 10,101.74 | 15. Casa 15 | 1. Pav. Superior | 3. Alvenarias 1 | Própria |  |  |  |
| 719 | 1.3.15.2.4 | 6. Revest. Gesso (Parede + Teto) | 7d | 2021-08-02 | 2021-08-10 | 11d | pedreiro [400%]; servente [400%] | 492.8h | 5,398.69 | 15. Casa 15 | 1. Pav. Superior | 5. Ref. Inter. Arg (Parede) 1 | Própria |  |  |  |
| 720 | 1.3.15.2.5 | 7. Impermeabilização | 1d | 2021-08-02 | 2021-08-02 | 17d | gesseiro [300%]; servente | 35.2h | 2,119.41 | 15. Casa 15 | 1. Pav. Superior | 6. Revest. Gesso (Parede + Teto) 1 | Própria |  |  |  |
| 721 | 1.3.15.2.6 | 8. Contrapiso | 2d | 2021-08-02 | 2021-08-03 | 16d | aplicador de manta | 17.6h | 2,046.85 | 15. Casa 15 | 1. Pav. Superior | 7. Impermeabilização 1 | Própria |  |  |  |
| 722 | 1.3.15.2.7 | 9. Fachada | 1d? | 2021-08-02 | 2021-08-02 | 17d | pedreiro [200%]; servente | 26.4h | 2,476.11 | 15. Casa 15 | 1. Pav. Superior | 8. Contrapiso 1 | Própria |  |  |  |
| 723 | 1.3.15.2.8 | 9.1. Chapisco | 0.5d | 2021-08-02 | 2021-08-02 | 17.5d |  |  |  | 15. Casa 15 | 1. Pav. Superior | 9. Fachada 1 | Própria |  |  |  |
| 724 | 1.3.15.2.9 | 9.2. Emboço | 1.5d | 2021-08-02 | 2021-08-03 | 16.5d | pedreiro [600%]; servente [400%] | 132h | 5,131.51 | 15. Casa 15 | 1. Pav. Superior | 9. Fachada 1 | Própria |  |  |  |
| 725 | 1.3.15.2.10 | 9.3. Pint. 1 Demão | 1d | 2021-08-02 | 2021-08-02 | 17d | pedreiro [600%]; servente [400%] | 88h | 7,697.26 | 15. Casa 15 | 1. Pav. Superior | 9. Fachada 1 | Própria |  |  |  |
| 726 | 1.3.15.2.11 | 9.4. Pint. 2 Demão | 2d | 2021-08-02 | 2021-08-03 | 16d | pintor [400%]; aux.pintor [200%] | 105.6h | 1,135.92 | 15. Casa 15 | 1. Pav. Superior | 9. Fachada 1 | Própria |  |  |  |
| 727 | 1.3.15.2.12 | 10. Cer. Piso | 8d | 2021-08-02 | 2021-08-11 | 10d | pintor [400%]; aux.pintor [200%] | 422.4h | 757.28 | 15. Casa 15 | 1. Pav. Superior | 9. Fachada 1 | Própria |  |  |  |
| 728 | 1.3.15.2.13 | 11. Cer. Parede | 2d | 2021-08-02 | 2021-08-03 | 16d | pedreiro [200%]; servente | 52.8h | 19,807.17 | 15. Casa 15 | 1. Pav. Superior | 10. Cer. Piso 1 | Própria | 10 | 10 | 10 |
| 729 | 1.3.15.2.14 | 12. Forro (WC's e cozinha) | 1d | 2021-08-02 | 2021-08-02 | 17d | pedreiro [200%]; servente | 26.4h | 4,238.82 | 15. Casa 15 | 1. Pav. Superior | 11. Cer. Parede 1 | Própria | 11 | 11 | 11 |
| 730 | 1.3.15.2.15 | 13. Esq. Alumínio | 1d | 2021-08-02 | 2021-08-02 | 17d | gesseiro; servente | 17.6h | 895 | 15. Casa 15 | 1. Pav. Superior | 12. Forro (WC's e cozinha) 1 | Própria | 12 | 12 | 12 |
| 731 | 1.3.15.2.16 | 14. Portas | 2d | 2021-08-02 | 2021-08-03 | 16d | montador esquadrias [200%] | 35.2h | 8,489.61 | 15. Casa 15 | 1. Pav. Superior | 13. Esq. Alumínio 1 | Própria | 13 | 13 | 13 |
| 732 | 1.3.15.2.17 | 15. Pintura (1ª Demão) | 6d | 2021-08-02 | 2021-08-09 | 12d | marceneiro [200%] | 105.6h | 1,858.35 | 15. Casa 15 | 1. Pav. Superior | 14. Portas 1 | Própria | 14 | 14 | 14 |
| 733 | 1.3.15.2.18 | 16. Bancadas | 1d | 2021-08-02 | 2021-08-02 | 17d | pintor [400%]; aux.pintor [200%] | 52.8h | 3,764.82 | 15. Casa 15 | 1. Pav. Superior | 15. Pintura (1ª Demão) 1 | Própria | 15 | 15 | 15 |
| 734 | 1.3.15.2.19 | 17. Pintura (2ª Demão) | 4d | 2021-08-02 | 2021-08-05 | 14d | pedreiro [200%]; servente | 105.6h | 6,972.08 | 15. Casa 15 | 1. Pav. Superior | 16. Bancadas 1 | Própria | 16 | 16 | 16 |
| 735 | 1.3.15.2.20 | 18. Limp. Interna | 1d | 2021-08-02 | 2021-08-02 | 17d | pintor [400%]; aux.pintor [200%] | 52.8h | 1,563.98 | 15. Casa 15 | 1. Pav. Superior | 17. Pintura (2ª Demão) 1 | Própria | 17 | 17 | 17 |
| 736 | 1.3.15.3 | **2. Coberta** | 6d | 2021-08-02 | 2021-08-09 | 12d |  | 536.8h | 35,295.19 |  |  |  |  |  |  |  |
| 737 | 1.3.15.3.1 | 1. Alvenarias | 6d | 2021-08-02 | 2021-08-09 | 12d | pedreiro [200%]; servente [200%] | 211.2h | 9,834.12 | 15. Casa 15 | 2. Coberta | 3. Alvenarias 1 | Própria |  |  |  |
| 738 | 1.3.15.3.2 | 2. Impermeabilização | 1d | 2021-08-02 | 2021-08-02 | 17d | aplicador de manta | 8.8h | 1,296.54 | 15. Casa 15 | 2. Coberta | 7. Impermeabilização 1 | Própria |  |  |  |
| 739 | 1.3.15.3.3 | 3. Coberta | 6d | 2021-08-02 | 2021-08-09 | 12d | carpinteiro [400%]; aux. Carpinteiro [200%] | 316.8h | 24,164.53 | 15. Casa 15 | 2. Coberta | 4. Coberta 1 | Própria |  |  |  |

| ID | WBS | Task | Duration | Start | Finish | Total slack | Resources | Work | Cost | Casa | Pav | Equipe | Empresa | Pacote | Cor | LB |
| --- | --- | --- | --- | --- | --- | --- | --- | --- | --- | --- | --- | --- | --- | --- | --- | --- |
| 740 | 1.3.16 | **16. Casa 16** | 18d? | 2021-08-02 | 2021-08-25 | 0d |  | 8668h | 315,265.59 |  |  |  |  |  |  |  |
| 741 | 1.3.16.1 | **0. Térreo** | 16d? | 2021-08-02 | 2021-08-23 | 2d |  | 4496.8h | 165,509.25 |  |  |  |  |  |  |  |
| 742 | 1.3.16.1.1 | 0. Locação | 2d | 2021-08-02 | 2021-08-03 | 16d | carpinteiro; aux. Carpinteiro | 35.2h | 456.99 | 16. Casa 16 | 0. Térreo | 0. Locação 1 | Própria |  |  |  |
| 743 | 1.3.16.1.2 | 1. Fundação | 9d | 2021-08-02 | 2021-08-12 | 9d | servente estrutura [300%]; aux. Carpinteiro; aux. ferreiro; ferreiro; carpinteiro [200%] | 633.6h | 19,882.86 | 16. Casa 16 | 0. Térreo | 1. Fundação 1 | Própria |  |  |  |
| 744 | 1.3.16.1.3 | 2. Estrutura | 7d | 2021-08-02 | 2021-08-10 | 11d | servente estrutura [300%]; aux. Carpinteiro [200%]; aux. ferreiro [200%]; ferreiro [500%]; carpinteiro [200%] | 862.4h | 46,439.03 | 16. Casa 16 | 0. Térreo | 2. Estrutura 1 | Própria |  |  |  |
| 745 | 1.3.16.1.4 | 3. Alvenarias | 10d | 2021-08-02 | 2021-08-13 | 8d | pedreiro [200%]; servente [200%] | 352h | 8,388.41 | 16. Casa 16 | 0. Térreo | 3. Alvenarias 1 | Própria |  |  |  |
| 746 | 1.3.16.1.5 | 5. Ref. Inter. Arg (Parede) | 16d | 2021-08-02 | 2021-08-23 | 2d | pedreiro [400%]; servente [400%] | 1126.4h | 5,776 | 16. Casa 16 | 0. Térreo | 5. Ref. Inter. Arg (Parede) 1 | Própria |  |  |  |
| 747 | 1.3.16.1.6 | 6. Revest. Gesso (Parede + Teto) | 5d | 2021-08-02 | 2021-08-06 | 13d | gesseiro [300%]; servente | 176h | 2,119.41 | 16. Casa 16 | 0. Térreo | 6. Revest. Gesso (Parede + Teto) 1 | Própria |  |  |  |
| 748 | 1.3.16.1.7 | 7. Impermeabilização | 2d | 2021-08-02 | 2021-08-03 | 16d | aplicador de manta | 17.6h | 3,288.15 | 16. Casa 16 | 0. Térreo | 7. Impermeabilização 1 | Própria |  |  |  |
| 749 | 1.3.16.1.8 | 8. Contrapiso | 2d | 2021-08-02 | 2021-08-03 | 16d | pedreiro [200%]; servente | 52.8h | 3,735.07 | 16. Casa 16 | 0. Térreo | 8. Contrapiso 1 | Própria |  |  |  |
| 750 | 1.3.16.1.9 | 9. Fachada | 1d? | 2021-08-02 | 2021-08-02 | 17d |  |  |  | 16. Casa 16 | 0. Térreo | 9. Fachada 1 | Própria |  |  |  |
| 751 | 1.3.16.1.10 | 9.1. Chapisco | 0.5d | 2021-08-02 | 2021-08-02 | 17.5d | pedreiro [600%]; servente [400%] | 44h | 5,131.51 | 16. Casa 16 | 0. Térreo | 9. Fachada 1 | Própria |  |  |  |
| 752 | 1.3.16.1.11 | 9.2. Emboço | 1.5d | 2021-08-02 | 2021-08-03 | 16.5d | pedreiro [600%]; servente [400%] | 132h | 7,697.26 | 16. Casa 16 | 0. Térreo | 9. Fachada 1 | Própria |  |  |  |
| 753 | 1.3.16.1.12 | 9.3. Pint. 1 Demão | 1d | 2021-08-02 | 2021-08-02 | 17d | pintor [400%]; aux.pintor [200%] | 52.8h | 1,135.92 | 16. Casa 16 | 0. Térreo | 9. Fachada 1 | Própria |  |  |  |
| 754 | 1.3.16.1.13 | 9.4. Pint. 2 Demão | 2d | 2021-08-02 | 2021-08-03 | 16d | pintor [400%]; aux.pintor [200%] | 105.6h | 757.28 | 16. Casa 16 | 0. Térreo | 9. Fachada 1 | Própria |  |  |  |
| 755 | 1.3.16.1.14 | 10. Cer. Piso | 7d | 2021-08-02 | 2021-08-10 | 11d | pedreiro [200%]; servente | 184.8h | 25,485.98 | 16. Casa 16 | 0. Térreo | 10. Cer. Piso 1 | Própria | 10 | 10 | 10 |
| 756 | 1.3.16.1.15 | 11. Cer. Parede | 3d | 2021-08-02 | 2021-08-04 | 15d | pedreiro [200%]; servente | 79.2h | 4,238.82 | 16. Casa 16 | 0. Térreo | 11. Cer. Parede 1 | Própria | 11 | 11 | 11 |
| 757 | 1.3.16.1.16 | 12. Forro (WC's e cozinha) | 1d | 2021-08-02 | 2021-08-02 | 17d | gesseiro; servente | 17.6h | 635.82 | 16. Casa 16 | 0. Térreo | 12. Forro (WC's e cozinha) 1 | Própria | 12 | 12 | 12 |
| 758 | 1.3.16.1.17 | 13. Esq. Alumínio | 1d | 2021-08-02 | 2021-08-02 | 17d | montador esquadrias [200%] | 17.6h | 11,307.22 | 16. Casa 16 | 0. Térreo | 13. Esq. Alumínio 1 | Própria | 13 | 13 | 13 |
| 759 | 1.3.16.1.18 | 14. Portas | 2d | 2021-08-02 | 2021-08-03 | 16d | marceneiro [200%] | 35.2h | 2,827.85 | 16. Casa 16 | 0. Térreo | 14. Portas 1 | Própria | 14 | 14 | 14 |
| 760 | 1.3.16.1.19 | 15. Pintura (1ª Demão) | 6d | 2021-08-02 | 2021-08-09 | 12d | pintor [400%]; aux.pintor [200%] | 316.8h | 3,764.82 | 16. Casa 16 | 0. Térreo | 15. Pintura (1ª Demão) 1 | Própria | 15 | 15 | 15 |
| 761 | 1.3.16.1.20 | 16. Bancadas | 1d | 2021-08-02 | 2021-08-02 | 17d | pedreiro [200%]; servente | 26.4h | 10,458.12 | 16. Casa 16 | 0. Térreo | 16. Bancadas 1 | Própria | 16 | 16 | 16 |
| 762 | 1.3.16.1.21 | 17. Pintura (2ª Demão) | 4d | 2021-08-02 | 2021-08-05 | 14d | pintor [400%]; aux.pintor [200%] | 211.2h | 1,563.98 | 16. Casa 16 | 0. Térreo | 17. Pintura (2ª Demão) 1 | Própria | 17 | 17 | 17 |
| 763 | 1.3.16.1.22 | 18. Limp. Interna | 1d | 2021-08-02 | 2021-08-02 | 17d | Diarista [200%] | 17.6h | 418.75 | 16. Casa 16 | 0. Térreo | 18. Limp. Interna 1 | Própria | 18 | 18 | 18 |

| ID | WBS | Task | Duration | Start | Finish | Total slack | Resources | Work | Cost | Casa | Pav | Equipe | Empresa | Pacote | Cor | LB |
| --- | --- | --- | --- | --- | --- | --- | --- | --- | --- | --- | --- | --- | --- | --- | --- | --- |
| 764 | 1.3.16.2 | **1. Pav. Superior** | 18d? | 2021-08-02 | 2021-08-25 | 0d |  | 3634.4h | 114,461.15 |  |  |  |  |  |  |  |
| 765 | 1.3.16.2.1 | 2. Estrutura | 7d | 2021-08-02 | 2021-08-10 | 11d |  |  |  | 16. Casa 16 |  |  |  |  |  |  |
| 766 | 1.3.16.2.2 | 3. Alvenarias | 10d | 2021-08-02 | 2021-08-13 | 8d | servente estrutura [300%]; aux. Carpinteiro [200%]; aux. ferreiro [200%]; ferreiro [500%]; carpinteiro [200%] | 1232h | 30,006.55 | 16. Casa 16 | 1. Pav. Superior | 2. Estrutura 1 | Própria |  |  |  |
| 767 | 1.3.16.2.3 | 5. Ref. Inter. Arg (Parede) | 18d | 2021-08-02 | 2021-08-25 | 0d | pedreiro [200%]; servente [200%] | 633.6h | 10,101.74 | 16. Casa 16 | 1. Pav. Superior | 3. Alvenarias 1 | Própria |  |  |  |
| 768 | 1.3.16.2.4 | 6. Revest. Gesso (Parede + Teto) | 7d | 2021-08-02 | 2021-08-10 | 11d | pedreiro [400%]; servente [400%] | 492.8h | 5,398.69 | 16. Casa 16 | 1. Pav. Superior | 5. Ref. Inter. Arg (Parede) 1 | Própria |  |  |  |
| 769 | 1.3.16.2.5 | 7. Impermeabilização | 1d | 2021-08-02 | 2021-08-02 | 17d | gesseiro [300%]; servente | 35.2h | 2,119.41 | 16. Casa 16 | 1. Pav. Superior | 6. Revest. Gesso (Parede + Teto) 1 | Própria |  |  |  |
| 770 | 1.3.16.2.6 | 8. Contrapiso | 2d | 2021-08-02 | 2021-08-03 | 16d | aplicador de manta | 17.6h | 2,046.85 | 16. Casa 16 | 1. Pav. Superior | 7. Impermeabilização 1 | Própria |  |  |  |
| 771 | 1.3.16.2.7 | 9. Fachada | 1d? | 2021-08-02 | 2021-08-02 | 17d | pedreiro [200%]; servente | 26.4h | 2,476.11 | 16. Casa 16 | 1. Pav. Superior | 8. Contrapiso 1 | Própria |  |  |  |
| 772 | 1.3.16.2.8 | 9.1. Chapisco | 0.5d | 2021-08-02 | 2021-08-02 | 17.5d |  |  |  | 16. Casa 16 | 1. Pav. Superior | 9. Fachada 1 | Própria |  |  |  |
| 773 | 1.3.16.2.9 | 9.2. Emboço | 1.5d | 2021-08-02 | 2021-08-03 | 16.5d | pedreiro [600%]; servente [400%] | 132h | 5,131.51 | 16. Casa 16 | 1. Pav. Superior | 9. Fachada 1 | Própria |  |  |  |
| 774 | 1.3.16.2.10 | 9.3. Pint. 1 Demão | 1d | 2021-08-02 | 2021-08-02 | 17d | pedreiro [600%]; servente [400%] | 88h | 7,697.26 | 16. Casa 16 | 1. Pav. Superior | 9. Fachada 1 | Própria |  |  |  |
| 775 | 1.3.16.2.11 | 9.4. Pint. 2 Demão | 2d | 2021-08-02 | 2021-08-03 | 16d | pintor [400%]; aux.pintor [200%] | 105.6h | 1,135.92 | 16. Casa 16 | 1. Pav. Superior | 9. Fachada 1 | Própria |  |  |  |
| 776 | 1.3.16.2.12 | 10. Cer. Piso | 8d | 2021-08-02 | 2021-08-11 | 10d | pintor [400%]; aux.pintor [200%] | 422.4h | 757.28 | 16. Casa 16 | 1. Pav. Superior | 9. Fachada 1 | Própria |  |  |  |
| 777 | 1.3.16.2.13 | 11. Cer. Parede | 2d | 2021-08-02 | 2021-08-03 | 16d | pedreiro [200%]; servente | 52.8h | 19,807.17 | 16. Casa 16 | 1. Pav. Superior | 10. Cer. Piso 1 | Própria | 10 | 10 | 10 |
| 778 | 1.3.16.2.14 | 12. Forro (WC's e cozinha) | 1d | 2021-08-02 | 2021-08-02 | 17d | pedreiro [200%]; servente | 26.4h | 4,238.82 | 16. Casa 16 | 1. Pav. Superior | 11. Cer. Parede 1 | Própria | 11 | 11 | 11 |
| 779 | 1.3.16.2.15 | 13. Esq. Alumínio | 1d | 2021-08-02 | 2021-08-02 | 17d | gesseiro; servente | 17.6h | 895 | 16. Casa 16 | 1. Pav. Superior | 12. Forro (WC's e cozinha) 1 | Própria | 12 | 12 | 12 |
| 780 | 1.3.16.2.16 | 14. Portas | 2d | 2021-08-02 | 2021-08-03 | 16d | montador esquadrias [200%] | 35.2h | 8,489.61 | 16. Casa 16 | 1. Pav. Superior | 13. Esq. Alumínio 1 | Própria | 13 | 13 | 13 |
| 781 | 1.3.16.2.17 | 15. Pintura (1ª Demão) | 6d | 2021-08-02 | 2021-08-09 | 12d | marceneiro [200%] | 105.6h | 1,858.35 | 16. Casa 16 | 1. Pav. Superior | 14. Portas 1 | Própria | 14 | 14 | 14 |
| 782 | 1.3.16.2.18 | 16. Bancadas | 1d | 2021-08-02 | 2021-08-02 | 17d | pintor [400%]; aux.pintor [200%] | 52.8h | 3,764.82 | 16. Casa 16 | 1. Pav. Superior | 15. Pintura (1ª Demão) 1 | Própria | 15 | 15 | 15 |
| 783 | 1.3.16.2.19 | 17. Pintura (2ª Demão) | 4d | 2021-08-02 | 2021-08-05 | 14d | pedreiro [200%]; servente | 105.6h | 6,972.08 | 16. Casa 16 | 1. Pav. Superior | 16. Bancadas 1 | Própria | 16 | 16 | 16 |
| 784 | 1.3.16.2.20 | 18. Limp. Interna | 1d | 2021-08-02 | 2021-08-02 | 17d | pintor [400%]; aux.pintor [200%] | 52.8h | 1,563.98 | 16. Casa 16 | 1. Pav. Superior | 17. Pintura (2ª Demão) 1 | Própria | 17 | 17 | 17 |
| 785 | 1.3.16.3 | **2. Coberta** | 6d | 2021-08-02 | 2021-08-09 | 12d |  | 536.8h | 35,295.19 |  |  |  |  |  |  |  |
| 786 | 1.3.16.3.1 | 1. Alvenarias | 6d | 2021-08-02 | 2021-08-09 | 12d | pedreiro [200%]; servente [200%] | 211.2h | 9,834.12 | 16. Casa 16 | 2. Coberta | 3. Alvenarias 1 | Própria |  |  |  |
| 787 | 1.3.16.3.2 | 2. Impermeabilização | 1d | 2021-08-02 | 2021-08-02 | 17d | aplicador de manta | 8.8h | 1,296.54 | 16. Casa 16 | 2. Coberta | 7. Impermeabilização 1 | Própria |  |  |  |
| 788 | 1.3.16.3.3 | 3. Coberta | 6d | 2021-08-02 | 2021-08-09 | 12d | carpinteiro [400%]; aux. Carpinteiro [200%] | 316.8h | 24,164.53 | 16. Casa 16 | 2. Coberta | 4. Coberta 1 | Própria |  |  |  |

| ID | WBS | Task | Duration | Start | Finish | Total slack | Resources | Work | Cost | Casa | Pav | Pacote | Equipe | Empresa | LB | Cor |
| --- | --- | --- | --- | --- | --- | --- | --- | --- | --- | --- | --- | --- | --- | --- | --- | --- |
| 789 | 1.4 | **Obra Instalações** | 4d | 2021-08-02 | 2021-08-05 | 14d |  | 12390.4h | 1,152,793.92 |  |  |  |  |  |  |  |
| 790 | 1.4.1 | **1. Casa 1** | 4d | 2021-08-02 | 2021-08-05 | 14d |  | 774.4h | 72,049.62 |  |  |  |  |  |  |  |
| 791 | 1.4.1.1 | **0. Térreo** | 4d | 2021-08-02 | 2021-08-05 | 14d |  | 369.6h | 47,239.83 |  |  |  |  |  |  |  |
| 792 | 1.4.1.1.1 | 1.Inst. Embut. Em Fundações | 2d | 2021-08-02 | 2021-08-03 | 16d | bombeiro; eletricista | 35.2h | 1,554.25 | 1. Casa 1 | 0. Térreo | 19 | 19. Instalações1 | Própria | 19 |  |
| 793 | 1.4.1.1.2 | 2.Inst. Elétricas Laje | 2d | 2021-08-02 | 2021-08-03 | 16d | eletricista; aux. eletricista | 35.2h | 6,661.65 | 1. Casa 1 | 0. Térreo | 20 | 20. Elétrica1 | Própria | 20 |  |
| 794 | 1.4.1.1.3 | 3.Inst. Elétricas Paredes | 2d | 2021-08-02 | 2021-08-03 | 16d | eletricista; aux. eletricista | 35.2h | 1,704.34 | 1. Casa 1 | 0. Térreo | 21 | 21. HS1 | Própria | 21 |  |
| 795 | 1.4.1.1.4 | 4.Inst. Gás | 2d | 2021-08-02 | 2021-08-03 | 16d | aux. bombeiro; bombeiro | 35.2h | 2,592.32 | 1. Casa 1 | 0. Térreo | 22 | 21. HS1 | Própria | 22 |  |
| 796 | 1.4.1.1.5 | 5.Inst. AF e AQ | 2d | 2021-08-02 | 2021-08-03 | 16d | aux. bombeiro; bombeiro | 35.2h | 4,586.31 | 1. Casa 1 | 0. Térreo | 23 | 21. HS1 | Própria | 23 |  |
| 797 | 1.4.1.1.6 | 6.Inst. Esgoto | 2d | 2021-08-02 | 2021-08-03 | 16d | aux. bombeiro; bombeiro | 35.2h | 2,922.8 | 1. Casa 1 | 0. Térreo | 24 | 21. HS1 | Própria | 24 |  |
| 798 | 1.4.1.1.7 | 7.Fiação | 4d | 2021-08-02 | 2021-08-05 | 14d | eletricista; aux. eletricista | 70.4h | 11,873.92 | 1. Casa 1 | 0. Térreo | 25 | 20. Elétrica1 | Própria | 25 |  |
| 799 | 1.4.1.1.8 | 8.Interr. Tom e luminárias | 1d | 2021-08-02 | 2021-08-02 | 17d | eletricista; aux. eletricista | 17.6h | 6,963.62 | 1. Casa 1 | 0. Térreo | 26 | 20. Elétrica1 | Própria | 26 |  |
| 800 | 1.4.1.1.9 | 9.Quadro elétrico | 2d | 2021-08-02 | 2021-08-03 | 16d | eletricista; aux. eletricista | 35.2h | 1,788.87 | 1. Casa 1 | 0. Térreo | 27 | 20. Elétrica1 | Própria | 27 |  |
| 801 | 1.4.1.1.10 | 10.Louças e Metais | 2d | 2021-08-02 | 2021-08-03 | 16d | aux. bombeiro; bombeiro | 35.2h | 6,591.75 | 1. Casa 1 | 0. Térreo | 28 | 21. HS1 | Própria | 28 | 10 |
| 802 | 1.4.1.2 | **1. Pav. Superior** | 4d | 2021-08-02 | 2021-08-05 | 14d |  | 334.4h | 21,866.33 |  |  |  |  |  |  |  |
| 803 | 1.4.1.2.1 | 2.Inst. Elétricas Laje | 2d | 2021-08-02 | 2021-08-03 | 16d | eletricista; aux. eletricista | 35.2h | 2,995.3 | 1. Casa 1 | 1. Pav. Superior | 20 | 20. Elétrica1 | Própria | 20 |  |
| 804 | 1.4.1.2.2 | 3.Inst. Elétricas Paredes | 2d | 2021-08-02 | 2021-08-03 | 16d | eletricista; aux. eletricista | 35.2h | 766.33 | 1. Casa 1 | 1. Pav. Superior | 21 | 20. Elétrica1 | Própria | 21 |  |
| 805 | 1.4.1.2.3 | 4.Inst. Gás | 2d | 2021-08-02 | 2021-08-03 | 16d | aux. bombeiro; bombeiro | 35.2h | 1,371.29 | 1. Casa 1 | 1. Pav. Superior | 22 | 21. HS1 | Própria | 22 |  |
| 806 | 1.4.1.2.4 | 5.Inst. AF e AQ | 2d | 2021-08-02 | 2021-08-03 | 16d | aux. bombeiro; bombeiro | 35.2h | 2,426.07 | 1. Casa 1 | 1. Pav. Superior | 23 | 21. HS1 | Própria | 23 |  |
| 807 | 1.4.1.2.5 | 6.Inst. Esgoto | 2d | 2021-08-02 | 2021-08-03 | 16d | aux. bombeiro; bombeiro | 35.2h | 1,546.11 | 1. Casa 1 | 1. Pav. Superior | 24 | 21. HS1 | Própria | 24 |  |
| 808 | 1.4.1.2.6 | 7.Fiação | 4d | 2021-08-02 | 2021-08-05 | 14d | eletricista; aux. eletricista | 70.4h | 5,338.91 | 1. Casa 1 | 1. Pav. Superior | 25 | 20. Elétrica1 | Própria | 25 |  |
| 809 | 1.4.1.2.7 | 8.Interr. Tom e luminárias | 1d | 2021-08-02 | 2021-08-02 | 17d | eletricista; aux. eletricista | 17.6h | 3,131.08 | 1. Casa 1 | 1. Pav. Superior | 26 | 20. Elétrica1 | Própria | 26 |  |
| 810 | 1.4.1.2.8 | 9.Quadro elétrico | 2d | 2021-08-02 | 2021-08-03 | 16d | eletricista; aux. eletricista | 35.2h | 804.33 | 1. Casa 1 | 1. Pav. Superior | 27 | 20. Elétrica1 | Própria | 27 |  |
| 811 | 1.4.1.2.9 | 10.Louças e Metais | 2d | 2021-08-02 | 2021-08-03 | 16d | aux. bombeiro; bombeiro | 35.2h | 3,486.91 | 1. Casa 1 | 1. Pav. Superior | 28 | 21. HS1 | Própria | 28 | 10 |
| 812 | 1.4.1.3 | **2. Coberta** | 2d | 2021-08-02 | 2021-08-03 | 16d |  | 70.4h | 2,943.46 |  |  |  |  |  |  |  |
| 813 | 1.4.1.3.1 | Barrilette | 2d | 2021-08-02 | 2021-08-03 | 16d | aux. bombeiro; bombeiro | 35.2h | 1,177.38 | 1. Casa 1 | 2. Coberta | 29 | 21. HS1 | Própria | 29 | 11 |
| 814 | 1.4.1.3.2 | Caixa D'água | 2d | 2021-08-02 | 2021-08-03 | 16d | aux. bombeiro; bombeiro | 35.2h | 1,766.08 | 1. Casa 1 | 2. Coberta | 30 | 21. HS1 | Própria | 30 | 11 |

| ID | WBS | Task | Duration | Start | Finish | Total slack | Resources | Work | Cost | Casa | Pav | Pacote | Equipe | Empresa | LB | Cor |
| --- | --- | --- | --- | --- | --- | --- | --- | --- | --- | --- | --- | --- | --- | --- | --- | --- |
| 815 | 1.4.2 | **2. Casa 2** | 4d | 2021-08-02 | 2021-08-05 | 14d |  | 774.4h | 72,049.62 |  |  |  |  |  |  |  |
| 816 | 1.4.2.1 | **0. Térreo** | 4d | 2021-08-02 | 2021-08-05 | 14d |  | 369.6h | 47,239.83 |  |  |  |  |  |  |  |
| 817 | 1.4.2.1.1 | 1.Inst. Embut. Em Fundações | 2d | 2021-08-02 | 2021-08-03 | 16d | bombeiro; eletricista | 35.2h | 1,554.25 | 2. Casa 2 | 0. Térreo | 19 | 19. Instalações1 | Própria | 19 |  |
| 818 | 1.4.2.1.2 | 2.Inst. Elétricas Laje | 2d | 2021-08-02 | 2021-08-03 | 16d | eletricista; aux. eletricista | 35.2h | 6,661.65 | 2. Casa 2 | 0. Térreo | 20 | 20. Elétrica1 | Própria | 20 |  |
| 819 | 1.4.2.1.3 | 3.Inst. Elétricas Paredes | 2d | 2021-08-02 | 2021-08-03 | 16d | eletricista; aux. eletricista | 35.2h | 1,704.34 | 2. Casa 2 | 0. Térreo | 21 | 21. HS1 | Própria | 21 |  |
| 820 | 1.4.2.1.4 | 4.Inst. Gás | 2d | 2021-08-02 | 2021-08-03 | 16d | aux. bombeiro; bombeiro | 35.2h | 2,592.32 | 2. Casa 2 | 0. Térreo | 22 | 21. HS1 | Própria | 22 |  |
| 821 | 1.4.2.1.5 | 5.Inst. AF e AQ | 2d | 2021-08-02 | 2021-08-03 | 16d | aux. bombeiro; bombeiro | 35.2h | 4,586.31 | 2. Casa 2 | 0. Térreo | 23 | 21. HS1 | Própria | 23 |  |
| 822 | 1.4.2.1.6 | 6.Inst. Esgoto | 2d | 2021-08-02 | 2021-08-03 | 16d | aux. bombeiro; bombeiro | 35.2h | 2,922.8 | 2. Casa 2 | 0. Térreo | 24 | 21. HS1 | Própria | 24 |  |
| 823 | 1.4.2.1.7 | 7.Fiação | 4d | 2021-08-02 | 2021-08-05 | 14d | eletricista; aux. eletricista | 70.4h | 11,873.92 | 2. Casa 2 | 0. Térreo | 25 | 20. Elétrica1 | Própria | 25 |  |
| 824 | 1.4.2.1.8 | 8.Interr. Tom e luminárias | 1d | 2021-08-02 | 2021-08-02 | 17d | eletricista; aux. eletricista | 17.6h | 6,963.62 | 2. Casa 2 | 0. Térreo | 26 | 20. Elétrica1 | Própria | 26 |  |
| 825 | 1.4.2.1.9 | 9.Quadro elétrico | 2d | 2021-08-02 | 2021-08-03 | 16d | eletricista; aux. eletricista | 35.2h | 1,788.87 | 2. Casa 2 | 0. Térreo | 27 | 20. Elétrica1 | Própria | 27 |  |
| 826 | 1.4.2.1.10 | 10.Louças e Metais | 2d | 2021-08-02 | 2021-08-03 | 16d | aux. bombeiro; bombeiro | 35.2h | 6,591.75 | 2. Casa 2 | 0. Térreo | 28 | 21. HS1 | Própria | 28 | 10 |
| 827 | 1.4.2.2 | **1. Pav. Superior** | 4d | 2021-08-02 | 2021-08-05 | 14d |  | 334.4h | 21,866.33 |  |  |  |  |  |  |  |
| 828 | 1.4.2.2.1 | 2.Inst. Elétricas Laje | 2d | 2021-08-02 | 2021-08-03 | 16d | eletricista; aux. eletricista | 35.2h | 2,995.3 | 2. Casa 2 | 1. Pav. Superior | 20 | 20. Elétrica1 | Própria | 20 |  |
| 829 | 1.4.2.2.2 | 3.Inst. Elétricas Paredes | 2d | 2021-08-02 | 2021-08-03 | 16d | eletricista; aux. eletricista | 35.2h | 766.33 | 2. Casa 2 | 1. Pav. Superior | 21 | 20. Elétrica1 | Própria | 21 |  |
| 830 | 1.4.2.2.3 | 4.Inst. Gás | 2d | 2021-08-02 | 2021-08-03 | 16d | aux. bombeiro; bombeiro | 35.2h | 1,371.29 | 2. Casa 2 | 1. Pav. Superior | 22 | 21. HS1 | Própria | 22 |  |
| 831 | 1.4.2.2.4 | 5.Inst. AF e AQ | 2d | 2021-08-02 | 2021-08-03 | 16d | aux. bombeiro; bombeiro | 35.2h | 2,426.07 | 2. Casa 2 | 1. Pav. Superior | 23 | 21. HS1 | Própria | 23 |  |
| 832 | 1.4.2.2.5 | 6.Inst. Esgoto | 2d | 2021-08-02 | 2021-08-03 | 16d | aux. bombeiro; bombeiro | 35.2h | 1,546.11 | 2. Casa 2 | 1. Pav. Superior | 24 | 21. HS1 | Própria | 24 |  |
| 833 | 1.4.2.2.6 | 7.Fiação | 4d | 2021-08-02 | 2021-08-05 | 14d | eletricista; aux. eletricista | 70.4h | 5,338.91 | 2. Casa 2 | 1. Pav. Superior | 25 | 20. Elétrica1 | Própria | 25 |  |
| 834 | 1.4.2.2.7 | 8.Interr. Tom e luminárias | 1d | 2021-08-02 | 2021-08-02 | 17d | eletricista; aux. eletricista | 17.6h | 3,131.08 | 2. Casa 2 | 1. Pav. Superior | 26 | 20. Elétrica1 | Própria | 26 |  |
| 835 | 1.4.2.2.8 | 9.Quadro elétrico | 2d | 2021-08-02 | 2021-08-03 | 16d | eletricista; aux. eletricista | 35.2h | 804.33 | 2. Casa 2 | 1. Pav. Superior | 27 | 20. Elétrica1 | Própria | 27 |  |
| 836 | 1.4.2.2.9 | 10.Louças e Metais | 2d | 2021-08-02 | 2021-08-03 | 16d | aux. bombeiro; bombeiro | 35.2h | 3,486.91 | 2. Casa 2 | 1. Pav. Superior | 28 | 21. HS1 | Própria | 28 | 10 |
| 837 | 1.4.2.3 | **2. Coberta** | 2d | 2021-08-02 | 2021-08-03 | 16d |  | 70.4h | 2,943.46 |  |  |  |  |  |  |  |
| 838 | 1.4.2.3.1 | Barrilette | 2d | 2021-08-02 | 2021-08-03 | 16d | aux. bombeiro; bombeiro | 35.2h | 1,177.38 | 2. Casa 2 | 2. Coberta | 29 | 21. HS1 | Própria | 29 | 11 |
| 839 | 1.4.2.3.2 | Caixa D'água | 2d | 2021-08-02 | 2021-08-03 | 16d | aux. bombeiro; bombeiro | 35.2h | 1,766.08 | 2. Casa 2 | 2. Coberta | 30 | 21. HS1 | Própria | 30 | 11 |

| ID | WBS | Task | Duration | Start | Finish | Total slack | Resources | Work | Cost | Casa | Pav | Pacote | Equipe | Empresa | LB | Cor |
| --- | --- | --- | --- | --- | --- | --- | --- | --- | --- | --- | --- | --- | --- | --- | --- | --- |
| 840 | 1.4.3 | **3. Casa 3** | 4d | 2021-08-02 | 2021-08-05 | 14d |  | 774.4h | 72,049.62 |  |  |  |  |  |  |  |
| 841 | 1.4.3.1 | **0. Térreo** | 4d | 2021-08-02 | 2021-08-05 | 14d |  | 369.6h | 47,239.83 |  |  |  |  |  |  |  |
| 842 | 1.4.3.1.1 | 1.Inst. Embut. Em Fundações | 2d | 2021-08-02 | 2021-08-03 | 16d | bombeiro; eletricista | 35.2h | 1,554.25 | 3. Casa 3 | 0. Térreo | 19 | 19. Instalações1 | Própria | 19 |  |
| 843 | 1.4.3.1.2 | 2.Inst. Elétricas Laje | 2d | 2021-08-02 | 2021-08-03 | 16d | eletricista; aux. eletricista | 35.2h | 6,661.65 | 3. Casa 3 | 0. Térreo | 20 | 20. Elétrica1 | Própria | 20 |  |
| 844 | 1.4.3.1.3 | 3.Inst. Elétricas Paredes | 2d | 2021-08-02 | 2021-08-03 | 16d | eletricista; aux. eletricista | 35.2h | 1,704.34 | 3. Casa 3 | 0. Térreo | 21 | 21. HS1 | Própria | 21 |  |
| 845 | 1.4.3.1.4 | 4.Inst. Gás | 2d | 2021-08-02 | 2021-08-03 | 16d | aux. bombeiro; bombeiro | 35.2h | 2,592.32 | 3. Casa 3 | 0. Térreo | 22 | 21. HS1 | Própria | 22 |  |
| 846 | 1.4.3.1.5 | 5.Inst. AF e AQ | 2d | 2021-08-02 | 2021-08-03 | 16d | aux. bombeiro; bombeiro | 35.2h | 4,586.31 | 3. Casa 3 | 0. Térreo | 23 | 21. HS1 | Própria | 23 |  |
| 847 | 1.4.3.1.6 | 6.Inst. Esgoto | 2d | 2021-08-02 | 2021-08-03 | 16d | aux. bombeiro; bombeiro | 35.2h | 2,922.8 | 3. Casa 3 | 0. Térreo | 24 | 21. HS1 | Própria | 24 |  |
| 848 | 1.4.3.1.7 | 7.Fiação | 4d | 2021-08-02 | 2021-08-05 | 14d | eletricista; aux. eletricista | 70.4h | 11,873.92 | 3. Casa 3 | 0. Térreo | 25 | 20. Elétrica1 | Própria | 25 |  |
| 849 | 1.4.3.1.8 | 8.Interr. Tom e luminárias | 1d | 2021-08-02 | 2021-08-02 | 17d | eletricista; aux. eletricista | 17.6h | 6,963.62 | 3. Casa 3 | 0. Térreo | 26 | 20. Elétrica1 | Própria | 26 |  |
| 850 | 1.4.3.1.9 | 9.Quadro elétrico | 2d | 2021-08-02 | 2021-08-03 | 16d | eletricista; aux. eletricista | 35.2h | 1,788.87 | 3. Casa 3 | 0. Térreo | 27 | 20. Elétrica1 | Própria | 27 |  |
| 851 | 1.4.3.1.10 | 10.Louças e Metais | 2d | 2021-08-02 | 2021-08-03 | 16d | aux. bombeiro; bombeiro | 35.2h | 6,591.75 | 3. Casa 3 | 0. Térreo | 28 | 21. HS1 | Própria | 28 | 10 |
| 852 | 1.4.3.2 | **1. Pav. Superior** | 4d | 2021-08-02 | 2021-08-05 | 14d |  | 334.4h | 21,866.33 |  |  |  |  |  |  |  |
| 853 | 1.4.3.2.1 | 2.Inst. Elétricas Laje | 2d | 2021-08-02 | 2021-08-03 | 16d | eletricista; aux. eletricista | 35.2h | 2,995.3 | 3. Casa 3 | 1. Pav. Superior | 20 | 20. Elétrica1 | Própria | 20 |  |
| 854 | 1.4.3.2.2 | 3.Inst. Elétricas Paredes | 2d | 2021-08-02 | 2021-08-03 | 16d | eletricista; aux. eletricista | 35.2h | 766.33 | 3. Casa 3 | 1. Pav. Superior | 21 | 20. Elétrica1 | Própria | 21 |  |
| 855 | 1.4.3.2.3 | 4.Inst. Gás | 2d | 2021-08-02 | 2021-08-03 | 16d | aux. bombeiro; bombeiro | 35.2h | 1,371.29 | 3. Casa 3 | 1. Pav. Superior | 22 | 21. HS1 | Própria | 22 |  |
| 856 | 1.4.3.2.4 | 5.Inst. AF e AQ | 2d | 2021-08-02 | 2021-08-03 | 16d | aux. bombeiro; bombeiro | 35.2h | 2,426.07 | 3. Casa 3 | 1. Pav. Superior | 23 | 21. HS1 | Própria | 23 |  |
| 857 | 1.4.3.2.5 | 6.Inst. Esgoto | 2d | 2021-08-02 | 2021-08-03 | 16d | aux. bombeiro; bombeiro | 35.2h | 1,546.11 | 3. Casa 3 | 1. Pav. Superior | 24 | 21. HS1 | Própria | 24 |  |
| 858 | 1.4.3.2.6 | 7.Fiação | 4d | 2021-08-02 | 2021-08-05 | 14d | eletricista; aux. eletricista | 70.4h | 5,338.91 | 3. Casa 3 | 1. Pav. Superior | 25 | 20. Elétrica1 | Própria | 25 |  |
| 859 | 1.4.3.2.7 | 8.Interr. Tom e luminárias | 1d | 2021-08-02 | 2021-08-02 | 17d | eletricista; aux. eletricista | 17.6h | 3,131.08 | 3. Casa 3 | 1. Pav. Superior | 26 | 20. Elétrica1 | Própria | 26 |  |
| 860 | 1.4.3.2.8 | 9.Quadro elétrico | 2d | 2021-08-02 | 2021-08-03 | 16d | eletricista; aux. eletricista | 35.2h | 804.33 | 3. Casa 3 | 1. Pav. Superior | 27 | 20. Elétrica1 | Própria | 27 |  |
| 861 | 1.4.3.2.9 | 10.Louças e Metais | 2d | 2021-08-02 | 2021-08-03 | 16d | aux. bombeiro; bombeiro | 35.2h | 3,486.91 | 3. Casa 3 | 1. Pav. Superior | 28 | 21. HS1 | Própria | 28 | 10 |
| 862 | 1.4.3.3 | **2. Coberta** | 2d | 2021-08-02 | 2021-08-03 | 16d |  | 70.4h | 2,943.46 |  |  |  |  |  |  |  |
| 863 | 1.4.3.3.1 | Barrilette | 2d | 2021-08-02 | 2021-08-03 | 16d | aux. bombeiro; bombeiro | 35.2h | 1,177.38 | 3. Casa 3 | 2. Coberta | 29 | 21. HS1 | Própria | 29 | 11 |
| 864 | 1.4.3.3.2 | Caixa D'água | 2d | 2021-08-02 | 2021-08-03 | 16d | aux. bombeiro; bombeiro | 35.2h | 1,766.08 | 3. Casa 3 | 2. Coberta | 30 | 21. HS1 | Própria | 30 | 11 |

| ID | WBS | Task | Duration | Start | Finish | Total slack | Resources | Work | Cost | Casa | Pav | Pacote | Equipe | Empresa | LB | Cor |
| --- | --- | --- | --- | --- | --- | --- | --- | --- | --- | --- | --- | --- | --- | --- | --- | --- |
| 865 | 1.4.4 | **4. Casa 4** | 4d | 2021-08-02 | 2021-08-05 | 14d |  | 774.4h | 72,049.62 |  |  |  |  |  |  |  |
| 866 | 1.4.4.1 | **0. Térreo** | 4d | 2021-08-02 | 2021-08-05 | 14d |  | 369.6h | 47,239.83 |  |  |  |  |  |  |  |
| 867 | 1.4.4.1.1 | 1.Inst. Embut. Em Fundações | 2d | 2021-08-02 | 2021-08-03 | 16d | bombeiro; eletricista | 35.2h | 1,554.25 | 4. Casa 4 | 0. Térreo | 19 | 19. Instalações1 | Própria | 19 |  |
| 868 | 1.4.4.1.2 | 2.Inst. Elétricas Laje | 2d | 2021-08-02 | 2021-08-03 | 16d | eletricista; aux. eletricista | 35.2h | 6,661.65 | 4. Casa 4 | 0. Térreo | 20 | 20. Elétrica1 | Própria | 20 |  |
| 869 | 1.4.4.1.3 | 3.Inst. Elétricas Paredes | 2d | 2021-08-02 | 2021-08-03 | 16d | eletricista; aux. eletricista | 35.2h | 1,704.34 | 4. Casa 4 | 0. Térreo | 21 | 21. HS1 | Própria | 21 |  |
| 870 | 1.4.4.1.4 | 4.Inst. Gás | 2d | 2021-08-02 | 2021-08-03 | 16d | aux. bombeiro; bombeiro | 35.2h | 2,592.32 | 4. Casa 4 | 0. Térreo | 22 | 21. HS1 | Própria | 22 |  |
| 871 | 1.4.4.1.5 | 5.Inst. AF e AQ | 2d | 2021-08-02 | 2021-08-03 | 16d | aux. bombeiro; bombeiro | 35.2h | 4,586.31 | 4. Casa 4 | 0. Térreo | 23 | 21. HS1 | Própria | 23 |  |
| 872 | 1.4.4.1.6 | 6.Inst. Esgoto | 2d | 2021-08-02 | 2021-08-03 | 16d | aux. bombeiro; bombeiro | 35.2h | 2,922.8 | 4. Casa 4 | 0. Térreo | 24 | 21. HS1 | Própria | 24 |  |
| 873 | 1.4.4.1.7 | 7.Fiação | 4d | 2021-08-02 | 2021-08-05 | 14d | eletricista; aux. eletricista | 70.4h | 11,873.92 | 4. Casa 4 | 0. Térreo | 25 | 20. Elétrica1 | Própria | 25 |  |
| 874 | 1.4.4.1.8 | 8.Interr. Tom e luminárias | 1d | 2021-08-02 | 2021-08-02 | 17d | eletricista; aux. eletricista | 17.6h | 6,963.62 | 4. Casa 4 | 0. Térreo | 26 | 20. Elétrica1 | Própria | 26 |  |
| 875 | 1.4.4.1.9 | 9.Quadro elétrico | 2d | 2021-08-02 | 2021-08-03 | 16d | eletricista; aux. eletricista | 35.2h | 1,788.87 | 4. Casa 4 | 0. Térreo | 27 | 20. Elétrica1 | Própria | 27 |  |
| 876 | 1.4.4.1.10 | 10.Louças e Metais | 2d | 2021-08-02 | 2021-08-03 | 16d | aux. bombeiro; bombeiro | 35.2h | 6,591.75 | 4. Casa 4 | 0. Térreo | 28 | 21. HS1 | Própria | 28 | 10 |
| 877 | 1.4.4.2 | **1. Pav. Superior** | 4d | 2021-08-02 | 2021-08-05 | 14d |  | 334.4h | 21,866.33 |  |  |  |  |  |  |  |
| 878 | 1.4.4.2.1 | 2.Inst. Elétricas Laje | 2d | 2021-08-02 | 2021-08-03 | 16d | eletricista; aux. eletricista | 35.2h | 2,995.3 | 4. Casa 4 | 1. Pav. Superior | 20 | 20. Elétrica1 | Própria | 20 |  |
| 879 | 1.4.4.2.2 | 3.Inst. Elétricas Paredes | 2d | 2021-08-02 | 2021-08-03 | 16d | eletricista; aux. eletricista | 35.2h | 766.33 | 4. Casa 4 | 1. Pav. Superior | 21 | 20. Elétrica1 | Própria | 21 |  |
| 880 | 1.4.4.2.3 | 4.Inst. Gás | 2d | 2021-08-02 | 2021-08-03 | 16d | aux. bombeiro; bombeiro | 35.2h | 1,371.29 | 4. Casa 4 | 1. Pav. Superior | 22 | 21. HS1 | Própria | 22 |  |
| 881 | 1.4.4.2.4 | 5.Inst. AF e AQ | 2d | 2021-08-02 | 2021-08-03 | 16d | aux. bombeiro; bombeiro | 35.2h | 2,426.07 | 4. Casa 4 | 1. Pav. Superior | 23 | 21. HS1 | Própria | 23 |  |
| 882 | 1.4.4.2.5 | 6.Inst. Esgoto | 2d | 2021-08-02 | 2021-08-03 | 16d | aux. bombeiro; bombeiro | 35.2h | 1,546.11 | 4. Casa 4 | 1. Pav. Superior | 24 | 21. HS1 | Própria | 24 |  |
| 883 | 1.4.4.2.6 | 7.Fiação | 4d | 2021-08-02 | 2021-08-05 | 14d | eletricista; aux. eletricista | 70.4h | 5,338.91 | 4. Casa 4 | 1. Pav. Superior | 25 | 20. Elétrica1 | Própria | 25 |  |
| 884 | 1.4.4.2.7 | 8.Interr. Tom e luminárias | 1d | 2021-08-02 | 2021-08-02 | 17d | eletricista; aux. eletricista | 17.6h | 3,131.08 | 4. Casa 4 | 1. Pav. Superior | 26 | 20. Elétrica1 | Própria | 26 |  |
| 885 | 1.4.4.2.8 | 9.Quadro elétrico | 2d | 2021-08-02 | 2021-08-03 | 16d | eletricista; aux. eletricista | 35.2h | 804.33 | 4. Casa 4 | 1. Pav. Superior | 27 | 20. Elétrica1 | Própria | 27 |  |
| 886 | 1.4.4.2.9 | 10.Louças e Metais | 2d | 2021-08-02 | 2021-08-03 | 16d | aux. bombeiro; bombeiro | 35.2h | 3,486.91 | 4. Casa 4 | 1. Pav. Superior | 28 | 21. HS1 | Própria | 28 | 10 |
| 887 | 1.4.4.3 | **2. Coberta** | 2d | 2021-08-02 | 2021-08-03 | 16d |  | 70.4h | 2,943.46 |  |  |  |  |  |  |  |
| 888 | 1.4.4.3.1 | Barrilette | 2d | 2021-08-02 | 2021-08-03 | 16d | aux. bombeiro; bombeiro | 35.2h | 1,177.38 | 4. Casa 4 | 2. Coberta | 29 | 21. HS1 | Própria | 29 | 11 |
| 889 | 1.4.4.3.2 | Caixa D'água | 2d | 2021-08-02 | 2021-08-03 | 16d | aux. bombeiro; bombeiro | 35.2h | 1,766.08 | 4. Casa 4 | 2. Coberta | 30 | 21. HS1 | Própria | 30 | 11 |

| ID | WBS | Task | Duration | Start | Finish | Total slack | Resources | Work | Cost | Casa | Pav | Pacote | Equipe | Empresa | LB | Cor |
| --- | --- | --- | --- | --- | --- | --- | --- | --- | --- | --- | --- | --- | --- | --- | --- | --- |
| 890 | 1.4.5 | **5. Casa 5** | 4d | 2021-08-02 | 2021-08-05 | 14d |  | 774.4h | 72,049.62 |  |  |  |  |  |  |  |
| 891 | 1.4.5.1 | **0. Térreo** | 4d | 2021-08-02 | 2021-08-05 | 14d |  | 369.6h | 47,239.83 |  |  |  |  |  |  |  |
| 892 | 1.4.5.1.1 | 1.Inst. Embut. Em Fundações | 2d | 2021-08-02 | 2021-08-03 | 16d | bombeiro; eletricista | 35.2h | 1,554.25 | 5. Casa 5 | 0. Térreo | 19 | 19. Instalações1 | Própria | 19 |  |
| 893 | 1.4.5.1.2 | 2.Inst. Elétricas Laje | 2d | 2021-08-02 | 2021-08-03 | 16d | eletricista; aux. eletricista | 35.2h | 6,661.65 | 5. Casa 5 | 0. Térreo | 20 | 20. Elétrica1 | Própria | 20 |  |
| 894 | 1.4.5.1.3 | 3.Inst. Elétricas Paredes | 2d | 2021-08-02 | 2021-08-03 | 16d | eletricista; aux. eletricista | 35.2h | 1,704.34 | 5. Casa 5 | 0. Térreo | 21 | 21. HS1 | Própria | 21 |  |
| 895 | 1.4.5.1.4 | 4.Inst. Gás | 2d | 2021-08-02 | 2021-08-03 | 16d | aux. bombeiro; bombeiro | 35.2h | 2,592.32 | 5. Casa 5 | 0. Térreo | 22 | 21. HS1 | Própria | 22 |  |
| 896 | 1.4.5.1.5 | 5.Inst. AF e AQ | 2d | 2021-08-02 | 2021-08-03 | 16d | aux. bombeiro; bombeiro | 35.2h | 4,586.31 | 5. Casa 5 | 0. Térreo | 23 | 21. HS1 | Própria | 23 |  |
| 897 | 1.4.5.1.6 | 6.Inst. Esgoto | 2d | 2021-08-02 | 2021-08-03 | 16d | aux. bombeiro; bombeiro | 35.2h | 2,922.8 | 5. Casa 5 | 0. Térreo | 24 | 21. HS1 | Própria | 24 |  |
| 898 | 1.4.5.1.7 | 7.Fiação | 4d | 2021-08-02 | 2021-08-05 | 14d | eletricista; aux. eletricista | 70.4h | 11,873.92 | 5. Casa 5 | 0. Térreo | 25 | 20. Elétrica1 | Própria | 25 |  |
| 899 | 1.4.5.1.8 | 8.Interr. Tom e luminárias | 1d | 2021-08-02 | 2021-08-02 | 17d | eletricista; aux. eletricista | 17.6h | 6,963.62 | 5. Casa 5 | 0. Térreo | 26 | 20. Elétrica1 | Própria | 26 |  |
| 900 | 1.4.5.1.9 | 9.Quadro elétrico | 2d | 2021-08-02 | 2021-08-03 | 16d | eletricista; aux. eletricista | 35.2h | 1,788.87 | 5. Casa 5 | 0. Térreo | 27 | 20. Elétrica1 | Própria | 27 |  |
| 901 | 1.4.5.1.10 | 10.Louças e Metais | 2d | 2021-08-02 | 2021-08-03 | 16d | aux. bombeiro; bombeiro | 35.2h | 6,591.75 | 5. Casa 5 | 0. Térreo | 28 | 21. HS1 | Própria | 28 | 10 |
| 902 | 1.4.5.2 | **1. Pav. Superior** | 4d | 2021-08-02 | 2021-08-05 | 14d |  | 334.4h | 21,866.33 |  |  |  |  |  |  |  |
| 903 | 1.4.5.2.1 | 2.Inst. Elétricas Laje | 2d | 2021-08-02 | 2021-08-03 | 16d | eletricista; aux. eletricista | 35.2h | 2,995.3 | 5. Casa 5 | 1. Pav. Superior | 20 | 20. Elétrica1 | Própria | 20 |  |
| 904 | 1.4.5.2.2 | 3.Inst. Elétricas Paredes | 2d | 2021-08-02 | 2021-08-03 | 16d | eletricista; aux. eletricista | 35.2h | 766.33 | 5. Casa 5 | 1. Pav. Superior | 21 | 20. Elétrica1 | Própria | 21 |  |
| 905 | 1.4.5.2.3 | 4.Inst. Gás | 2d | 2021-08-02 | 2021-08-03 | 16d | aux. bombeiro; bombeiro | 35.2h | 1,371.29 | 5. Casa 5 | 1. Pav. Superior | 22 | 21. HS1 | Própria | 22 |  |
| 906 | 1.4.5.2.4 | 5.Inst. AF e AQ | 2d | 2021-08-02 | 2021-08-03 | 16d | aux. bombeiro; bombeiro | 35.2h | 2,426.07 | 5. Casa 5 | 1. Pav. Superior | 23 | 21. HS1 | Própria | 23 |  |
| 907 | 1.4.5.2.5 | 6.Inst. Esgoto | 2d | 2021-08-02 | 2021-08-03 | 16d | aux. bombeiro; bombeiro | 35.2h | 1,546.11 | 5. Casa 5 | 1. Pav. Superior | 24 | 21. HS1 | Própria | 24 |  |
| 908 | 1.4.5.2.6 | 7.Fiação | 4d | 2021-08-02 | 2021-08-05 | 14d | eletricista; aux. eletricista | 70.4h | 5,338.91 | 5. Casa 5 | 1. Pav. Superior | 25 | 20. Elétrica1 | Própria | 25 |  |
| 909 | 1.4.5.2.7 | 8.Interr. Tom e luminárias | 1d | 2021-08-02 | 2021-08-02 | 17d | eletricista; aux. eletricista | 17.6h | 3,131.08 | 5. Casa 5 | 1. Pav. Superior | 26 | 20. Elétrica1 | Própria | 26 |  |
| 910 | 1.4.5.2.8 | 9.Quadro elétrico | 2d | 2021-08-02 | 2021-08-03 | 16d | eletricista; aux. eletricista | 35.2h | 804.33 | 5. Casa 5 | 1. Pav. Superior | 27 | 20. Elétrica1 | Própria | 27 |  |
| 911 | 1.4.5.2.9 | 10.Louças e Metais | 2d | 2021-08-02 | 2021-08-03 | 16d | aux. bombeiro; bombeiro | 35.2h | 3,486.91 | 5. Casa 5 | 1. Pav. Superior | 28 | 21. HS1 | Própria | 28 | 10 |
| 912 | 1.4.5.3 | **2. Coberta** | 2d | 2021-08-02 | 2021-08-03 | 16d |  | 70.4h | 2,943.46 |  |  |  |  |  |  |  |
| 913 | 1.4.5.3.1 | Barrilette | 2d | 2021-08-02 | 2021-08-03 | 16d | aux. bombeiro; bombeiro | 35.2h | 1,177.38 | 5. Casa 5 | 2. Coberta | 29 | 21. HS1 | Própria | 29 | 11 |
| 914 | 1.4.5.3.2 | Caixa D'água | 2d | 2021-08-02 | 2021-08-03 | 16d | aux. bombeiro; bombeiro | 35.2h | 1,766.08 | 5. Casa 5 | 2. Coberta | 30 | 21. HS1 | Própria | 30 | 11 |

| ID | WBS | Task | Duration | Start | Finish | Total slack | Resources | Work | Cost | Casa | Pav | Pacote | Equipe | Empresa | LB | Cor |
| --- | --- | --- | --- | --- | --- | --- | --- | --- | --- | --- | --- | --- | --- | --- | --- | --- |
| 915 | 1.4.6 | **6. Casa 6** | 4d | 2021-08-02 | 2021-08-05 | 14d |  | 774.4h | 72,049.62 |  |  |  |  |  |  |  |
| 916 | 1.4.6.1 | **0. Térreo** | 4d | 2021-08-02 | 2021-08-05 | 14d |  | 369.6h | 47,239.83 |  |  |  |  |  |  |  |
| 917 | 1.4.6.1.1 | 1.Inst. Embut. Em Fundações | 2d | 2021-08-02 | 2021-08-03 | 16d | bombeiro; eletricista | 35.2h | 1,554.25 | 6. Casa 6 | 0. Térreo | 19 | 19. Instalações1 | Própria | 19 |  |
| 918 | 1.4.6.1.2 | 2.Inst. Elétricas Laje | 2d | 2021-08-02 | 2021-08-03 | 16d | eletricista; aux. eletricista | 35.2h | 6,661.65 | 6. Casa 6 | 0. Térreo | 20 | 20. Elétrica1 | Própria | 20 |  |
| 919 | 1.4.6.1.3 | 3.Inst. Elétricas Paredes | 2d | 2021-08-02 | 2021-08-03 | 16d | eletricista; aux. eletricista | 35.2h | 1,704.34 | 6. Casa 6 | 0. Térreo | 21 | 21. HS1 | Própria | 21 |  |
| 920 | 1.4.6.1.4 | 4.Inst. Gás | 2d | 2021-08-02 | 2021-08-03 | 16d | aux. bombeiro; bombeiro | 35.2h | 2,592.32 | 6. Casa 6 | 0. Térreo | 22 | 21. HS1 | Própria | 22 |  |
| 921 | 1.4.6.1.5 | 5.Inst. AF e AQ | 2d | 2021-08-02 | 2021-08-03 | 16d | aux. bombeiro; bombeiro | 35.2h | 4,586.31 | 6. Casa 6 | 0. Térreo | 23 | 21. HS1 | Própria | 23 |  |
| 922 | 1.4.6.1.6 | 6.Inst. Esgoto | 2d | 2021-08-02 | 2021-08-03 | 16d | aux. bombeiro; bombeiro | 35.2h | 2,922.8 | 6. Casa 6 | 0. Térreo | 24 | 21. HS1 | Própria | 24 |  |
| 923 | 1.4.6.1.7 | 7.Fiação | 4d | 2021-08-02 | 2021-08-05 | 14d | eletricista; aux. eletricista | 70.4h | 11,873.92 | 6. Casa 6 | 0. Térreo | 25 | 20. Elétrica1 | Própria | 25 |  |
| 924 | 1.4.6.1.8 | 8.Interr. Tom e luminárias | 1d | 2021-08-02 | 2021-08-02 | 17d | eletricista; aux. eletricista | 17.6h | 6,963.62 | 6. Casa 6 | 0. Térreo | 26 | 20. Elétrica1 | Própria | 26 |  |
| 925 | 1.4.6.1.9 | 9.Quadro elétrico | 2d | 2021-08-02 | 2021-08-03 | 16d | eletricista; aux. eletricista | 35.2h | 1,788.87 | 6. Casa 6 | 0. Térreo | 27 | 20. Elétrica1 | Própria | 27 |  |
| 926 | 1.4.6.1.10 | 10.Louças e Metais | 2d | 2021-08-02 | 2021-08-03 | 16d | aux. bombeiro; bombeiro | 35.2h | 6,591.75 | 6. Casa 6 | 0. Térreo | 28 | 21. HS1 | Própria | 28 | 10 |
| 927 | 1.4.6.2 | **1. Pav. Superior** | 4d | 2021-08-02 | 2021-08-05 | 14d |  | 334.4h | 21,866.33 |  |  |  |  |  |  |  |
| 928 | 1.4.6.2.1 | 2.Inst. Elétricas Laje | 2d | 2021-08-02 | 2021-08-03 | 16d | eletricista; aux. eletricista | 35.2h | 2,995.3 | 6. Casa 6 | 1. Pav. Superior | 20 | 20. Elétrica1 | Própria | 20 |  |
| 929 | 1.4.6.2.2 | 3.Inst. Elétricas Paredes | 2d | 2021-08-02 | 2021-08-03 | 16d | eletricista; aux. eletricista | 35.2h | 766.33 | 6. Casa 6 | 1. Pav. Superior | 21 | 20. Elétrica1 | Própria | 21 |  |
| 930 | 1.4.6.2.3 | 4.Inst. Gás | 2d | 2021-08-02 | 2021-08-03 | 16d | aux. bombeiro; bombeiro | 35.2h | 1,371.29 | 6. Casa 6 | 1. Pav. Superior | 22 | 21. HS1 | Própria | 22 |  |
| 931 | 1.4.6.2.4 | 5.Inst. AF e AQ | 2d | 2021-08-02 | 2021-08-03 | 16d | aux. bombeiro; bombeiro | 35.2h | 2,426.07 | 6. Casa 6 | 1. Pav. Superior | 23 | 21. HS1 | Própria | 23 |  |
| 932 | 1.4.6.2.5 | 6.Inst. Esgoto | 2d | 2021-08-02 | 2021-08-03 | 16d | aux. bombeiro; bombeiro | 35.2h | 1,546.11 | 6. Casa 6 | 1. Pav. Superior | 24 | 21. HS1 | Própria | 24 |  |
| 933 | 1.4.6.2.6 | 7.Fiação | 4d | 2021-08-02 | 2021-08-05 | 14d | eletricista; aux. eletricista | 70.4h | 5,338.91 | 6. Casa 6 | 1. Pav. Superior | 25 | 20. Elétrica1 | Própria | 25 |  |
| 934 | 1.4.6.2.7 | 8.Interr. Tom e luminárias | 1d | 2021-08-02 | 2021-08-02 | 17d | eletricista; aux. eletricista | 17.6h | 3,131.08 | 6. Casa 6 | 1. Pav. Superior | 26 | 20. Elétrica1 | Própria | 26 |  |
| 935 | 1.4.6.2.8 | 9.Quadro elétrico | 2d | 2021-08-02 | 2021-08-03 | 16d | eletricista; aux. eletricista | 35.2h | 804.33 | 6. Casa 6 | 1. Pav. Superior | 27 | 20. Elétrica1 | Própria | 27 |  |
| 936 | 1.4.6.2.9 | 10.Louças e Metais | 2d | 2021-08-02 | 2021-08-03 | 16d | aux. bombeiro; bombeiro | 35.2h | 3,486.91 | 6. Casa 6 | 1. Pav. Superior | 28 | 21. HS1 | Própria | 28 | 10 |
| 937 | 1.4.6.3 | **2. Coberta** | 2d | 2021-08-02 | 2021-08-03 | 16d |  | 70.4h | 2,943.46 |  |  |  |  |  |  |  |
| 938 | 1.4.6.3.1 | Barrilette | 2d | 2021-08-02 | 2021-08-03 | 16d | aux. bombeiro; bombeiro | 35.2h | 1,177.38 | 6. Casa 6 | 2. Coberta | 29 | 21. HS1 | Própria | 29 | 11 |
| 939 | 1.4.6.3.2 | Caixa D'água | 2d | 2021-08-02 | 2021-08-03 | 16d | aux. bombeiro; bombeiro | 35.2h | 1,766.08 | 6. Casa 6 | 2. Coberta | 30 | 21. HS1 | Própria | 30 | 11 |

| ID | WBS | Task | Duration | Start | Finish | Total slack | Resources | Work | Cost | Casa | Pav | Pacote | Equipe | Empresa | LB | Cor |
| --- | --- | --- | --- | --- | --- | --- | --- | --- | --- | --- | --- | --- | --- | --- | --- | --- |
| 940 | 1.4.7 | **7. Casa 7** | 4d | 2021-08-02 | 2021-08-05 | 14d |  | 774.4h | 72,049.62 |  |  |  |  |  |  |  |
| 941 | 1.4.7.1 | **0. Térreo** | 4d | 2021-08-02 | 2021-08-05 | 14d |  | 369.6h | 47,239.83 |  |  |  |  |  |  |  |
| 942 | 1.4.7.1.1 | 1.Inst. Embut. Em Fundações | 2d | 2021-08-02 | 2021-08-03 | 16d | bombeiro; eletricista | 35.2h | 1,554.25 | 7. Casa 7 | 0. Térreo | 19 | 19. Instalações1 | Própria | 19 |  |
| 943 | 1.4.7.1.2 | 2.Inst. Elétricas Laje | 2d | 2021-08-02 | 2021-08-03 | 16d | eletricista; aux. eletricista | 35.2h | 6,661.65 | 7. Casa 7 | 0. Térreo | 20 | 20. Elétrica1 | Própria | 20 |  |
| 944 | 1.4.7.1.3 | 3.Inst. Elétricas Paredes | 2d | 2021-08-02 | 2021-08-03 | 16d | eletricista; aux. eletricista | 35.2h | 1,704.34 | 7. Casa 7 | 0. Térreo | 21 | 21. HS1 | Própria | 21 |  |
| 945 | 1.4.7.1.4 | 4.Inst. Gás | 2d | 2021-08-02 | 2021-08-03 | 16d | aux. bombeiro; bombeiro | 35.2h | 2,592.32 | 7. Casa 7 | 0. Térreo | 22 | 21. HS1 | Própria | 22 |  |
| 946 | 1.4.7.1.5 | 5.Inst. AF e AQ | 2d | 2021-08-02 | 2021-08-03 | 16d | aux. bombeiro; bombeiro | 35.2h | 4,586.31 | 7. Casa 7 | 0. Térreo | 23 | 21. HS1 | Própria | 23 |  |
| 947 | 1.4.7.1.6 | 6.Inst. Esgoto | 2d | 2021-08-02 | 2021-08-03 | 16d | aux. bombeiro; bombeiro | 35.2h | 2,922.8 | 7. Casa 7 | 0. Térreo | 24 | 21. HS1 | Própria | 24 |  |
| 948 | 1.4.7.1.7 | 7.Fiação | 4d | 2021-08-02 | 2021-08-05 | 14d | eletricista; aux. eletricista | 70.4h | 11,873.92 | 7. Casa 7 | 0. Térreo | 25 | 20. Elétrica1 | Própria | 25 |  |
| 949 | 1.4.7.1.8 | 8.Interr. Tom e luminárias | 1d | 2021-08-02 | 2021-08-02 | 17d | eletricista; aux. eletricista | 17.6h | 6,963.62 | 7. Casa 7 | 0. Térreo | 26 | 20. Elétrica1 | Própria | 26 |  |
| 950 | 1.4.7.1.9 | 9.Quadro elétrico | 2d | 2021-08-02 | 2021-08-03 | 16d | eletricista; aux. eletricista | 35.2h | 1,788.87 | 7. Casa 7 | 0. Térreo | 27 | 20. Elétrica1 | Própria | 27 |  |
| 951 | 1.4.7.1.10 | 10.Louças e Metais | 2d | 2021-08-02 | 2021-08-03 | 16d | aux. bombeiro; bombeiro | 35.2h | 6,591.75 | 7. Casa 7 | 0. Térreo | 28 | 21. HS1 | Própria | 28 | 10 |
| 952 | 1.4.7.2 | **1. Pav. Superior** | 4d | 2021-08-02 | 2021-08-05 | 14d |  | 334.4h | 21,866.33 |  |  |  |  |  |  |  |
| 953 | 1.4.7.2.1 | 2.Inst. Elétricas Laje | 2d | 2021-08-02 | 2021-08-03 | 16d | eletricista; aux. eletricista | 35.2h | 2,995.3 | 7. Casa 7 | 1. Pav. Superior | 20 | 20. Elétrica1 | Própria | 20 |  |
| 954 | 1.4.7.2.2 | 3.Inst. Elétricas Paredes | 2d | 2021-08-02 | 2021-08-03 | 16d | eletricista; aux. eletricista | 35.2h | 766.33 | 7. Casa 7 | 1. Pav. Superior | 21 | 20. Elétrica1 | Própria | 21 |  |
| 955 | 1.4.7.2.3 | 4.Inst. Gás | 2d | 2021-08-02 | 2021-08-03 | 16d | aux. bombeiro; bombeiro | 35.2h | 1,371.29 | 7. Casa 7 | 1. Pav. Superior | 22 | 21. HS1 | Própria | 22 |  |
| 956 | 1.4.7.2.4 | 5.Inst. AF e AQ | 2d | 2021-08-02 | 2021-08-03 | 16d | aux. bombeiro; bombeiro | 35.2h | 2,426.07 | 7. Casa 7 | 1. Pav. Superior | 23 | 21. HS1 | Própria | 23 |  |
| 957 | 1.4.7.2.5 | 6.Inst. Esgoto | 2d | 2021-08-02 | 2021-08-03 | 16d | aux. bombeiro; bombeiro | 35.2h | 1,546.11 | 7. Casa 7 | 1. Pav. Superior | 24 | 21. HS1 | Própria | 24 |  |
| 958 | 1.4.7.2.6 | 7.Fiação | 4d | 2021-08-02 | 2021-08-05 | 14d | eletricista; aux. eletricista | 70.4h | 5,338.91 | 7. Casa 7 | 1. Pav. Superior | 25 | 20. Elétrica1 | Própria | 25 |  |
| 959 | 1.4.7.2.7 | 8.Interr. Tom e luminárias | 1d | 2021-08-02 | 2021-08-02 | 17d | eletricista; aux. eletricista | 17.6h | 3,131.08 | 7. Casa 7 | 1. Pav. Superior | 26 | 20. Elétrica1 | Própria | 26 |  |
| 960 | 1.4.7.2.8 | 9.Quadro elétrico | 2d | 2021-08-02 | 2021-08-03 | 16d | eletricista; aux. eletricista | 35.2h | 804.33 | 7. Casa 7 | 1. Pav. Superior | 27 | 20. Elétrica1 | Própria | 27 |  |
| 961 | 1.4.7.2.9 | 10.Louças e Metais | 2d | 2021-08-02 | 2021-08-03 | 16d | aux. bombeiro; bombeiro | 35.2h | 3,486.91 | 7. Casa 7 | 1. Pav. Superior | 28 | 21. HS1 | Própria | 28 | 10 |
| 962 | 1.4.7.3 | **2. Coberta** | 2d | 2021-08-02 | 2021-08-03 | 16d |  | 70.4h | 2,943.46 |  |  |  |  |  |  |  |
| 963 | 1.4.7.3.1 | Barrilette | 2d | 2021-08-02 | 2021-08-03 | 16d | aux. bombeiro; bombeiro | 35.2h | 1,177.38 | 7. Casa 7 | 2. Coberta | 29 | 21. HS1 | Própria | 29 | 11 |
| 964 | 1.4.7.3.2 | Caixa D'água | 2d | 2021-08-02 | 2021-08-03 | 16d | aux. bombeiro; bombeiro | 35.2h | 1,766.08 | 7. Casa 7 | 2. Coberta | 30 | 21. HS1 | Própria | 30 | 11 |

| ID | WBS | Task | Duration | Start | Finish | Total slack | Resources | Work | Cost | Casa | Pav | Pacote | Equipe | Empresa | LB | Cor |
| --- | --- | --- | --- | --- | --- | --- | --- | --- | --- | --- | --- | --- | --- | --- | --- | --- |
| 965 | 1.4.8 | **8. Casa 8** | 4d | 2021-08-02 | 2021-08-05 | 14d |  | 774.4h | 72,049.62 |  |  |  |  |  |  |  |
| 966 | 1.4.8.1 | **0. Térreo** | 4d | 2021-08-02 | 2021-08-05 | 14d |  | 369.6h | 47,239.83 |  |  |  |  |  |  |  |
| 967 | 1.4.8.1.1 | 1.Inst. Embut. Em Fundações | 2d | 2021-08-02 | 2021-08-03 | 16d | bombeiro; eletricista | 35.2h | 1,554.25 | 8. Casa 8 | 0. Térreo | 19 | 19. Instalações1 | Própria | 19 |  |
| 968 | 1.4.8.1.2 | 2.Inst. Elétricas Laje | 2d | 2021-08-02 | 2021-08-03 | 16d | eletricista; aux. eletricista | 35.2h | 6,661.65 | 8. Casa 8 | 0. Térreo | 20 | 20. Elétrica1 | Própria | 20 |  |
| 969 | 1.4.8.1.3 | 3.Inst. Elétricas Paredes | 2d | 2021-08-02 | 2021-08-03 | 16d | eletricista; aux. eletricista | 35.2h | 1,704.34 | 8. Casa 8 | 0. Térreo | 21 | 21. HS1 | Própria | 21 |  |
| 970 | 1.4.8.1.4 | 4.Inst. Gás | 2d | 2021-08-02 | 2021-08-03 | 16d | aux. bombeiro; bombeiro | 35.2h | 2,592.32 | 8. Casa 8 | 0. Térreo | 22 | 21. HS1 | Própria | 22 |  |
| 971 | 1.4.8.1.5 | 5.Inst. AF e AQ | 2d | 2021-08-02 | 2021-08-03 | 16d | aux. bombeiro; bombeiro | 35.2h | 4,586.31 | 8. Casa 8 | 0. Térreo | 23 | 21. HS1 | Própria | 23 |  |
| 972 | 1.4.8.1.6 | 6.Inst. Esgoto | 2d | 2021-08-02 | 2021-08-03 | 16d | aux. bombeiro; bombeiro | 35.2h | 2,922.8 | 8. Casa 8 | 0. Térreo | 24 | 21. HS1 | Própria | 24 |  |
| 973 | 1.4.8.1.7 | 7.Fiação | 4d | 2021-08-02 | 2021-08-05 | 14d | eletricista; aux. eletricista | 70.4h | 11,873.92 | 8. Casa 8 | 0. Térreo | 25 | 20. Elétrica1 | Própria | 25 |  |
| 974 | 1.4.8.1.8 | 8.Interr. Tom e luminárias | 1d | 2021-08-02 | 2021-08-02 | 17d | eletricista; aux. eletricista | 17.6h | 6,963.62 | 8. Casa 8 | 0. Térreo | 26 | 20. Elétrica1 | Própria | 26 |  |
| 975 | 1.4.8.1.9 | 9.Quadro elétrico | 2d | 2021-08-02 | 2021-08-03 | 16d | eletricista; aux. eletricista | 35.2h | 1,788.87 | 8. Casa 8 | 0. Térreo | 27 | 20. Elétrica1 | Própria | 27 |  |
| 976 | 1.4.8.1.10 | 10.Louças e Metais | 2d | 2021-08-02 | 2021-08-03 | 16d | aux. bombeiro; bombeiro | 35.2h | 6,591.75 | 8. Casa 8 | 0. Térreo | 28 | 21. HS1 | Própria | 28 | 10 |
| 977 | 1.4.8.2 | **1. Pav. Superior** | 4d | 2021-08-02 | 2021-08-05 | 14d |  | 334.4h | 21,866.33 |  |  |  |  |  |  |  |
| 978 | 1.4.8.2.1 | 2.Inst. Elétricas Laje | 2d | 2021-08-02 | 2021-08-03 | 16d | eletricista; aux. eletricista | 35.2h | 2,995.3 | 8. Casa 8 | 1. Pav. Superior | 20 | 20. Elétrica1 | Própria | 20 |  |
| 979 | 1.4.8.2.2 | 3.Inst. Elétricas Paredes | 2d | 2021-08-02 | 2021-08-03 | 16d | eletricista; aux. eletricista | 35.2h | 766.33 | 8. Casa 8 | 1. Pav. Superior | 21 | 20. Elétrica1 | Própria | 21 |  |
| 980 | 1.4.8.2.3 | 4.Inst. Gás | 2d | 2021-08-02 | 2021-08-03 | 16d | aux. bombeiro; bombeiro | 35.2h | 1,371.29 | 8. Casa 8 | 1. Pav. Superior | 22 | 21. HS1 | Própria | 22 |  |
| 981 | 1.4.8.2.4 | 5.Inst. AF e AQ | 2d | 2021-08-02 | 2021-08-03 | 16d | aux. bombeiro; bombeiro | 35.2h | 2,426.07 | 8. Casa 8 | 1. Pav. Superior | 23 | 21. HS1 | Própria | 23 |  |
| 982 | 1.4.8.2.5 | 6.Inst. Esgoto | 2d | 2021-08-02 | 2021-08-03 | 16d | aux. bombeiro; bombeiro | 35.2h | 1,546.11 | 8. Casa 8 | 1. Pav. Superior | 24 | 21. HS1 | Própria | 24 |  |
| 983 | 1.4.8.2.6 | 7.Fiação | 4d | 2021-08-02 | 2021-08-05 | 14d | eletricista; aux. eletricista | 70.4h | 5,338.91 | 8. Casa 8 | 1. Pav. Superior | 25 | 20. Elétrica1 | Própria | 25 |  |
| 984 | 1.4.8.2.7 | 8.Interr. Tom e luminárias | 1d | 2021-08-02 | 2021-08-02 | 17d | eletricista; aux. eletricista | 17.6h | 3,131.08 | 8. Casa 8 | 1. Pav. Superior | 26 | 20. Elétrica1 | Própria | 26 |  |
| 985 | 1.4.8.2.8 | 9.Quadro elétrico | 2d | 2021-08-02 | 2021-08-03 | 16d | eletricista; aux. eletricista | 35.2h | 804.33 | 8. Casa 8 | 1. Pav. Superior | 27 | 20. Elétrica1 | Própria | 27 |  |
| 986 | 1.4.8.2.9 | 10.Louças e Metais | 2d | 2021-08-02 | 2021-08-03 | 16d | aux. bombeiro; bombeiro | 35.2h | 3,486.91 | 8. Casa 8 | 1. Pav. Superior | 28 | 21. HS1 | Própria | 28 | 10 |
| 987 | 1.4.8.3 | **2. Coberta** | 2d | 2021-08-02 | 2021-08-03 | 16d |  | 70.4h | 2,943.46 |  |  |  |  |  |  |  |
| 988 | 1.4.8.3.1 | Barrilette | 2d | 2021-08-02 | 2021-08-03 | 16d | aux. bombeiro; bombeiro | 35.2h | 1,177.38 | 8. Casa 8 | 2. Coberta | 29 | 21. HS1 | Própria | 29 | 11 |
| 989 | 1.4.8.3.2 | Caixa D'água | 2d | 2021-08-02 | 2021-08-03 | 16d | aux. bombeiro; bombeiro | 35.2h | 1,766.08 | 8. Casa 8 | 2. Coberta | 30 | 21. HS1 | Própria | 30 | 11 |

| ID | WBS | Task | Duration | Start | Finish | Total slack | Resources | Work | Cost | Casa | Pav | Pacote | Equipe | Empresa | LB | Cor |
| --- | --- | --- | --- | --- | --- | --- | --- | --- | --- | --- | --- | --- | --- | --- | --- | --- |
| 990 | 1.4.9 | **9. Casa 9** | 4d | 2021-08-02 | 2021-08-05 | 14d |  | 774.4h | 72,049.62 |  |  |  |  |  |  |  |
| 991 | 1.4.9.1 | **0. Térreo** | 4d | 2021-08-02 | 2021-08-05 | 14d |  | 369.6h | 47,239.83 |  |  |  |  |  |  |  |
| 992 | 1.4.9.1.1 | 1.Inst. Embut. Em Fundações | 2d | 2021-08-02 | 2021-08-03 | 16d | bombeiro; eletricista | 35.2h | 1,554.25 | 9. Casa 9 | 0. Térreo | 19 | 19. Instalações1 | Própria | 19 |  |
| 993 | 1.4.9.1.2 | 2.Inst. Elétricas Laje | 2d | 2021-08-02 | 2021-08-03 | 16d | eletricista; aux. eletricista | 35.2h | 6,661.65 | 9. Casa 9 | 0. Térreo | 20 | 20. Elétrica1 | Própria | 20 |  |
| 994 | 1.4.9.1.3 | 3.Inst. Elétricas Paredes | 2d | 2021-08-02 | 2021-08-03 | 16d | eletricista; aux. eletricista | 35.2h | 1,704.34 | 9. Casa 9 | 0. Térreo | 21 | 21. HS1 | Própria | 21 |  |
| 995 | 1.4.9.1.4 | 4.Inst. Gás | 2d | 2021-08-02 | 2021-08-03 | 16d | aux. bombeiro; bombeiro | 35.2h | 2,592.32 | 9. Casa 9 | 0. Térreo | 22 | 21. HS1 | Própria | 22 |  |
| 996 | 1.4.9.1.5 | 5.Inst. AF e AQ | 2d | 2021-08-02 | 2021-08-03 | 16d | aux. bombeiro; bombeiro | 35.2h | 4,586.31 | 9. Casa 9 | 0. Térreo | 23 | 21. HS1 | Própria | 23 |  |
| 997 | 1.4.9.1.6 | 6.Inst. Esgoto | 2d | 2021-08-02 | 2021-08-03 | 16d | aux. bombeiro; bombeiro | 35.2h | 2,922.8 | 9. Casa 9 | 0. Térreo | 24 | 21. HS1 | Própria | 24 |  |
| 998 | 1.4.9.1.7 | 7.Fiação | 4d | 2021-08-02 | 2021-08-05 | 14d | eletricista; aux. eletricista | 70.4h | 11,873.92 | 9. Casa 9 | 0. Térreo | 25 | 20. Elétrica1 | Própria | 25 |  |
| 999 | 1.4.9.1.8 | 8.Interr. Tom e luminárias | 1d | 2021-08-02 | 2021-08-02 | 17d | eletricista; aux. eletricista | 17.6h | 6,963.62 | 9. Casa 9 | 0. Térreo | 26 | 20. Elétrica1 | Própria | 26 |  |
| 1000 | 1.4.9.1.9 | 9.Quadro elétrico | 2d | 2021-08-02 | 2021-08-03 | 16d | eletricista; aux. eletricista | 35.2h | 1,788.87 | 9. Casa 9 | 0. Térreo | 27 | 20. Elétrica1 | Própria | 27 |  |
| 1001 | 1.4.9.1.10 | 10.Louças e Metais | 2d | 2021-08-02 | 2021-08-03 | 16d | aux. bombeiro; bombeiro | 35.2h | 6,591.75 | 9. Casa 9 | 0. Térreo | 28 | 21. HS1 | Própria | 28 | 10 |
| 1002 | 1.4.9.2 | **1. Pav. Superior** | 4d | 2021-08-02 | 2021-08-05 | 14d |  | 334.4h | 21,866.33 |  |  |  |  |  |  |  |
| 1003 | 1.4.9.2.1 | 2.Inst. Elétricas Laje | 2d | 2021-08-02 | 2021-08-03 | 16d | eletricista; aux. eletricista | 35.2h | 2,995.3 | 9. Casa 9 | 1. Pav. Superior | 20 | 20. Elétrica1 | Própria | 20 |  |
| 1004 | 1.4.9.2.2 | 3.Inst. Elétricas Paredes | 2d | 2021-08-02 | 2021-08-03 | 16d | eletricista; aux. eletricista | 35.2h | 766.33 | 9. Casa 9 | 1. Pav. Superior | 21 | 20. Elétrica1 | Própria | 21 |  |
| 1005 | 1.4.9.2.3 | 4.Inst. Gás | 2d | 2021-08-02 | 2021-08-03 | 16d | aux. bombeiro; bombeiro | 35.2h | 1,371.29 | 9. Casa 9 | 1. Pav. Superior | 22 | 21. HS1 | Própria | 22 |  |
| 1006 | 1.4.9.2.4 | 5.Inst. AF e AQ | 2d | 2021-08-02 | 2021-08-03 | 16d | aux. bombeiro; bombeiro | 35.2h | 2,426.07 | 9. Casa 9 | 1. Pav. Superior | 23 | 21. HS1 | Própria | 23 |  |
| 1007 | 1.4.9.2.5 | 6.Inst. Esgoto | 2d | 2021-08-02 | 2021-08-03 | 16d | aux. bombeiro; bombeiro | 35.2h | 1,546.11 | 9. Casa 9 | 1. Pav. Superior | 24 | 21. HS1 | Própria | 24 |  |
| 1008 | 1.4.9.2.6 | 7.Fiação | 4d | 2021-08-02 | 2021-08-05 | 14d | eletricista; aux. eletricista | 70.4h | 5,338.91 | 9. Casa 9 | 1. Pav. Superior | 25 | 20. Elétrica1 | Própria | 25 |  |
| 1009 | 1.4.9.2.7 | 8.Interr. Tom e luminárias | 1d | 2021-08-02 | 2021-08-02 | 17d | eletricista; aux. eletricista | 17.6h | 3,131.08 | 9. Casa 9 | 1. Pav. Superior | 26 | 20. Elétrica1 | Própria | 26 |  |
| 1010 | 1.4.9.2.8 | 9.Quadro elétrico | 2d | 2021-08-02 | 2021-08-03 | 16d | eletricista; aux. eletricista | 35.2h | 804.33 | 9. Casa 9 | 1. Pav. Superior | 27 | 20. Elétrica1 | Própria | 27 |  |
| 1011 | 1.4.9.2.9 | 10.Louças e Metais | 2d | 2021-08-02 | 2021-08-03 | 16d | aux. bombeiro; bombeiro | 35.2h | 3,486.91 | 9. Casa 9 | 1. Pav. Superior | 28 | 21. HS1 | Própria | 28 | 10 |
| 1012 | 1.4.9.3 | **2. Coberta** | 2d | 2021-08-02 | 2021-08-03 | 16d |  | 70.4h | 2,943.46 |  |  |  |  |  |  |  |
| 1013 | 1.4.9.3.1 | Barrilette | 2d | 2021-08-02 | 2021-08-03 | 16d | aux. bombeiro; bombeiro | 35.2h | 1,177.38 | 9. Casa 9 | 2. Coberta | 29 | 21. HS1 | Própria | 29 | 11 |
| 1014 | 1.4.9.3.2 | Caixa D'água | 2d | 2021-08-02 | 2021-08-03 | 16d | aux. bombeiro; bombeiro | 35.2h | 1,766.08 | 9. Casa 9 | 2. Coberta | 30 | 21. HS1 | Própria | 30 | 11 |

| ID | WBS | Task | Duration | Start | Finish | Total slack | Resources | Work | Cost | Casa | Pav | Pacote | Equipe | Empresa | LB | Cor |
| --- | --- | --- | --- | --- | --- | --- | --- | --- | --- | --- | --- | --- | --- | --- | --- | --- |
| 1015 | 1.4.10 | **10. Casa 10** | 4d | 2021-08-02 | 2021-08-05 | 14d |  | 774.4h | 72,049.62 |  |  |  |  |  |  |  |
| 1016 | 1.4.10.1 | **0. Térreo** | 4d | 2021-08-02 | 2021-08-05 | 14d |  | 369.6h | 47,239.83 |  |  |  |  |  |  |  |
| 1017 | 1.4.10.1.1 | 1.Inst. Embut. Em Fundações | 2d | 2021-08-02 | 2021-08-03 | 16d | bombeiro; eletricista | 35.2h | 1,554.25 | 10. Casa 10 | 0. Térreo | 19 | 19. Instalações1 | Própria | 19 |  |
| 1018 | 1.4.10.1.2 | 2.Inst. Elétricas Laje | 2d | 2021-08-02 | 2021-08-03 | 16d | eletricista; aux. eletricista | 35.2h | 6,661.65 | 10. Casa 10 | 0. Térreo | 20 | 20. Elétrica1 | Própria | 20 |  |
| 1019 | 1.4.10.1.3 | 3.Inst. Elétricas Paredes | 2d | 2021-08-02 | 2021-08-03 | 16d | eletricista; aux. eletricista | 35.2h | 1,704.34 | 10. Casa 10 | 0. Térreo | 21 | 21. HS1 | Própria | 21 |  |
| 1020 | 1.4.10.1.4 | 4.Inst. Gás | 2d | 2021-08-02 | 2021-08-03 | 16d | aux. bombeiro; bombeiro | 35.2h | 2,592.32 | 10. Casa 10 | 0. Térreo | 22 | 21. HS1 | Própria | 22 |  |
| 1021 | 1.4.10.1.5 | 5.Inst. AF e AQ | 2d | 2021-08-02 | 2021-08-03 | 16d | aux. bombeiro; bombeiro | 35.2h | 4,586.31 | 10. Casa 10 | 0. Térreo | 23 | 21. HS1 | Própria | 23 |  |
| 1022 | 1.4.10.1.6 | 6.Inst. Esgoto | 2d | 2021-08-02 | 2021-08-03 | 16d | aux. bombeiro; bombeiro | 35.2h | 2,922.8 | 1 0. Casa 10 | 0. Térreo | 24 | 21. HS1 | Própria | 24 |  |
| 1023 | 1.4.10.1.7 | 7.Fiação | 4d | 2021-08-02 | 2021-08-05 | 14d | eletricista; aux. eletricista | 70.4h | 11,873.92 | 10. Casa 10 | 0. Térreo | 25 | 20. Elétrica1 | Própria | 25 |  |
| 1024 | 1.4.10.1.8 | 8.Interr. Tom e luminárias | 1d | 2021-08-02 | 2021-08-02 | 17d | eletricista; aux. eletricista | 17.6h | 6,963.62 | 10. Casa 10 | 0. Térreo | 26 | 20. Elétrica1 | Própria | 26 |  |
| 1025 | 1.4.10.1.9 | 9.Quadro elétrico | 2d | 2021-08-02 | 2021-08-03 | 16d | eletricista; aux. eletricista | 35.2h | 1,788.87 | 10. Casa 10 | 0. Térreo | 27 | 20. Elétrica1 | Própria | 27 |  |
| 1026 | 1.4.10.1.10 | 10.Louças e Metais | 2d | 2021-08-02 | 2021-08-03 | 16d | aux. bombeiro; bombeiro | 35.2h | 6,591.75 | 10. Casa 10 | 0. Térreo | 28 | 21. HS1 | Própria | 28 | 10 |
| 1027 | 1.4.10.2 | **1. Pav. Superior** | 4d | 2021-08-02 | 2021-08-05 | 14d |  | 334.4h | 21,866.33 |  |  |  |  |  |  |  |
| 1028 | 1.4.10.2.1 | 2.Inst. Elétricas Laje | 2d | 2021-08-02 | 2021-08-03 | 16d | eletricista; aux. eletricista | 35.2h | 2,995.3 | 10. Casa 10 | 1. Pav. Superior | 20 | 20. Elétrica1 | Própria | 20 |  |
| 1029 | 1.4.10.2.2 | 3.Inst. Elétricas Paredes | 2d | 2021-08-02 | 2021-08-03 | 16d | eletricista; aux. eletricista | 35.2h | 766.33 | 10. Casa 10 | 1. Pav. Superior | 21 | 20. Elétrica1 | Própria | 21 |  |
| 1030 | 1.4.10.2.3 | 4.Inst. Gás | 2d | 2021-08-02 | 2021-08-03 | 16d | aux. bombeiro; bombeiro | 35.2h | 1,371.29 | 10. Casa 10 | 1. Pav. Superior | 22 | 21. HS1 | Própria | 22 |  |
| 1031 | 1.4.10.2.4 | 5.Inst. AF e AQ | 2d | 2021-08-02 | 2021-08-03 | 16d | aux. bombeiro; bombeiro | 35.2h | 2,426.07 | 10. Casa 10 | 1. Pav. Superior | 23 | 21. HS1 | Própria | 23 |  |
| 1032 | 1.4.10.2.5 | 6.Inst. Esgoto | 2d | 2021-08-02 | 2021-08-03 | 16d | aux. bombeiro; bombeiro | 35.2h | 1,546.11 | 10. Casa 10 | 1. Pav. Superior | 24 | 21. HS1 | Própria | 24 |  |
| 1033 | 1.4.10.2.6 | 7.Fiação | 4d | 2021-08-02 | 2021-08-05 | 14d | eletricista; aux. eletricista | 70.4h | 5,338.91 | 10. Casa 10 | 1. Pav. Superior | 25 | 20. Elétrica1 | Própria | 25 |  |
| 1034 | 1.4.10.2.7 | 8.Interr. Tom e luminárias | 1d | 2021-08-02 | 2021-08-02 | 17d | eletricista; aux. eletricista | 17.6h | 3,131.08 | 10. Casa 10 | 1. Pav. Superior | 26 | 20. Elétrica1 | Própria | 26 |  |
| 1035 | 1.4.10.2.8 | 9.Quadro elétrico | 2d | 2021-08-02 | 2021-08-03 | 16d | eletricista; aux. eletricista | 35.2h | 804.33 | 10. Casa 10 | 1. Pav. Superior | 27 | 20. Elétrica1 | Própria | 27 |  |
| 1036 | 1.4.10.2.9 | 10.Louças e Metais | 2d | 2021-08-02 | 2021-08-03 | 16d | aux. bombeiro; bombeiro | 35.2h | 3,486.91 | 10. Casa 10 | 1. Pav. Superior | 28 | 21. HS1 | Própria | 28 | 10 |
| 1037 | 1.4.10.3 | **2. Coberta** | 2d | 2021-08-02 | 2021-08-03 | 16d |  | 70.4h | 2,943.46 |  |  |  |  |  |  |  |
| 1038 | 1.4.10.3.1 | Barrilette | 2d | 2021-08-02 | 2021-08-03 | 16d | aux. bombeiro; bombeiro | 35.2h | 1,177.38 | 10. Casa 10 | 2. Coberta | 29 | 21. HS1 | Própria | 29 | 11 |
| 1039 | 1.4.10.3.2 | Caixa D'água | 2d | 2021-08-02 | 2021-08-03 | 16d | aux. bombeiro; bombeiro | 35.2h | 1,766.08 | 10. Casa 10 | 2. Coberta | 30 | 21. HS1 | Própria | 30 | 11 |

| ID | WBS | Task | Duration | Start | Finish | Total slack | Resources | Work | Cost | Casa | Pav | Pacote | Equipe | Empresa | LB | Cor |
| --- | --- | --- | --- | --- | --- | --- | --- | --- | --- | --- | --- | --- | --- | --- | --- | --- |
| 1040 | 1.4.11 | **11. Casa 11** | 4d | 2021-08-02 | 2021-08-05 | 14d |  | 774.4h | 72,049.62 |  |  |  |  |  |  |  |
| 1041 | 1.4.11.1 | **0. Térreo** | 4d | 2021-08-02 | 2021-08-05 | 14d |  | 369.6h | 47,239.83 |  |  |  |  |  |  |  |
| 1042 | 1.4.11.1.1 | 1.Inst. Embut. Em Fundações | 2d | 2021-08-02 | 2021-08-03 | 16d | bombeiro; eletricista | 35.2h | 1,554.25 | 11. Casa 11 | 0. Térreo | 19 | 19. Instalações1 | Própria | 19 |  |
| 1043 | 1.4.11.1.2 | 2.Inst. Elétricas Laje | 2d | 2021-08-02 | 2021-08-03 | 16d | eletricista; aux. eletricista | 35.2h | 6,661.65 | 11. Casa 11 | 0. Térreo | 20 | 20. Elétrica1 | Própria | 20 |  |
| 1044 | 1.4.11.1.3 | 3.Inst. Elétricas Paredes | 2d | 2021-08-02 | 2021-08-03 | 16d | eletricista; aux. eletricista | 35.2h | 1,704.34 | 11. Casa 11 | 0. Térreo | 21 | 21. HS1 | Própria | 21 |  |
| 1045 | 1.4.11.1.4 | 4.Inst. Gás | 2d | 2021-08-02 | 2021-08-03 | 16d | aux. bombeiro; bombeiro | 35.2h | 2,592.32 | 11. Casa 11 | 0. Térreo | 22 | 21. HS1 | Própria | 22 |  |
| 1046 | 1.4.11.1.5 | 5.Inst. AF e AQ | 2d | 2021-08-02 | 2021-08-03 | 16d | aux. bombeiro; bombeiro | 35.2h | 4,586.31 | 11. Casa 11 | 0. Térreo | 23 | 21. HS1 | Própria | 23 |  |
| 1047 | 1.4.11.1.6 | 6.Inst. Esgoto | 2d | 2021-08-02 | 2021-08-03 | 16d | aux. bombeiro; bombeiro | 35.2h | 2,922.8 | 11. Casa 11 | 0. Térreo | 24 | 21. HS1 | Própria | 24 |  |
| 1048 | 1.4.11.1.7 | 7.Fiação | 4d | 2021-08-02 | 2021-08-05 | 14d | eletricista; aux. eletricista | 70.4h | 11,873.92 | 11. Casa 11 | 0. Térreo | 25 | 20. Elétrica1 | Própria | 25 |  |
| 1049 | 1.4.11.1.8 | 8.Interr. Tom e luminárias | 1d | 2021-08-02 | 2021-08-02 | 17d | eletricista; aux. eletricista | 17.6h | 6,963.62 | 11. Casa 11 | 0. Térreo | 26 | 20. Elétrica1 | Própria | 26 |  |
| 1050 | 1.4.11.1.9 | 9.Quadro elétrico | 2d | 2021-08-02 | 2021-08-03 | 16d | eletricista; aux. eletricista | 35.2h | 1,788.87 | 11. Casa 11 | 0. Térreo | 27 | 20. Elétrica1 | Própria | 27 |  |
| 1051 | 1.4.11.1.10 | 10.Louças e Metais | 2d | 2021-08-02 | 2021-08-03 | 16d | aux. bombeiro; bombeiro | 35.2h | 6,591.75 | 11. Casa 11 | 0. Térreo | 28 | 21. HS1 | Própria | 28 | 10 |
| 1052 | 1.4.11.2 | **1. Pav. Superior** | 4d | 2021-08-02 | 2021-08-05 | 14d |  | 334.4h | 21,866.33 |  |  |  |  |  |  |  |
| 1053 | 1.4.11.2.1 | 2.Inst. Elétricas Laje | 2d | 2021-08-02 | 2021-08-03 | 16d | eletricista; aux. eletricista | 35.2h | 2,995.3 | 11. Casa 11 | 1. Pav. Superior | 20 | 20. Elétrica1 | Própria | 20 |  |
| 1054 | 1.4.11.2.2 | 3.Inst. Elétricas Paredes | 2d | 2021-08-02 | 2021-08-03 | 16d | eletricista; aux. eletricista | 35.2h | 766.33 | 11. Casa 11 | 1. Pav. Superior | 21 | 20. Elétrica1 | Própria | 21 |  |
| 1055 | 1.4.11.2.3 | 4.Inst. Gás | 2d | 2021-08-02 | 2021-08-03 | 16d | aux. bombeiro; bombeiro | 35.2h | 1,371.29 | 11. Casa 11 | 1. Pav. Superior | 22 | 21. HS1 | Própria | 22 |  |
| 1056 | 1.4.11.2.4 | 5.Inst. AF e AQ | 2d | 2021-08-02 | 2021-08-03 | 16d | aux. bombeiro; bombeiro | 35.2h | 2,426.07 | 11. Casa 11 | 1. Pav. Superior | 23 | 21. HS1 | Própria | 23 |  |
| 1057 | 1.4.11.2.5 | 6.Inst. Esgoto | 2d | 2021-08-02 | 2021-08-03 | 16d | aux. bombeiro; bombeiro | 35.2h | 1,546.11 | 11. Casa 11 | 1. Pav. Superior | 24 | 21. HS1 | Própria | 24 |  |
| 1058 | 1.4.11.2.6 | 7.Fiação | 4d | 2021-08-02 | 2021-08-05 | 14d | eletricista; aux. eletricista | 70.4h | 5,338.91 | 11. Casa 11 | 1. Pav. Superior | 25 | 20. Elétrica1 | Própria | 25 |  |
| 1059 | 1.4.11.2.7 | 8.Interr. Tom e luminárias | 1d | 2021-08-02 | 2021-08-02 | 17d | eletricista; aux. eletricista | 17.6h | 3,131.08 | 11. Casa 11 | 1. Pav. Superior | 26 | 20. Elétrica1 | Própria | 26 |  |
| 1060 | 1.4.11.2.8 | 9.Quadro elétrico | 2d | 2021-08-02 | 2021-08-03 | 16d | eletricista; aux. eletricista | 35.2h | 804.33 | 11. Casa 11 | 1. Pav. Superior | 27 | 20. Elétrica1 | Própria | 27 |  |
| 1061 | 1.4.11.2.9 | 10.Louças e Metais | 2d | 2021-08-02 | 2021-08-03 | 16d | aux. bombeiro; bombeiro | 35.2h | 3,486.91 | 11. Casa 11 | 1. Pav. Superior | 28 | 21. HS1 | Própria | 28 | 10 |
| 1062 | 1.4.11.3 | **2. Coberta** | 2d | 2021-08-02 | 2021-08-03 | 16d |  | 70.4h | 2,943.46 |  |  |  |  |  |  |  |
| 1063 | 1.4.11.3.1 | Barrilette | 2d | 2021-08-02 | 2021-08-03 | 16d | aux. bombeiro; bombeiro | 35.2h | 1,177.38 | 11. Casa 11 | 2. Coberta | 29 | 21. HS1 | Própria | 29 | 11 |
| 1064 | 1.4.11.3.2 | Caixa D'água | 2d | 2021-08-02 | 2021-08-03 | 16d | aux. bombeiro; bombeiro | 35.2h | 1,766.08 | 11. Casa 11 | 2. Coberta | 30 | 21. HS1 | Própria | 30 | 11 |

| ID | WBS | Task | Duration | Start | Finish | Total slack | Resources | Work | Cost | Casa | Pav | Pacote | Equipe | Empresa | LB | Cor |
| --- | --- | --- | --- | --- | --- | --- | --- | --- | --- | --- | --- | --- | --- | --- | --- | --- |
| 1065 | 1.4.12 | **12. Casa 12** | 4d | 2021-08-02 | 2021-08-05 | 14d |  | 774.4h | 72,049.62 |  |  |  |  |  |  |  |
| 1066 | 1.4.12.1 | **0. Térreo** | 4d | 2021-08-02 | 2021-08-05 | 14d |  | 369.6h | 47,239.83 |  |  |  |  |  |  |  |
| 1067 | 1.4.12.1.1 | 1.Inst. Embut. Em Fundações | 2d | 2021-08-02 | 2021-08-03 | 16d | bombeiro; eletricista | 35.2h | 1,554.25 | 12. Casa 12 | 0. Térreo | 19 | 19. Instalações1 | Própria | 19 |  |
| 1068 | 1.4.12.1.2 | 2.Inst. Elétricas Laje | 2d | 2021-08-02 | 2021-08-03 | 16d | eletricista; aux. eletricista | 35.2h | 6,661.65 | 12. Casa 12 | 0. Térreo | 20 | 20. Elétrica1 | Própria | 20 |  |
| 1069 | 1.4.12.1.3 | 3.Inst. Elétricas Paredes | 2d | 2021-08-02 | 2021-08-03 | 16d | eletricista; aux. eletricista | 35.2h | 1,704.34 | 12. Casa 12 | 0. Térreo | 21 | 21. HS1 | Própria | 21 |  |
| 1070 | 1.4.12.1.4 | 4.Inst. Gás | 2d | 2021-08-02 | 2021-08-03 | 16d | aux. bombeiro; bombeiro | 35.2h | 2,592.32 | 12. Casa 12 | 0. Térreo | 22 | 21. HS1 | Própria | 22 |  |
| 1071 | 1.4.12.1.5 | 5.Inst. AF e AQ | 2d | 2021-08-02 | 2021-08-03 | 16d | aux. bombeiro; bombeiro | 35.2h | 4,586.31 | 12. Casa 12 | 0. Térreo | 23 | 21. HS1 | Própria | 23 |  |
| 1072 | 1.4.12.1.6 | 6.Inst. Esgoto | 2d | 2021-08-02 | 2021-08-03 | 16d | aux. bombeiro; bombeiro | 35.2h | 2,922.8 | 12. Casa 12 | 0. Térreo | 24 | 21. HS1 | Própria | 24 |  |
| 1073 | 1.4.12.1.7 | 7.Fiação | 4d | 2021-08-02 | 2021-08-05 | 14d | eletricista; aux. eletricista | 70.4h | 11,873.92 | 12. Casa 12 | 0. Térreo | 25 | 20. Elétrica1 | Própria | 25 |  |
| 1074 | 1.4.12.1.8 | 8.Interr. Tom e luminárias | 1d | 2021-08-02 | 2021-08-02 | 17d | eletricista; aux. eletricista | 17.6h | 6,963.62 | 12. Casa 12 | 0. Térreo | 26 | 20. Elétrica1 | Própria | 26 |  |
| 1075 | 1.4.12.1.9 | 9.Quadro elétrico | 2d | 2021-08-02 | 2021-08-03 | 16d | eletricista; aux. eletricista | 35.2h | 1,788.87 | 12. Casa 12 | 0. Térreo | 27 | 20. Elétrica1 | Própria | 27 |  |
| 1076 | 1.4.12.1.10 | 10.Louças e Metais | 2d | 2021-08-02 | 2021-08-03 | 16d | aux. bombeiro; bombeiro | 35.2h | 6,591.75 | 12. Casa 12 | 0. Térreo | 28 | 21. HS1 | Própria | 28 | 10 |
| 1077 | 1.4.12.2 | **1. Pav. Superior** | 4d | 2021-08-02 | 2021-08-05 | 14d |  | 334.4h | 21,866.33 |  |  |  |  |  |  |  |
| 1078 | 1.4.12.2.1 | 2.Inst. Elétricas Laje | 2d | 2021-08-02 | 2021-08-03 | 16d | eletricista; aux. eletricista | 35.2h | 2,995.3 | 12. Casa 12 | 1. Pav. Superior | 20 | 20. Elétrica1 | Própria | 20 |  |
| 1079 | 1.4.12.2.2 | 3.Inst. Elétricas Paredes | 2d | 2021-08-02 | 2021-08-03 | 16d | eletricista; aux. eletricista | 35.2h | 766.33 | 12. Casa 12 | 1. Pav. Superior | 21 | 20. Elétrica1 | Própria | 21 |  |
| 1080 | 1.4.12.2.3 | 4.Inst. Gás | 2d | 2021-08-02 | 2021-08-03 | 16d | aux. bombeiro; bombeiro | 35.2h | 1,371.29 | 12. Casa 12 | 1. Pav. Superior | 22 | 21. HS1 | Própria | 22 |  |
| 1081 | 1.4.12.2.4 | 5.Inst. AF e AQ | 2d | 2021-08-02 | 2021-08-03 | 16d | aux. bombeiro; bombeiro | 35.2h | 2,426.07 | 12. Casa 12 | 1. Pav. Superior | 23 | 21. HS1 | Própria | 23 |  |
| 1082 | 1.4.12.2.5 | 6.Inst. Esgoto | 2d | 2021-08-02 | 2021-08-03 | 16d | aux. bombeiro; bombeiro | 35.2h | 1,546.11 | 12. Casa 12 | 1. Pav. Superior | 24 | 21. HS1 | Própria | 24 |  |
| 1083 | 1.4.12.2.6 | 7.Fiação | 4d | 2021-08-02 | 2021-08-05 | 14d | eletricista; aux. eletricista | 70.4h | 5,338.91 | 12. Casa 12 | 1. Pav. Superior | 25 | 20. Elétrica1 | Própria | 25 |  |
| 1084 | 1.4.12.2.7 | 8.Interr. Tom e luminárias | 1d | 2021-08-02 | 2021-08-02 | 17d | eletricista; aux. eletricista | 17.6h | 3,131.08 | 12. Casa 12 | 1. Pav. Superior | 26 | 20. Elétrica1 | Própria | 26 |  |
| 1085 | 1.4.12.2.8 | 9.Quadro elétrico | 2d | 2021-08-02 | 2021-08-03 | 16d | eletricista; aux. eletricista | 35.2h | 804.33 | 12. Casa 12 | 1. Pav. Superior | 27 | 20. Elétrica1 | Própria | 27 |  |
| 1086 | 1.4.12.2.9 | 10.Louças e Metais | 2d | 2021-08-02 | 2021-08-03 | 16d | aux. bombeiro; bombeiro | 35.2h | 3,486.91 | 12. Casa 12 | 1. Pav. Superior | 28 | 21. HS1 | Própria | 28 | 10 |
| 1087 | 1.4.12.3 | **2. Coberta** | 2d | 2021-08-02 | 2021-08-03 | 16d |  | 70.4h | 2,943.46 |  |  |  |  |  |  |  |
| 1088 | 1.4.12.3.1 | Barrilette | 2d | 2021-08-02 | 2021-08-03 | 16d | aux. bombeiro; bombeiro | 35.2h | 1,177.38 | 12. Casa 12 | 2. Coberta | 29 | 21. HS1 | Própria | 29 | 11 |
| 1089 | 1.4.12.3.2 | Caixa D'água | 2d | 2021-08-02 | 2021-08-03 | 16d | aux. bombeiro; bombeiro | 35.2h | 1,766.08 | 12. Casa 12 | 2. Coberta | 30 | 21. HS1 | Própria | 30 | 11 |

| ID | WBS | Task | Duration | Start | Finish | Total slack | Resources | Work | Cost | Casa | Pav | Pacote | Equipe | Empresa | LB | Cor |
| --- | --- | --- | --- | --- | --- | --- | --- | --- | --- | --- | --- | --- | --- | --- | --- | --- |
| 1090 | 1.4.13 | **13. Casa 13** | 4d | 2021-08-02 | 2021-08-05 | 14d |  | 774.4h | 72,049.62 |  |  |  |  |  |  |  |
| 1091 | 1.4.13.1 | **0. Térreo** | 4d | 2021-08-02 | 2021-08-05 | 14d |  | 369.6h | 47,239.83 |  |  |  |  |  |  |  |
| 1092 | 1.4.13.1.1 | 1.Inst. Embut. Em Fundações | 2d | 2021-08-02 | 2021-08-03 | 16d | bombeiro; eletricista | 35.2h | 1,554.25 | 13. Casa 13 | 0. Térreo | 19 | 19. Instalações1 | Própria | 19 |  |
| 1093 | 1.4.13.1.2 | 2.Inst. Elétricas Laje | 2d | 2021-08-02 | 2021-08-03 | 16d | eletricista; aux. eletricista | 35.2h | 6,661.65 | 13. Casa 13 | 0. Térreo | 20 | 20. Elétrica1 | Própria | 20 |  |
| 1094 | 1.4.13.1.3 | 3.Inst. Elétricas Paredes | 2d | 2021-08-02 | 2021-08-03 | 16d | eletricista; aux. eletricista | 35.2h | 1,704.34 | 13. Casa 13 | 0. Térreo | 21 | 21. HS1 | Própria | 21 |  |
| 1095 | 1.4.13.1.4 | 4.Inst. Gás | 2d | 2021-08-02 | 2021-08-03 | 16d | aux. bombeiro; bombeiro | 35.2h | 2,592.32 | 13. Casa 13 | 0. Térreo | 22 | 21. HS1 | Própria | 22 |  |
| 1096 | 1.4.13.1.5 | 5.Inst. AF e AQ | 2d | 2021-08-02 | 2021-08-03 | 16d | aux. bombeiro; bombeiro | 35.2h | 4,586.31 | 13. Casa 13 | 0. Térreo | 23 | 21. HS1 | Própria | 23 |  |
| 1097 | 1.4.13.1.6 | 6.Inst. Esgoto | 2d | 2021-08-02 | 2021-08-03 | 16d | aux. bombeiro; bombeiro | 35.2h | 2,922.8 | 13. Casa 13 | 0. Térreo | 24 | 21. HS1 | Própria | 24 |  |
| 1098 | 1.4.13.1.7 | 7.Fiação | 4d | 2021-08-02 | 2021-08-05 | 14d | eletricista; aux. eletricista | 70.4h | 11,873.92 | 13. Casa 13 | 0. Térreo | 25 | 20. Elétrica1 | Própria | 25 |  |
| 1099 | 1.4.13.1.8 | 8.Interr. Tom e luminárias | 1d | 2021-08-02 | 2021-08-02 | 17d | eletricista; aux. eletricista | 17.6h | 6,963.62 | 13. Casa 13 | 0. Térreo | 26 | 20. Elétrica1 | Própria | 26 |  |
| 1100 | 1.4.13.1.9 | 9.Quadro elétrico | 2d | 2021-08-02 | 2021-08-03 | 16d | eletricista; aux. eletricista | 35.2h | 1,788.87 | 13. Casa 13 | 0. Térreo | 27 | 20. Elétrica1 | Própria | 27 |  |
| 1101 | 1.4.13.1.10 | 10.Louças e Metais | 2d | 2021-08-02 | 2021-08-03 | 16d | aux. bombeiro; bombeiro | 35.2h | 6,591.75 | 13. Casa 13 | 0. Térreo | 28 | 21. HS1 | Própria | 28 | 10 |
| 1102 | 1.4.13.2 | **1. Pav. Superior** | 4d | 2021-08-02 | 2021-08-05 | 14d |  | 334.4h | 21,866.33 |  |  |  |  |  |  |  |
| 1103 | 1.4.13.2.1 | 2.Inst. Elétricas Laje | 2d | 2021-08-02 | 2021-08-03 | 16d | eletricista; aux. eletricista | 35.2h | 2,995.3 | 13. Casa 13 | 1. Pav. Superior | 20 | 20. Elétrica1 | Própria | 20 |  |
| 1104 | 1.4.13.2.2 | 3.Inst. Elétricas Paredes | 2d | 2021-08-02 | 2021-08-03 | 16d | eletricista; aux. eletricista | 35.2h | 766.33 | 13. Casa 13 | 1. Pav. Superior | 21 | 20. Elétrica1 | Própria | 21 |  |
| 1105 | 1.4.13.2.3 | 4.Inst. Gás | 2d | 2021-08-02 | 2021-08-03 | 16d | aux. bombeiro; bombeiro | 35.2h | 1,371.29 | 13. Casa 13 | 1. Pav. Superior | 22 | 21. HS1 | Própria | 22 |  |
| 1106 | 1.4.13.2.4 | 5.Inst. AF e AQ | 2d | 2021-08-02 | 2021-08-03 | 16d | aux. bombeiro; bombeiro | 35.2h | 2,426.07 | 13. Casa 13 | 1. Pav. Superior | 23 | 21. HS1 | Própria | 23 |  |
| 1107 | 1.4.13.2.5 | 6.Inst. Esgoto | 2d | 2021-08-02 | 2021-08-03 | 16d | aux. bombeiro; bombeiro | 35.2h | 1,546.11 | 13. Casa 13 | 1. Pav. Superior | 24 | 21. HS1 | Própria | 24 |  |
| 1108 | 1.4.13.2.6 | 7.Fiação | 4d | 2021-08-02 | 2021-08-05 | 14d | eletricista; aux. eletricista | 70.4h | 5,338.91 | 13. Casa 13 | 1. Pav. Superior | 25 | 20. Elétrica1 | Própria | 25 |  |
| 1109 | 1.4.13.2.7 | 8.Interr. Tom e luminárias | 1d | 2021-08-02 | 2021-08-02 | 17d | eletricista; aux. eletricista | 17.6h | 3,131.08 | 13. Casa 13 | 1. Pav. Superior | 26 | 20. Elétrica1 | Própria | 26 |  |
| 1110 | 1.4.13.2.8 | 9.Quadro elétrico | 2d | 2021-08-02 | 2021-08-03 | 16d | eletricista; aux. eletricista | 35.2h | 804.33 | 13. Casa 13 | 1. Pav. Superior | 27 | 20. Elétrica1 | Própria | 27 |  |
| 1111 | 1.4.13.2.9 | 10.Louças e Metais | 2d | 2021-08-02 | 2021-08-03 | 16d | aux. bombeiro; bombeiro | 35.2h | 3,486.91 | 13. Casa 13 | 1. Pav. Superior | 28 | 21. HS1 | Própria | 28 | 10 |
| 1112 | 1.4.13.3 | **2. Coberta** | 2d | 2021-08-02 | 2021-08-03 | 16d |  | 70.4h | 2,943.46 |  |  |  |  |  |  |  |
| 1113 | 1.4.13.3.1 | Barrilette | 2d | 2021-08-02 | 2021-08-03 | 16d | aux. bombeiro; bombeiro | 35.2h | 1,177.38 | 13. Casa 13 | 2. Coberta | 29 | 21. HS1 | Própria | 29 | 11 |
| 1114 | 1.4.13.3.2 | Caixa D'água | 2d | 2021-08-02 | 2021-08-03 | 16d | aux. bombeiro; bombeiro | 35.2h | 1,766.08 | 13. Casa 13 | 2. Coberta | 30 | 21. HS1 | Própria | 30 | 11 |

| ID | WBS | Task | Duration | Start | Finish | Total slack | Resources | Work | Cost | Casa | Pav | Pacote | Equipe | Empresa | LB | Cor |
| --- | --- | --- | --- | --- | --- | --- | --- | --- | --- | --- | --- | --- | --- | --- | --- | --- |
| 1115 | 1.4.14 | **14. Casa 14** | 4d | 2021-08-02 | 2021-08-05 | 14d |  | 774.4h | 72,049.62 |  |  |  |  |  |  |  |
| 1116 | 1.4.14.1 | **0. Térreo** | 4d | 2021-08-02 | 2021-08-05 | 14d |  | 369.6h | 47,239.83 |  |  |  |  |  |  |  |
| 1117 | 1.4.14.1.1 | 1.Inst. Embut. Em Fundações | 2d | 2021-08-02 | 2021-08-03 | 16d | bombeiro; eletricista | 35.2h | 1,554.25 | 14. Casa 14 | 0. Térreo | 19 | 19. Instalações1 | Própria | 19 |  |
| 1118 | 1.4.14.1.2 | 2.Inst. Elétricas Laje | 2d | 2021-08-02 | 2021-08-03 | 16d | eletricista; aux. eletricista | 35.2h | 6,661.65 | 14. Casa 14 | 0. Térreo | 20 | 20. Elétrica1 | Própria | 20 |  |
| 1119 | 1.4.14.1.3 | 3.Inst. Elétricas Paredes | 2d | 2021-08-02 | 2021-08-03 | 16d | eletricista; aux. eletricista | 35.2h | 1,704.34 | 14. Casa 14 | 0. Térreo | 21 | 21. HS1 | Própria | 21 |  |
| 1120 | 1.4.14.1.4 | 4.Inst. Gás | 2d | 2021-08-02 | 2021-08-03 | 16d | aux. bombeiro; bombeiro | 35.2h | 2,592.32 | 14. Casa 14 | 0. Térreo | 22 | 21. HS1 | Própria | 22 |  |
| 1121 | 1.4.14.1.5 | 5.Inst. AF e AQ | 2d | 2021-08-02 | 2021-08-03 | 16d | aux. bombeiro; bombeiro | 35.2h | 4,586.31 | 14. Casa 14 | 0. Térreo | 23 | 21. HS1 | Própria | 23 |  |
| 1122 | 1.4.14.1.6 | 6.Inst. Esgoto | 2d | 2021-08-02 | 2021-08-03 | 16d | aux. bombeiro; bombeiro | 35.2h | 2,922.8 | 14. Casa 14 | 0. Térreo | 24 | 21. HS1 | Própria | 24 |  |
| 1123 | 1.4.14.1.7 | 7.Fiação | 4d | 2021-08-02 | 2021-08-05 | 14d | eletricista; aux. eletricista | 70.4h | 11,873.92 | 14. Casa 14 | 0. Térreo | 25 | 20. Elétrica1 | Própria | 25 |  |
| 1124 | 1.4.14.1.8 | 8.Interr. Tom e luminárias | 1d | 2021-08-02 | 2021-08-02 | 17d | eletricista; aux. eletricista | 17.6h | 6,963.62 | 14. Casa 14 | 0. Térreo | 26 | 20. Elétrica1 | Própria | 26 |  |
| 1125 | 1.4.14.1.9 | 9.Quadro elétrico | 2d | 2021-08-02 | 2021-08-03 | 16d | eletricista; aux. eletricista | 35.2h | 1,788.87 | 14. Casa 14 | 0. Térreo | 27 | 20. Elétrica1 | Própria | 27 |  |
| 1126 | 1.4.14.1.10 | 10.Louças e Metais | 2d | 2021-08-02 | 2021-08-03 | 16d | aux. bombeiro; bombeiro | 35.2h | 6,591.75 | 14. Casa 14 | 0. Térreo | 28 | 21. HS1 | Própria | 28 | 10 |
| 1127 | 1.4.14.2 | **1. Pav. Superior** | 4d | 2021-08-02 | 2021-08-05 | 14d |  | 334.4h | 21,866.33 |  |  |  |  |  |  |  |
| 1128 | 1.4.14.2.1 | 2.Inst. Elétricas Laje | 2d | 2021-08-02 | 2021-08-03 | 16d | eletricista; aux. eletricista | 35.2h | 2,995.3 | 14. Casa 14 | 1. Pav. Superior | 20 | 20. Elétrica1 | Própria | 20 |  |
| 1129 | 1.4.14.2.2 | 3.Inst. Elétricas Paredes | 2d | 2021-08-02 | 2021-08-03 | 16d | eletricista; aux. eletricista | 35.2h | 766.33 | 14. Casa 14 | 1. Pav. Superior | 21 | 20. Elétrica1 | Própria | 21 |  |
| 1130 | 1.4.14.2.3 | 4.Inst. Gás | 2d | 2021-08-02 | 2021-08-03 | 16d | aux. bombeiro; bombeiro | 35.2h | 1,371.29 | 14. Casa 14 | 1. Pav. Superior | 22 | 21. HS1 | Própria | 22 |  |
| 1131 | 1.4.14.2.4 | 5.Inst. AF e AQ | 2d | 2021-08-02 | 2021-08-03 | 16d | aux. bombeiro; bombeiro | 35.2h | 2,426.07 | 14. Casa 14 | 1. Pav. Superior | 23 | 21. HS1 | Própria | 23 |  |
| 1132 | 1.4.14.2.5 | 6.Inst. Esgoto | 2d | 2021-08-02 | 2021-08-03 | 16d | aux. bombeiro; bombeiro | 35.2h | 1,546.11 | 14. Casa 14 | 1. Pav. Superior | 24 | 21. HS1 | Própria | 24 |  |
| 1133 | 1.4.14.2.6 | 7.Fiação | 4d | 2021-08-02 | 2021-08-05 | 14d | eletricista; aux. eletricista | 70.4h | 5,338.91 | 14. Casa 14 | 1. Pav. Superior | 25 | 20. Elétrica1 | Própria | 25 |  |
| 1134 | 1.4.14.2.7 | 8.Interr. Tom e luminárias | 1d | 2021-08-02 | 2021-08-02 | 17d | eletricista; aux. eletricista | 17.6h | 3,131.08 | 14. Casa 14 | 1. Pav. Superior | 26 | 20. Elétrica1 | Própria | 26 |  |
| 1135 | 1.4.14.2.8 | 9.Quadro elétrico | 2d | 2021-08-02 | 2021-08-03 | 16d | eletricista; aux. eletricista | 35.2h | 804.33 | 14. Casa 14 | 1. Pav. Superior | 27 | 20. Elétrica1 | Própria | 27 |  |
| 1136 | 1.4.14.2.9 | 10.Louças e Metais | 2d | 2021-08-02 | 2021-08-03 | 16d | aux. bombeiro; bombeiro | 35.2h | 3,486.91 | 14. Casa 14 | 1. Pav. Superior | 28 | 21. HS1 | Própria | 28 | 10 |
| 1137 | 1.4.14.3 | **2. Coberta** | 2d | 2021-08-02 | 2021-08-03 | 16d |  | 70.4h | 2,943.46 |  |  |  |  |  |  |  |
| 1138 | 1.4.14.3.1 | Barrilette | 2d | 2021-08-02 | 2021-08-03 | 16d | aux. bombeiro; bombeiro | 35.2h | 1,177.38 | 14. Casa 14 | 2. Coberta | 29 | 21. HS1 | Própria | 29 | 11 |
| 1139 | 1.4.14.3.2 | Caixa D'água | 2d | 2021-08-02 | 2021-08-03 | 16d | aux. bombeiro; bombeiro | 35.2h | 1,766.08 | 14. Casa 14 | 2. Coberta | 30 | 21. HS1 | Própria | 30 | 11 |

| ID | WBS | Task | Duration | Start | Finish | Total slack | Resources | Work | Cost | Casa | Pav | Pacote | Equipe | Empresa | LB | Cor |
| --- | --- | --- | --- | --- | --- | --- | --- | --- | --- | --- | --- | --- | --- | --- | --- | --- |
| 1140 | 1.4.15 | **15. Casa 15** | 4d | 2021-08-02 | 2021-08-05 | 14d |  | 774.4h | 72,049.62 |  |  |  |  |  |  |  |
| 1141 | 1.4.15.1 | **0. Térreo** | 4d | 2021-08-02 | 2021-08-05 | 14d |  | 369.6h | 47,239.83 |  |  |  |  |  |  |  |
| 1142 | 1.4.15.1.1 | 1.Inst. Embut. Em Fundações | 2d | 2021-08-02 | 2021-08-03 | 16d | bombeiro; eletricista | 35.2h | 1,554.25 | 15. Casa 15 | 0. Térreo | 19 | 19. Instalações1 | Própria | 19 |  |
| 1143 | 1.4.15.1.2 | 2.Inst. Elétricas Laje | 2d | 2021-08-02 | 2021-08-03 | 16d | eletricista; aux. eletricista | 35.2h | 6,661.65 | 15. Casa 15 | 0. Térreo | 20 | 20. Elétrica1 | Própria | 20 |  |
| 1144 | 1.4.15.1.3 | 3.Inst. Elétricas Paredes | 2d | 2021-08-02 | 2021-08-03 | 16d | eletricista; aux. eletricista | 35.2h | 1,704.34 | 15. Casa 15 | 0. Térreo | 21 | 21. HS1 | Própria | 21 |  |
| 1145 | 1.4.15.1.4 | 4.Inst. Gás | 2d | 2021-08-02 | 2021-08-03 | 16d | aux. bombeiro; bombeiro | 35.2h | 2,592.32 | 15. Casa 15 | 0. Térreo | 22 | 21. HS1 | Própria | 22 |  |
| 1146 | 1.4.15.1.5 | 5.Inst. AF e AQ | 2d | 2021-08-02 | 2021-08-03 | 16d | aux. bombeiro; bombeiro | 35.2h | 4,586.31 | 15. Casa 15 | 0. Térreo | 23 | 21. HS1 | Própria | 23 |  |
| 1147 | 1.4.15.1.6 | 6.Inst. Esgoto | 2d | 2021-08-02 | 2021-08-03 | 16d | aux. bombeiro; bombeiro | 35.2h | 2,922.8 | 15. Casa 15 | 0. Térreo | 24 | 21. HS1 | Própria | 24 |  |
| 1148 | 1.4.15.1.7 | 7.Fiação | 4d | 2021-08-02 | 2021-08-05 | 14d | eletricista; aux. eletricista | 70.4h | 11,873.92 | 15. Casa 15 | 0. Térreo | 25 | 20. Elétrica1 | Própria | 25 |  |
| 1149 | 1.4.15.1.8 | 8.Interr. Tom e luminárias | 1d | 2021-08-02 | 2021-08-02 | 17d | eletricista; aux. eletricista | 17.6h | 6,963.62 | 15. Casa 15 | 0. Térreo | 26 | 20. Elétrica1 | Própria | 26 |  |
| 1150 | 1.4.15.1.9 | 9.Quadro elétrico | 2d | 2021-08-02 | 2021-08-03 | 16d | eletricista; aux. eletricista | 35.2h | 1,788.87 | 15. Casa 15 | 0. Térreo | 27 | 20. Elétrica1 | Própria | 27 |  |
| 1151 | 1.4.15.1.10 | 10.Louças e Metais | 2d | 2021-08-02 | 2021-08-03 | 16d | aux. bombeiro; bombeiro | 35.2h | 6,591.75 | 15. Casa 15 | 0. Térreo | 28 | 21. HS1 | Própria | 28 | 10 |
| 1152 | 1.4.15.2 | **1. Pav. Superior** | 4d | 2021-08-02 | 2021-08-05 | 14d |  | 334.4h | 21,866.33 |  |  |  |  |  |  |  |
| 1153 | 1.4.15.2.1 | 2.Inst. Elétricas Laje | 2d | 2021-08-02 | 2021-08-03 | 16d | eletricista; aux. eletricista | 35.2h | 2,995.3 | 15. Casa 15 | 1. Pav. Superior | 20 | 20. Elétrica1 | Própria | 20 |  |
| 1154 | 1.4.15.2.2 | 3.Inst. Elétricas Paredes | 2d | 2021-08-02 | 2021-08-03 | 16d | eletricista; aux. eletricista | 35.2h | 766.33 | 15. Casa 15 | 1. Pav. Superior | 21 | 20. Elétrica1 | Própria | 21 |  |
| 1155 | 1.4.15.2.3 | 4.Inst. Gás | 2d | 2021-08-02 | 2021-08-03 | 16d | aux. bombeiro; bombeiro | 35.2h | 1,371.29 | 15. Casa 15 | 1. Pav. Superior | 22 | 21. HS1 | Própria | 22 |  |
| 1156 | 1.4.15.2.4 | 5.Inst. AF e AQ | 2d | 2021-08-02 | 2021-08-03 | 16d | aux. bombeiro; bombeiro | 35.2h | 2,426.07 | 15. Casa 15 | 1. Pav. Superior | 23 | 21. HS1 | Própria | 23 |  |
| 1157 | 1.4.15.2.5 | 6.Inst. Esgoto | 2d | 2021-08-02 | 2021-08-03 | 16d | aux. bombeiro; bombeiro | 35.2h | 1,546.11 | 15. Casa 15 | 1. Pav. Superior | 24 | 21. HS1 | Própria | 24 |  |
| 1158 | 1.4.15.2.6 | 7.Fiação | 4d | 2021-08-02 | 2021-08-05 | 14d | eletricista; aux. eletricista | 70.4h | 5,338.91 | 15. Casa 15 | 1. Pav. Superior | 25 | 20. Elétrica1 | Própria | 25 |  |
| 1159 | 1.4.15.2.7 | 8.Interr. Tom e luminárias | 1d | 2021-08-02 | 2021-08-02 | 17d | eletricista; aux. eletricista | 17.6h | 3,131.08 | 15. Casa 15 | 1. Pav. Superior | 26 | 20. Elétrica1 | Própria | 26 |  |
| 1160 | 1.4.15.2.8 | 9.Quadro elétrico | 2d | 2021-08-02 | 2021-08-03 | 16d | eletricista; aux. eletricista | 35.2h | 804.33 | 15. Casa 15 | 1. Pav. Superior | 27 | 20. Elétrica1 | Própria | 27 |  |
| 1161 | 1.4.15.2.9 | 10.Louças e Metais | 2d | 2021-08-02 | 2021-08-03 | 16d | aux. bombeiro; bombeiro | 35.2h | 3,486.91 | 15. Casa 15 | 1. Pav. Superior | 28 | 21. HS1 | Própria | 28 | 10 |
| 1162 | 1.4.15.3 | **2. Coberta** | 2d | 2021-08-02 | 2021-08-03 | 16d |  | 70.4h | 2,943.46 |  |  |  |  |  |  |  |
| 1163 | 1.4.15.3.1 | Barrilette | 2d | 2021-08-02 | 2021-08-03 | 16d | aux. bombeiro; bombeiro | 35.2h | 1,177.38 | 15. Casa 15 | 2. Coberta | 29 | 21. HS1 | Própria | 29 | 11 |
| 1164 | 1.4.15.3.2 | Caixa D'água | 2d | 2021-08-02 | 2021-08-03 | 16d | aux. bombeiro; bombeiro | 35.2h | 1,766.08 | 15. Casa 15 | 2. Coberta | 30 | 21. HS1 | Própria | 30 | 11 |

| ID | WBS | Task | Duration | Start | Finish | Total slack | Resources | Work | Cost | Casa | Pav | Pacote | Equipe | Empresa | LB | Cor |
| --- | --- | --- | --- | --- | --- | --- | --- | --- | --- | --- | --- | --- | --- | --- | --- | --- |
| 1165 | 1.4.16 | **16. Casa 16** | 4d | 2021-08-02 | 2021-08-05 | 14d |  | 774.4h | 72,049.62 |  |  |  |  |  |  |  |
| 1166 | 1.4.16.1 | **0. Térreo** | 4d | 2021-08-02 | 2021-08-05 | 14d |  | 369.6h | 47,239.83 |  |  |  |  |  |  |  |
| 1167 | 1.4.16.1.1 | 1.Inst. Embut. Em Fundações | 2d | 2021-08-02 | 2021-08-03 | 16d | bombeiro; eletricista | 35.2h | 1,554.25 | 16. Casa 16 | 0. Térreo | 19 | 19. Instalações1 | Própria | 19 |  |
| 1168 | 1.4.16.1.2 | 2.Inst. Elétricas Laje | 2d | 2021-08-02 | 2021-08-03 | 16d | eletricista; aux. eletricista | 35.2h | 6,661.65 | 16. Casa 16 | 0. Térreo | 20 | 20. Elétrica1 | Própria | 20 |  |
| 1169 | 1.4.16.1.3 | 3.Inst. Elétricas Paredes | 2d | 2021-08-02 | 2021-08-03 | 16d | eletricista; aux. eletricista | 35.2h | 1,704.34 | 16. Casa 16 | 0. Térreo | 21 | 21. HS1 | Própria | 21 |  |
| 1170 | 1.4.16.1.4 | 4.Inst. Gás | 2d | 2021-08-02 | 2021-08-03 | 16d | aux. bombeiro; bombeiro | 35.2h | 2,592.32 | 16. Casa 16 | 0. Térreo | 22 | 21. HS1 | Própria | 22 |  |
| 1171 | 1.4.16.1.5 | 5.Inst. AF e AQ | 2d | 2021-08-02 | 2021-08-03 | 16d | aux. bombeiro; bombeiro | 35.2h | 4,586.31 | 16. Casa 16 | 0. Térreo | 23 | 21. HS1 | Própria | 23 |  |
| 1172 | 1.4.16.1.6 | 6.Inst. Esgoto | 2d | 2021-08-02 | 2021-08-03 | 16d | aux. bombeiro; bombeiro | 35.2h | 2,922.8 | 16. Casa 16 | 0. Térreo | 24 | 21. HS1 | Própria | 24 |  |
| 1173 | 1.4.16.1.7 | 7.Fiação | 4d | 2021-08-02 | 2021-08-05 | 14d | eletricista; aux. eletricista | 70.4h | 11,873.92 | 16. Casa 16 | 0. Térreo | 25 | 20. Elétrica1 | Própria | 25 |  |
| 1174 | 1.4.16.1.8 | 8.Interr. Tom e luminárias | 1d | 2021-08-02 | 2021-08-02 | 17d | eletricista; aux. eletricista | 17.6h | 6,963.62 | 16. Casa 16 | 0. Térreo | 26 | 20. Elétrica1 | Própria | 26 |  |
| 1175 | 1.4.16.1.9 | 9.Quadro elétrico | 2d | 2021-08-02 | 2021-08-03 | 16d | eletricista; aux. eletricista | 35.2h | 1,788.87 | 16. Casa 16 | 0. Térreo | 27 | 20. Elétrica1 | Própria | 27 |  |
| 1176 | 1.4.16.1.10 | 10.Louças e Metais | 2d | 2021-08-02 | 2021-08-03 | 16d | aux. bombeiro; bombeiro | 35.2h | 6,591.75 | 16. Casa 16 | 0. Térreo | 28 | 21. HS1 | Própria | 28 | 10 |
| 1177 | 1.4.16.2 | **1. Pav. Superior** | 4d | 2021-08-02 | 2021-08-05 | 14d |  | 334.4h | 21,866.33 |  |  |  |  |  |  |  |
| 1178 | 1.4.16.2.1 | 2.Inst. Elétricas Laje | 2d | 2021-08-02 | 2021-08-03 | 16d | eletricista; aux. eletricista | 35.2h | 2,995.3 | 16. Casa 16 | 1. Pav. Superior | 20 | 20. Elétrica1 | Própria | 20 |  |
| 1179 | 1.4.16.2.2 | 3.Inst. Elétricas Paredes | 2d | 2021-08-02 | 2021-08-03 | 16d | eletricista; aux. eletricista | 35.2h | 766.33 | 16. Casa 16 | 1. Pav. Superior | 21 | 20. Elétrica1 | Própria | 21 |  |
| 1180 | 1.4.16.2.3 | 4.Inst. Gás | 2d | 2021-08-02 | 2021-08-03 | 16d | aux. bombeiro; bombeiro | 35.2h | 1,371.29 | 16. Casa 16 | 1. Pav. Superior | 22 | 21. HS1 | Própria | 22 |  |
| 1181 | 1.4.16.2.4 | 5.Inst. AF e AQ | 2d | 2021-08-02 | 2021-08-03 | 16d | aux. bombeiro; bombeiro | 35.2h | 2,426.07 | 16. Casa 16 | 1. Pav. Superior | 23 | 21. HS1 | Própria | 23 |  |
| 1182 | 1.4.16.2.5 | 6.Inst. Esgoto | 2d | 2021-08-02 | 2021-08-03 | 16d | aux. bombeiro; bombeiro | 35.2h | 1,546.11 | 16. Casa 16 | 1. Pav. Superior | 24 | 21. HS1 | Própria | 24 |  |
| 1183 | 1.4.16.2.6 | 7.Fiação | 4d | 2021-08-02 | 2021-08-05 | 14d | eletricista; aux. eletricista | 70.4h | 5,338.91 | 16. Casa 16 | 1. Pav. Superior | 25 | 20. Elétrica1 | Própria | 25 |  |
| 1184 | 1.4.16.2.7 | 8.Interr. Tom e luminárias | 1d | 2021-08-02 | 2021-08-02 | 17d | eletricista; aux. eletricista | 17.6h | 3,131.08 | 16. Casa 16 | 1. Pav. Superior | 26 | 20. Elétrica1 | Própria | 26 |  |
| 1185 | 1.4.16.2.8 | 9.Quadro elétrico | 2d | 2021-08-02 | 2021-08-03 | 16d | eletricista; aux. eletricista | 35.2h | 804.33 | 16. Casa 16 | 1. Pav. Superior | 27 | 20. Elétrica1 | Própria | 27 |  |
| 1186 | 1.4.16.2.9 | 10.Louças e Metais | 2d | 2021-08-02 | 2021-08-03 | 16d | aux. bombeiro; bombeiro | 35.2h | 3,486.91 | 16. Casa 16 | 1. Pav. Superior | 28 | 21. HS1 | Própria | 28 | 10 |
| 1187 | 1.4.16.3 | **2. Coberta** | 2d | 2021-08-02 | 2021-08-03 | 16d |  | 70.4h | 2,943.46 |  |  |  |  |  |  |  |
| 1188 | 1.4.16.3.1 | Barrilette | 2d | 2021-08-02 | 2021-08-03 | 16d | aux. bombeiro; bombeiro | 35.2h | 1,177.38 | 16. Casa 16 | 2. Coberta | 29 | 21. HS1 | Própria | 29 | 11 |
| 1189 | 1.4.16.3.2 | Caixa D'água | 2d | 2021-08-02 | 2021-08-03 | 16d | aux. bombeiro; bombeiro | 35.2h | 1,766.08 | 16. Casa 16 | 2. Coberta | 30 | 21. HS1 | Própria | 30 | 11 |
